# Consultation 4_FF_scHH6e

Schedule from MS Project, 2026-09-15 to 2028-11-27, status date 2026-03-03, 7 hours a day.
CHU de Clermont-Ferrand

## Calendars

- Standard: Mon-Fri 09:00-12:00, 14:00-18:00; Sat-Sun off. Exceptions (off unless hours are given): 2026-01-01 to 2030-01-01 (Jour de l'an, recurring), 2026-05-01 to 2030-05-01 (Fête du travail, recurring), 2026-05-08 to 2030-05-08 (Victoire 1945, recurring), 2026-07-14 to 2030-07-14 (Fête nationale, recurring), 2026-08-15 to 2030-08-15 (Assomption, recurring), 2026-11-01 to 2030-11-01 (Toussaint, recurring), 2026-11-11 to 2030-11-11 (Armistice 1918, recurring), 2026-12-25 to 2030-12-25 (Noël, recurring), 2027-03-29 (Pâques), 2027-05-06 (Ascension), 2027-05-17 (Pentecôte), 2028-04-17 (Pâques), 2028-05-25 (Ascension), 2028-06-05 (Pentecôte).

## Resources

| Resource |
| --- |
| Lot 01 : Courants forts |
| Lot 02 : Courants faibles |
| Lot 03 : Chauffage, climatisation, ventilation, plomberie |
| Lot 04 : Fluides de laboratoire |
| Lot 05 : Portes automatiques |
| Lot 06 : Paillasses, matériel de laboratoire |
| Lot 07 : Sols souples, protections murales |
| Lot 08 : Curage, démolitions, platrerie, peinture, faux-plafonds |
| Lot 09 : Menuiseries extérieures, cloisons vitrées, protections solaires |
| Lot 10 : Cloisons et plafonds agroalimentaires |
| Lot 11 : Installations de chantier |
| Déménagement interne |
| Déménagement externe |
| Service exploitation |
| Services techniques |
| Direction du laboratoire |
| Direction des Travaux, de l'Environnement et de la Sécurité |
| Prestataire entretien des locaux |

## Schedule

| ID | WBS | Task | Type | Duration | Start | Finish | Predecessors | Total slack | Free slack | Resources | Work |
| --- | --- | --- | --- | --- | --- | --- | --- | --- | --- | --- | --- |
| 1 | 1 | OS de démarrage | milestone, manual | 0d | 2026-09-30 | 2026-09-30 |  |  |  |  |  |
| 3 | 2 | **Préparation de chantier** |  | 55.5d | 2026-09-15 | 2026-12-02 |  | 0d |  |  | 4721.5h |
| 4 | 2.1 | Réunion de lancement |  | 0.5d | 2026-10-06 | 2026-10-06 | 1FS+4d | 0d |  | Lot 01 : Courants forts; Lot 02 : Courants faibles; Lot 03 : Chauffage, climatisation, ventilation, plomberie; Lot 04 : Fluides de laboratoire; Lot 05 : Portes automatiques; Lot 06 : Paillasses, matériel de laboratoire; Lot 07 : Sols souples, protections murales; Lot 08 : Curage, démolitions, platrerie, peinture, faux-plafonds; Lot 09 : Menuiseries extérieures, cloisons vitrées, protections solaires; Lot 10 : Cloisons et plafonds agroalimentaires; Lot 11 : Installations de chantier; Service exploitation; Services techniques; Direction des Travaux, de l'Environnement et de la Sécurité; Direction du laboratoire | 52.5h |
| 5 | 2.2 | Adapation planning |  | 15d | 2026-10-06 | 2026-10-27 | 4 | 25d |  | Lot 01 : Courants forts; Lot 02 : Courants faibles; Lot 03 : Chauffage, climatisation, ventilation, plomberie; Lot 04 : Fluides de laboratoire; Lot 05 : Portes automatiques; Lot 06 : Paillasses, matériel de laboratoire; Direction des Travaux, de l'Environnement et de la Sécurité; Direction du laboratoire; Lot 07 : Sols souples, protections murales; Lot 08 : Curage, démolitions, platrerie, peinture, faux-plafonds; Lot 09 : Menuiseries extérieures, cloisons vitrées, protections solaires; Lot 10 : Cloisons et plafonds agroalimentaires; Lot 11 : Installations de chantier | 1365h |
| 6 | 2.3 | Production des plans EXE |  | 15d | 2026-10-06 | 2026-10-27 | 4 | 0d |  | Lot 01 : Courants forts; Lot 02 : Courants faibles; Lot 03 : Chauffage, climatisation, ventilation, plomberie; Lot 04 : Fluides de laboratoire; Lot 05 : Portes automatiques; Lot 06 : Paillasses, matériel de laboratoire; Direction des Travaux, de l'Environnement et de la Sécurité; Direction du laboratoire; Lot 07 : Sols souples, protections murales; Lot 08 : Curage, démolitions, platrerie, peinture, faux-plafonds; Lot 09 : Menuiseries extérieures, cloisons vitrées, protections solaires; Lot 10 : Cloisons et plafonds agroalimentaires; Lot 11 : Installations de chantier | 1365h |
| 7 | 2.4 | VISA SP5 phase 1et2, SP6 rdc et 4e étage phase 1 et 6e étage, SP9 Phase 1.1 |  | 5d | 2026-10-27 | 2026-11-03 | 6 | 0d |  | Direction des Travaux, de l'Environnement et de la Sécurité | 35h |
| 8 | 2.5 | Synthèses SP5 phase 1et2, SP6 rdc et 4e étage phase 1 et 6e étage, SP9 Phase 1.1 |  | 20d | 2026-11-03 | 2026-12-02 | 7 | 0d |  | Lot 01 : Courants forts; Lot 02 : Courants faibles; Lot 03 : Chauffage, climatisation, ventilation, plomberie; Lot 04 : Fluides de laboratoire; Lot 05 : Portes automatiques; Lot 06 : Paillasses, matériel de laboratoire; Direction des Travaux, de l'Environnement et de la Sécurité; Direction du laboratoire; Lot 07 : Sols souples, protections murales; Lot 08 : Curage, démolitions, platrerie, peinture, faux-plafonds; Lot 09 : Menuiseries extérieures, cloisons vitrées, protections solaires; Lot 10 : Cloisons et plafonds agroalimentaires | 1680h |
| 9 | 2.6 | VISA suite |  | 1d | 2026-09-15 | 2026-09-15 |  | 54.5d |  |  |  |
| 10 | 2.7 | Synthèses suite |  | 1d | 2026-09-15 | 2026-09-15 |  | 54.5d |  |  |  |
| 11 | 2.8 | Modification entrée laboratoire / Interphonne |  | 3d | 2026-11-04 | 2026-11-06 | 1FS+25d | 2.5d | 0d | Lot 02 : Courants faibles | 21h |
| 12 | 2.9 | Installation base vie et sécurisation zone |  | 5d | 2026-11-09 | 2026-11-16 | 11 | 2.5d | 0d | Lot 11 : Installations de chantier; Lot 01 : Courants forts; Lot 02 : Courants faibles | 105h |
| 13 | 2.10 | Dépose des brises soleil |  | 2d | 2026-11-17 | 2026-11-18 | 12 | 2.5d | 0d | Lot 09 : Menuiseries extérieures, cloisons vitrées, protections solaires | 14h |
| 14 | 2.11 | Installation échaffaudage et lift |  | 5d | 2026-11-19 | 2026-11-25 | 13 | 2.5d | 0d | Lot 11 : Installations de chantier; Lot 02 : Courants faibles | 70h |
| 15 | 2.12 | Remplacement des menuiseries pour accès extérieur |  | 2d | 2026-11-26 | 2026-11-27 | 14 | 2.5d | 0d | Lot 09 : Menuiseries extérieures, cloisons vitrées, protections solaires | 14h |
| 17 | 3 | **Opérations préalables communes** |  | 8d | 2026-11-30 | 2026-12-09 |  | 466.5d | 0d |  | 91h |
| 18 | 3.1 | Dépose des faux-plafond des circulations |  | 5d | 2026-11-30 | 2026-12-04 | 15 | 466.5d | 0d | Lot 08 : Curage, démolitions, platrerie, peinture, faux-plafonds | 35h |
| 19 | 3.2 | Installation éclairage de chantier |  | 5d | 2026-12-01 | 2026-12-07 | 15FS+1d | 468.5d |  | Lot 01 : Courants forts | 35h |
| 20 | 3.3 | Création des ouvertures pour passage des réseaux |  | 3d | 2026-12-07 | 2026-12-09 | 18 | 466.5d |  | Lot 08 : Curage, démolitions, platrerie, peinture, faux-plafonds | 21h |
| 22 | 4 | **Installation de la centrale à CO2** |  | 30d | 2026-12-10 | 2027-01-22 |  | 466.5d |  |  | 210h |
| 23 | 4.1 | Dépose des faux-plafond des circulations |  | 30d | 2026-12-10 | 2027-01-22 | 17 | 466.5d |  | Lot 04 : Fluides de laboratoire | 210h |
| 25 | 5 | **SP5 : 5ème étage** |  | 190.5d | 2026-12-02 | 2027-09-02 |  | 311.5d |  |  | 4389h |
| 26 | 5.1 | **SP05 - Phase 1** |  | 38.5d | 2026-12-02 | 2027-01-27 |  | 311.5d |  |  | 899.5h |
| 27 | 5.1.1 | **Phase 1.1** |  | 8.5d | 2026-12-02 | 2026-12-14 |  | 490.5d |  |  | 108.5h |
| 28 | 5.1.1.1 | **Pièce 11101-15_0015** |  | 8.5d | 2026-12-02 | 2026-12-14 |  | 490.5d | 0d |  | 108.5h |
| 29 | 5.1.1.1.1 | 15_0015 Dégager l'espace en travaux dans la pièce |  | 1d | 2026-12-02 | 2026-12-03 | 3 | 490.5d | 0d | Déménagement externe; Déménagement interne; Direction du laboratoire | 21h |
| 30 | 5.1.1.1.2 | Neutralisation réseaux (consignations) |  | 0.5d | 2026-12-03 | 2026-12-03 | 29 | 490.5d | 0d | Services techniques | 3.5h |
| 31 | 5.1.1.1.3 | Mise en place protection de zone en chantier |  | 0.5d | 2026-12-04 | 2026-12-04 | 30 | 490.5d | 0d | Lot 08 : Curage, démolitions, platrerie, peinture, faux-plafonds | 3.5h |
| 32 | 5.1.1.1.4 | Création de cloison modulaire |  | 2d | 2026-12-04 | 2026-12-08 | 31 | 491.5d | 1d | Lot 10 : Cloisons et plafonds agroalimentaires | 14h |
| 33 | 5.1.1.1.5 | Réseaux neufs CFO |  | 1d | 2026-12-04 | 2026-12-07 | 31 | 492.5d | 2d | Lot 01 : Courants forts | 7h |
| 34 | 5.1.1.1.6 | Réseaux neufs CFA |  | 1d | 2026-12-04 | 2026-12-07 | 31 | 492.5d | 2d | Lot 02 : Courants faibles | 7h |
| 35 | 5.1.1.1.7 | Réseaux neufs CVC |  | 3d | 2026-12-04 | 2026-12-09 | 31 | 490.5d | 0d | Lot 03 : Chauffage, climatisation, ventilation, plomberie | 21h |
| 36 | 5.1.1.1.8 | Finitions murales |  | 2d | 2026-12-09 | 2026-12-11 | 32, 33, 34, 35 | 490.5d | 0d | Lot 07 : Sols souples, protections murales | 14h |
| 37 | 5.1.1.1.9 | Pose équipement CFO |  | 0.5d | 2026-12-11 | 2026-12-11 | 36 | 490.5d | 0d | Lot 01 : Courants forts | 3.5h |
| 38 | 5.1.1.1.10 | Pose équipements CVC |  | 0.5d | 2026-12-11 | 2026-12-11 | 36 | 490.5d | 0d | Lot 03 : Chauffage, climatisation, ventilation, plomberie | 3.5h |
| 39 | 5.1.1.1.11 | Pose équipements CFA |  | 0.5d | 2026-12-11 | 2026-12-11 | 36 | 490.5d | 0d | Lot 02 : Courants faibles | 3.5h |
| 40 | 5.1.1.1.12 | Installation paillasses |  | 1d | 2026-12-14 | 2026-12-14 | 37, 38, 39 | 490.5d |  | Lot 06 : Paillasses, matériel de laboratoire | 7h |
| 41 | 5.1.2 | Réception phase 1.1 |  | 1d | 2026-12-15 | 2026-12-15 | 28 | 490.5d | 0d | Lot 01 : Courants forts; Lot 02 : Courants faibles; Lot 03 : Chauffage, climatisation, ventilation, plomberie; Lot 06 : Paillasses, matériel de laboratoire; Lot 07 : Sols souples, protections murales; Lot 08 : Curage, démolitions, platrerie, peinture, faux-plafonds; Lot 09 : Menuiseries extérieures, cloisons vitrées, protections solaires; Lot 10 : Cloisons et plafonds agroalimentaires; Direction des Travaux, de l'Environnement et de la Sécurité; Direction du laboratoire | 70h |
| 42 | 5.1.3 | Nettoyage avant installation installation (11101-15_0001 / 32) |  | 1d | 2026-12-16 | 2026-12-16 | 41 | 490.5d | 0d | Prestataire entretien des locaux | 7h |
| 43 | 5.1.4 | 15_0015 Aménagement micro fluo |  | 1d | 2026-12-17 | 2026-12-17 | 42 | 490.5d |  | Déménagement interne; Déménagement externe; Direction du laboratoire | 21h |

Notes:
- 28: Voir les besoins CVC et CFO. Durée 1 à 2h par jour d'utilisation

| ID | WBS | Task | Duration | Start | Finish | Predecessors | Total slack | Free slack | Resources | Work |
| --- | --- | --- | --- | --- | --- | --- | --- | --- | --- | --- |
| 44 | 5.1.5 | **Phase 1.2** | 1d | 2026-12-02 | 2026-12-03 |  | 352d | 0d |  | 42h |
| 45 | 5.1.5.1 | 11101-15_0013 et 14 vers 11101-16_0007 | 1d | 2026-12-02 | 2026-12-03 | 3, 694 | 352d |  | Déménagement externe; Déménagement interne; Direction du laboratoire | 21h |
| 46 | 5.1.5.2 | 11101-15_0012 vers 11101-15_00 | 1d | 2026-12-02 | 2026-12-03 | 3 | 352d |  | Déménagement externe; Déménagement interne; Direction du laboratoire | 21h |
| 47 | 5.1.6 | **Phase 1.3** | 30.5d | 2026-12-02 | 2027-01-15 |  | 311.5d | 0d |  | 416.5h |
| 48 | 5.1.6.1 | **Pièce 11103-15_0010 et 11** | 30.5d | 2026-12-02 | 2027-01-15 |  | 311.5d |  |  | 416.5h |
| 49 | 5.1.6.1.1 | 03-15_0010 Vider pièce | 1d | 2026-12-02 | 2026-12-03 | 3 | 311.5d | 0d | Déménagement externe; Déménagement interne; Direction du laboratoire | 21h |
| 50 | 5.1.6.1.2 | Consignation | 0.5d | 2026-12-03 | 2026-12-03 | 49 | 311.5d | 0d | Services techniques | 3.5h |
| 51 | 5.1.6.1.3 | Dépose équipements CFO | 2d | 2026-12-04 | 2026-12-07 | 50 | 311.5d | 0d | Lot 01 : Courants forts | 14h |
| 52 | 5.1.6.1.4 | Dépose faux-plafond, curage sol et dépose cloison | 5d | 2026-12-08 | 2026-12-14 | 51 | 311.5d | 0d | Lot 08 : Curage, démolitions, platrerie, peinture, faux-plafonds | 35h |
| 53 | 5.1.6.1.5 | Pose nouveaux réseaux CFO | 5d | 2026-12-15 | 2026-12-21 | 52 | 311.5d | 0d | Lot 01 : Courants forts | 35h |
| 54 | 5.1.6.1.6 | Pose nouveaux réseaux CFA | 5d | 2026-12-15 | 2026-12-21 | 52 | 311.5d | 0d | Lot 02 : Courants faibles | 35h |
| 55 | 5.1.6.1.7 | Dépose radiateurs, déplacement réseau radiateur | 5d | 2026-12-22 | 2026-12-29 | 53, 54 | 311.5d | 0d | Lot 03 : Chauffage, climatisation, ventilation, plomberie | 35h |
| 56 | 5.1.6.1.8 | Pose faux plafonds neuf | 5d | 2026-12-30 | 2027-01-06 | 55 | 311.5d | 0d | Lot 08 : Curage, démolitions, platrerie, peinture, faux-plafonds | 35h |
| 57 | 5.1.6.1.9 | Pose équipements CFO | 5d | 2026-12-24 | 2026-12-31 | 55SS+2d | 314.5d | 3d | Lot 01 : Courants forts | 35h |
| 58 | 5.1.6.1.10 | Pose équipements CFA | 5d | 2026-12-24 | 2026-12-31 | 55SS+2d | 314.5d | 3d | Lot 02 : Courants faibles | 35h |
| 59 | 5.1.6.1.11 | Peinture radiateurs | 5d | 2026-12-29 | 2027-01-05 | 55SS+4d | 312.5d | 1d | Lot 08 : Curage, démolitions, platrerie, peinture, faux-plafonds | 35h |
| 60 | 5.1.6.1.12 | Finitions murales | 5d | 2026-12-29 | 2027-01-05 | 55SS+4d | 312.5d | 1d | Lot 08 : Curage, démolitions, platrerie, peinture, faux-plafonds | 35h |
| 61 | 5.1.6.1.13 | Pose stores | 2d | 2027-01-07 | 2027-01-08 | 56, 57, 58, 59, 60 | 311.5d | 0d | Lot 09 : Menuiseries extérieures, cloisons vitrées, protections solaires | 14h |
| 62 | 5.1.6.1.14 | Repose radiateurs | 2d | 2027-01-07 | 2027-01-08 | 56, 57, 58, 59, 60 | 311.5d | 0d | Lot 03 : Chauffage, climatisation, ventilation, plomberie | 14h |
| 63 | 5.1.6.1.15 | Pose sol | 5d | 2027-01-11 | 2027-01-15 | 61, 62 | 311.5d |  | Lot 07 : Sols souples, protections murales | 35h |
| 64 | 5.1.7 | Réception phase 1.3 | 1d | 2027-01-18 | 2027-01-18 | 47 | 311.5d | 0d | Lot 01 : Courants forts; Lot 02 : Courants faibles; Lot 03 : Chauffage, climatisation, ventilation, plomberie; Lot 07 : Sols souples, protections murales; Lot 08 : Curage, démolitions, platrerie, peinture, faux-plafonds; Lot 09 : Menuiseries extérieures, cloisons vitrées, protections solaires; Direction des Travaux, de l'Environnement et de la Sécurité; Direction du laboratoire | 56h |
| 65 | 5.1.8 | **Phase 1.4** | 2d | 2027-01-19 | 2027-01-20 |  | 311.5d | 0d |  | 28h |
| 66 | 5.1.8.1 | Nettoyage avant installation installation (11103-15_00010 / 11) | 1d | 2027-01-19 | 2027-01-19 | 64 | 311.5d | 0d | Prestataire entretien des locaux | 7h |
| 67 | 5.1.8.2 | Déménagement 11101-15_0001, 32 vers 11103-15_0011 | 0.67d | 2027-01-20 | 2027-01-20 | 66 | 311.83d |  | Déménagement externe; Déménagement interne; Direction du laboratoire | 14h |
| 68 | 5.1.8.3 | 03-15_0011 Aménagement étagères | 1d | 2027-01-20 | 2027-01-20 | 66 | 311.5d |  | Déménagement interne | 7h |

| ID | WBS | Task | Duration | Start | Finish | Predecessors | Total slack | Free slack | Resources | Work |
| --- | --- | --- | --- | --- | --- | --- | --- | --- | --- | --- |
| 69 | 5.1.9 | **Phase 1.5** | 2.5d | 2027-01-21 | 2027-01-25 |  | 311.5d | 0d |  | 45.5h |
| 70 | 5.1.9.1 | **Pièce 11101-15_0032 et 01** | 2.5d | 2027-01-21 | 2027-01-25 |  | 311.5d |  |  | 45.5h |
| 71 | 5.1.9.1.1 | Neutralisation réseaux (consignations) | 0.5d | 2027-01-21 | 2027-01-21 | 65 | 311.5d | 0d | Services techniques | 3.5h |
| 72 | 5.1.9.1.2 | Réseaux neufs et pose équipements CFO | 2d | 2027-01-21 | 2027-01-25 | 71 | 311.5d |  | Lot 01 : Courants forts | 14h |
| 73 | 5.1.9.1.3 | Réseaux neufs et pose équipements CFA | 2d | 2027-01-21 | 2027-01-25 | 71 | 311.5d |  | Lot 02 : Courants faibles | 14h |
| 74 | 5.1.9.1.4 | Réseaux neufs CVC, plomberie et pose équipements | 2d | 2027-01-21 | 2027-01-25 | 71 | 311.5d |  | Lot 03 : Chauffage, climatisation, ventilation, plomberie | 14h |
| 75 | 5.1.10 | Réception sous phase 1.5 | 0.5d | 2027-01-25 | 2027-01-25 | 69 | 311.5d | 0d | Lot 01 : Courants forts; Lot 02 : Courants faibles; Lot 03 : Chauffage, climatisation, ventilation, plomberie; Lot 06 : Paillasses, matériel de laboratoire; Lot 07 : Sols souples, protections murales; Lot 08 : Curage, démolitions, platrerie, peinture, faux-plafonds; Lot 09 : Menuiseries extérieures, cloisons vitrées, protections solaires; Lot 10 : Cloisons et plafonds agroalimentaires; Direction des Travaux, de l'Environnement et de la Sécurité; Direction du laboratoire | 35h |
| 76 | 5.1.11 | **Phase 1.6 Déménagements transitoires fin de phase 1.5** | 2d | 2027-01-26 | 2027-01-27 |  | 311.5d | 0d |  | 70h |
| 77 | 5.1.11.1 | Nettoyage avant installation installation (11101-15_0001 / 32) | 1d | 2027-01-26 | 2027-01-26 | 75 | 311.5d | 0d | Prestataire entretien des locaux | 7h |
| 78 | 5.1.11.2 | 11101-15_0033 vers 11101-15_00 | 1d | 2027-01-27 | 2027-01-27 | 77 | 311.5d |  | Déménagement externe; Déménagement interne; Direction du laboratoire | 21h |
| 79 | 5.1.11.3 | 11101-15_0034 vers 11101-15_0001 (EasyMag) | 1d | 2027-01-27 | 2027-01-27 | 77 | 311.5d |  | Déménagement externe; Déménagement interne; Direction du laboratoire | 21h |
| 80 | 5.1.11.4 | Déménagement 11101-15_0035; 36 vers 11101-15_0032 | 1d | 2027-01-27 | 2027-01-27 | 77 | 311.5d |  | Déménagement externe; Déménagement interne; Direction du laboratoire | 21h |
| 81 | 5.2 | **SP05 - Phase 2** | 76d | 2026-12-03 | 2027-03-23 |  | 349d |  |  | 1855h |
| 82 | 5.2.1 | **Phase 2.1** | 32.5d | 2026-12-03 | 2027-01-20 |  | 352d |  |  | 507.5h |
| 83 | 5.2.1.1 | **Pièces 11101-15_0012, 13 et 14** | 32.5d | 2026-12-03 | 2027-01-20 |  | 352d | 0d |  | 507.5h |
| 84 | 5.2.1.1.1 | Neutralisation réseaux (consignations) | 0.5d | 2026-12-03 | 2026-12-03 | 44 | 352d | 0d | Services techniques | 3.5h |
| 85 | 5.2.1.1.2 | Déconnexion paillasse plomberie, dépose équipements de plomberie et CVC | 2d | 2026-12-04 | 2026-12-07 | 84 | 352d | 0d | Lot 03 : Chauffage, climatisation, ventilation, plomberie | 14h |
| 86 | 5.2.1.1.3 | Déconnexion paillasse CFO, sorbonne et luminaires | 2d | 2026-12-04 | 2026-12-07 | 84 | 352d | 0d | Lot 01 : Courants forts | 14h |
| 87 | 5.2.1.1.4 | Déconnexion paillasse, sorbonne et CFA | 2d | 2026-12-04 | 2026-12-07 | 84 | 352d | 0d | Lot 02 : Courants faibles | 14h |
| 88 | 5.2.1.1.5 | Renfort plafonds | 2d | 2026-12-04 | 2026-12-07 | 84 | 354d | 2d | Lot 10 : Cloisons et plafonds agroalimentaires | 14h |
| 89 | 5.2.1.1.6 | Enlèvement paillasse | 2d | 2026-12-08 | 2026-12-09 | 85, 86, 87 | 352d | 0d | Lot 08 : Curage, démolitions, platrerie, peinture, faux-plafonds | 14h |
| 90 | 5.2.1.1.7 | Curage FP, Sol, dépose cloisons | 3d | 2026-12-10 | 2026-12-14 | 88, 89 | 352d | 0d | Lot 08 : Curage, démolitions, platrerie, peinture, faux-plafonds | 21h |
| 91 | 5.2.1.1.8 | Réseaux neufs CFO | 10d | 2026-12-15 | 2026-12-29 | 90 | 352d | 0d | Lot 01 : Courants forts | 70h |
| 92 | 5.2.1.1.9 | Réseaux neufs CFA | 10d | 2026-12-15 | 2026-12-29 | 90 | 352d | 0d | Lot 02 : Courants faibles | 70h |
| 93 | 5.2.1.1.10 | Réseaux neufs CVC, plomberie | 10d | 2026-12-15 | 2026-12-29 | 90 | 352d | 0d | Lot 03 : Chauffage, climatisation, ventilation, plomberie | 70h |
| 94 | 5.2.1.1.11 | Création de cloison | 10d | 2026-12-15 | 2026-12-29 | 90 | 352d | 0d | Lot 10 : Cloisons et plafonds agroalimentaires | 70h |
| 95 | 5.2.1.1.12 | Pose plafonds agro | 3d | 2026-12-30 | 2027-01-04 | 94, 91, 92, 93 | 352d | 0d | Lot 10 : Cloisons et plafonds agroalimentaires | 21h |
| 96 | 5.2.1.1.13 | Finitions murales | 2d | 2027-01-05 | 2027-01-06 | 95 | 352d | 0d | Lot 07 : Sols souples, protections murales | 14h |
| 97 | 5.2.1.1.14 | Pose équipement CFO | 2d | 2027-01-07 | 2027-01-08 | 96 | 352d | 0d | Lot 01 : Courants forts | 14h |
| 98 | 5.2.1.1.15 | Pose équipements CVC | 2d | 2027-01-07 | 2027-01-08 | 96 | 352d | 0d | Lot 03 : Chauffage, climatisation, ventilation, plomberie | 14h |
| 99 | 5.2.1.1.16 | Pose équipements CFA | 2d | 2027-01-07 | 2027-01-08 | 96 | 352d | 0d | Lot 02 : Courants faibles | 14h |
| 100 | 5.2.1.1.17 | Pose sol | 3d | 2027-01-11 | 2027-01-13 | 97, 98, 99 | 352d | 0d | Lot 07 : Sols souples, protections murales | 21h |
| 101 | 5.2.1.1.18 | Installation paillasses et Sorbonnes | 5d | 2027-01-14 | 2027-01-20 | 100 | 352d |  | Lot 06 : Paillasses, matériel de laboratoire | 35h |
| 102 | 5.2.2 | Réception phase 2.1 | 1d | 2027-01-21 | 2027-01-21 | 83 | 352d | 0d | Lot 01 : Courants forts; Lot 02 : Courants faibles; Lot 03 : Chauffage, climatisation, ventilation, plomberie; Lot 06 : Paillasses, matériel de laboratoire; Lot 07 : Sols souples, protections murales; Lot 08 : Curage, démolitions, platrerie, peinture, faux-plafonds; Lot 10 : Cloisons et plafonds agroalimentaires; Direction des Travaux, de l'Environnement et de la Sécurité; Direction du laboratoire | 63h |

Notes:
- 83: Acitivité envisagée au 6e pendant les travaux. La DL doit voir s'il y a des besoins pour l'activité temporaire. / Voir si ventilation des sorbonnes peut absober le flux de l'armoire ventlée / A chainer avec la 6B06 pour permettre l'activité transitoire

| ID | WBS | Task | Duration | Start | Finish | Predecessors | Total slack | Free slack | Resources | Work |
| --- | --- | --- | --- | --- | --- | --- | --- | --- | --- | --- |
| 103 | 5.2.3 | **Emménagements** | 2d | 2027-01-22 | 2027-01-25 |  | 352d |  |  | 49h |
| 104 | 5.2.3.1 | Nettoyage avant installation installation (11101-15_0013) | 1d | 2027-01-22 | 2027-01-22 | 102 | 352d | 0d | Prestataire entretien des locaux | 7h |
| 105 | 5.2.3.2 | 11101-15_0031 vers 13 | 1d | 2027-01-25 | 2027-01-25 | 104 | 352d | 40.5d | Déménagement externe; Déménagement interne; Direction du laboratoire | 21h |
| 106 | 5.2.3.3 | 11101-16_0007 vers 11101-15_13 | 1d | 2027-01-25 | 2027-01-25 | 104 | 419d | 0d | Déménagement externe; Déménagement interne; Direction du laboratoire | 21h |
| 107 | 5.2.4 | **Phase 2.2** | 8d | 2027-01-28 | 2027-02-08 |  | 453.5d |  |  | 150.5h |
| 108 | 5.2.4.1 | **Pièce 11101-15_0003 et 06** | 8d | 2027-01-28 | 2027-02-08 |  | 453.5d | 0d |  | 150.5h |
| 109 | 5.2.4.1.1 | Neutralisation réseaux (consignations) | 0.5d | 2027-01-28 | 2027-01-28 | 76 | 454d | 0.5d | Services techniques | 3.5h |
| 110 | 5.2.4.1.2 | Neutralisation lave-mains | 1d | 2027-01-28 | 2027-01-28 | 76 | 453.5d | 0d | Lot 03 : Chauffage, climatisation, ventilation, plomberie | 7h |
| 111 | 5.2.4.1.3 | Réseaux neufs CFO | 3d | 2027-01-29 | 2027-02-02 | 109, 110 | 453.5d | 0d | Lot 01 : Courants forts | 21h |
| 112 | 5.2.4.1.4 | Réseaux neufs CFA | 3d | 2027-01-29 | 2027-02-02 | 109, 110 | 453.5d | 0d | Lot 02 : Courants faibles | 21h |
| 113 | 5.2.4.1.5 | Réseaux neufs CVC, plomberie | 3d | 2027-01-29 | 2027-02-02 | 109, 110 | 453.5d | 0d | Lot 03 : Chauffage, climatisation, ventilation, plomberie | 21h |
| 114 | 5.2.4.1.6 | Pose équipement CFO | 2d | 2027-02-03 | 2027-02-04 | 111, 112, 113 | 453.5d | 0d | Lot 01 : Courants forts | 14h |
| 115 | 5.2.4.1.7 | Pose équipements CVC | 2d | 2027-02-03 | 2027-02-04 | 111, 112, 113 | 453.5d | 0d | Lot 03 : Chauffage, climatisation, ventilation, plomberie | 14h |
| 116 | 5.2.4.1.8 | Pose équipements CFA | 2d | 2027-02-03 | 2027-02-04 | 111, 112, 113 | 453.5d | 0d | Lot 02 : Courants faibles | 14h |
| 117 | 5.2.4.1.9 | Remplacement portes dans local 11101-15_0003 | 2d | 2027-02-03 | 2027-02-04 | 111, 112, 113 | 453.5d | 0d | Lot 10 : Cloisons et plafonds agroalimentaires | 14h |
| 118 | 5.2.4.1.10 | Mise en place interlockage | 1d | 2027-02-05 | 2027-02-05 | 117 | 454.5d |  | Lot 02 : Courants faibles | 7h |
| 119 | 5.2.4.1.11 | Installation paillasses | 2d | 2027-02-05 | 2027-02-08 | 114, 115, 116, 117 | 453.5d |  | Lot 06 : Paillasses, matériel de laboratoire | 14h |
| 120 | 5.2.5 | Réception phase 2.2 | 1d | 2027-02-09 | 2027-02-09 | 108 | 453.5d | 0d |  |  |
| 121 | 5.2.6 | **Emménagements** | 1d | 2027-02-10 | 2027-02-10 |  | 453.5d |  |  | 14h |
| 122 | 5.2.6.1 | Nettoyage avant installation installation (11101-15_0006) | 1d | 2027-02-10 | 2027-02-10 | 120 | 453.5d |  | Prestataire entretien des locaux | 7h |
| 123 | 5.2.6.2 | 15_0006 Eménagement pièce | 1d | 2027-02-10 | 2027-02-10 | 120 | 453.5d |  | Déménagement interne | 7h |
| 124 | 5.2.7 | **Phase 2.3** | 34.5d | 2027-01-28 | 2027-03-17 |  | 311.5d | 0d |  | 980h |
| 125 | 5.2.7.1 | **Création niche couloir central (côté monte charge)** | 2d | 2027-01-28 | 2027-01-29 |  | 344d |  |  | 14h |
| 126 | 5.2.7.1.1 | Percement de l'espace de stockage | 2d | 2027-01-28 | 2027-01-29 | 76 | 344d |  | Lot 08 : Curage, démolitions, platrerie, peinture, faux-plafonds | 14h |

Notes:
- 125: Vérifier la faisabilité de réaliser cet espace de stockage

| ID | WBS | Task | Duration | Start | Finish | Predecessors | Total slack | Free slack | Resources | Work |
| --- | --- | --- | --- | --- | --- | --- | --- | --- | --- | --- |
| 127 | 5.2.7.2 | **Pièces 11101-15_ 35 et 36** | 34.5d | 2027-01-28 | 2027-03-17 |  | 311.5d |  |  | 451.5h |
| 128 | 5.2.7.2.1 | Neutralisation réseaux (consignations) | 0.5d | 2027-01-28 | 2027-01-28 | 76 | 311.5d | 0d | Services techniques | 3.5h |
| 129 | 5.2.7.2.2 | Mise en place cloisonnement provisoire | 1d | 2027-01-28 | 2027-01-29 | 128 | 344.5d |  | Lot 08 : Curage, démolitions, platrerie, peinture, faux-plafonds | 7h |
| 130 | 5.2.7.2.3 | Déconnexion paillasse plomberie, dépose équipements de plomberie et CVC | 2d | 2027-01-28 | 2027-02-01 | 128 | 311.5d | 0d | Lot 03 : Chauffage, climatisation, ventilation, plomberie | 14h |
| 131 | 5.2.7.2.4 | Déconnexion paillasse CFO et luminaires | 2d | 2027-01-28 | 2027-02-01 | 128 | 311.5d | 0d | Lot 01 : Courants forts | 14h |
| 132 | 5.2.7.2.5 | Déconnexion paillasse CFA | 2d | 2027-01-28 | 2027-02-01 | 128 | 311.5d | 0d | Lot 02 : Courants faibles | 14h |
| 133 | 5.2.7.2.6 | Renfort plafonds | 2d | 2027-01-28 | 2027-02-01 | 128 | 313.5d | 2d | Lot 10 : Cloisons et plafonds agroalimentaires | 14h |
| 134 | 5.2.7.2.7 | Enlèvement paillasse | 2d | 2027-02-01 | 2027-02-03 | 130, 131, 132 | 311.5d | 0d | Lot 08 : Curage, démolitions, platrerie, peinture, faux-plafonds | 14h |
| 135 | 5.2.7.2.8 | Curage FP, Sol, dépose cloisons | 3d | 2027-02-03 | 2027-02-08 | 133, 134 | 311.5d | 0d | Lot 08 : Curage, démolitions, platrerie, peinture, faux-plafonds | 21h |
| 136 | 5.2.7.2.9 | Création de cloison et étoupements | 3d | 2027-02-08 | 2027-02-11 | 135 | 311.5d | 0d | Lot 08 : Curage, démolitions, platrerie, peinture, faux-plafonds | 21h |
| 137 | 5.2.7.2.10 | Pose cloison vitrée | 1d | 2027-02-08 | 2027-02-09 | 135 | 337.5d |  | Lot 09 : Menuiseries extérieures, cloisons vitrées, protections solaires | 7h |
| 138 | 5.2.7.2.11 | Réseaux neufs CFO | 10d | 2027-02-15 | 2027-03-01 | 136FS+2d | 311.5d | 0d | Lot 01 : Courants forts | 70h |
| 139 | 5.2.7.2.12 | Réseaux neufs CFA | 10d | 2027-02-15 | 2027-03-01 | 136FS+2d | 311.5d | 0d | Lot 02 : Courants faibles | 70h |
| 140 | 5.2.7.2.13 | Réseaux neufs CVC, plomberie | 10d | 2027-02-15 | 2027-03-01 | 136FS+2d | 311.5d | 0d | Lot 03 : Chauffage, climatisation, ventilation, plomberie | 70h |
| 141 | 5.2.7.2.14 | Pose faux plafonds | 3d | 2027-03-01 | 2027-03-04 | 138, 139, 140 | 311.5d | 0d | Lot 08 : Curage, démolitions, platrerie, peinture, faux-plafonds | 21h |
| 142 | 5.2.7.2.15 | Finitions murales | 2d | 2027-03-04 | 2027-03-08 | 141 | 311.5d | 0d | Lot 07 : Sols souples, protections murales | 14h |
| 143 | 5.2.7.2.16 | Pose équipement CFO | 2d | 2027-03-08 | 2027-03-10 | 142 | 311.5d | 0d | Lot 01 : Courants forts | 14h |
| 144 | 5.2.7.2.17 | Pose équipements CVC | 2d | 2027-03-08 | 2027-03-10 | 142 | 311.5d | 0d | Lot 03 : Chauffage, climatisation, ventilation, plomberie | 14h |
| 145 | 5.2.7.2.18 | Pose équipements CFA | 2d | 2027-03-08 | 2027-03-10 | 142 | 311.5d | 0d | Lot 02 : Courants faibles | 14h |
| 146 | 5.2.7.2.19 | Pose sol | 3d | 2027-03-10 | 2027-03-15 | 143, 144, 145 | 311.5d | 0d | Lot 07 : Sols souples, protections murales | 21h |
| 147 | 5.2.7.2.20 | Installation paillasses | 2d | 2027-03-15 | 2027-03-17 | 146 | 311.5d |  | Lot 06 : Paillasses, matériel de laboratoire | 14h |
| 148 | 5.2.7.3 | **Pièces 11101-15_33 et 34** | 34.5d | 2027-01-28 | 2027-03-17 |  | 311.5d |  |  | 472.5h |
| 149 | 5.2.7.3.1 | Neutralisation réseaux (consignations) | 0.5d | 2027-01-28 | 2027-01-28 | 76 | 311.5d | 0d | Services techniques | 3.5h |
| 150 | 5.2.7.3.2 | Déconnexion paillasse plomberie, dépose équipements de plomberie et CVC | 2d | 2027-01-28 | 2027-02-01 | 149 | 311.5d | 0d | Lot 03 : Chauffage, climatisation, ventilation, plomberie | 14h |
| 151 | 5.2.7.3.3 | Déconnexion paillasse CFO et luminaires | 2d | 2027-01-28 | 2027-02-01 | 149 | 311.5d | 0d | Lot 01 : Courants forts | 14h |
| 152 | 5.2.7.3.4 | Déconnexion paillasse CFA | 2d | 2027-01-28 | 2027-02-01 | 149 | 311.5d | 0d | Lot 02 : Courants faibles | 14h |
| 153 | 5.2.7.3.5 | Démontage Sorbonne | 5d | 2027-01-28 | 2027-02-04 | 149 | 340.5d |  | Lot 06 : Paillasses, matériel de laboratoire | 35h |
| 154 | 5.2.7.3.6 | Renfort plafonds | 2d | 2027-01-28 | 2027-02-01 | 149 | 313.5d | 2d | Lot 10 : Cloisons et plafonds agroalimentaires | 14h |
| 155 | 5.2.7.3.7 | Enlèvement paillasse | 2d | 2027-02-01 | 2027-02-03 | 150, 151, 152 | 311.5d | 0d | Lot 08 : Curage, démolitions, platrerie, peinture, faux-plafonds | 14h |
| 156 | 5.2.7.3.8 | Curage FP, Sol, dépose cloisons | 3d | 2027-02-03 | 2027-02-08 | 154, 155 | 311.5d | 0d | Lot 08 : Curage, démolitions, platrerie, peinture, faux-plafonds | 21h |
| 157 | 5.2.7.3.9 | Création de cloison | 3d | 2027-02-08 | 2027-02-11 | 156 | 311.5d | 0d | Lot 08 : Curage, démolitions, platrerie, peinture, faux-plafonds | 21h |
| 158 | 5.2.7.3.10 | Réseaux neufs CFO | 10d | 2027-02-15 | 2027-03-01 | 157FS+2d | 311.5d | 0d | Lot 01 : Courants forts | 70h |
| 159 | 5.2.7.3.11 | Réseaux neufs CFA | 10d | 2027-02-15 | 2027-03-01 | 157FS+2d | 311.5d | 0d | Lot 02 : Courants faibles | 70h |
| 160 | 5.2.7.3.12 | Réseaux neufs CVC, plomberie | 10d | 2027-02-15 | 2027-03-01 | 157FS+2d | 311.5d | 0d | Lot 03 : Chauffage, climatisation, ventilation, plomberie | 70h |
| 161 | 5.2.7.3.13 | Pose faux plafonds | 3d | 2027-03-01 | 2027-03-04 | 158, 159, 160 | 311.5d | 0d | Lot 08 : Curage, démolitions, platrerie, peinture, faux-plafonds | 21h |
| 162 | 5.2.7.3.14 | Finitions murales | 2d | 2027-03-04 | 2027-03-08 | 161 | 311.5d | 0d | Lot 07 : Sols souples, protections murales | 14h |
| 163 | 5.2.7.3.15 | Pose équipement CFO | 2d | 2027-03-08 | 2027-03-10 | 162 | 311.5d | 0d | Lot 01 : Courants forts | 14h |
| 164 | 5.2.7.3.16 | Pose équipements CVC | 2d | 2027-03-08 | 2027-03-10 | 162 | 311.5d | 0d | Lot 03 : Chauffage, climatisation, ventilation, plomberie | 14h |
| 165 | 5.2.7.3.17 | Pose équipements CFA | 2d | 2027-03-08 | 2027-03-10 | 162 | 311.5d | 0d | Lot 02 : Courants faibles | 14h |
| 166 | 5.2.7.3.18 | Pose sol | 3d | 2027-03-10 | 2027-03-15 | 163, 164, 165 | 311.5d | 0d | Lot 07 : Sols souples, protections murales | 21h |
| 167 | 5.2.7.3.19 | Installation paillasses et Sorbonne | 2d | 2027-03-15 | 2027-03-17 | 166 | 311.5d |  | Lot 06 : Paillasses, matériel de laboratoire | 14h |

Notes:
- 148: Discuter avec le service pour savoir si il faut faire les travaux en 1 ou 2 phases distinctes (activité sur Panther)

| ID | WBS | Task | Duration | Start | Finish | Predecessors | Total slack | Free slack | Resources | Work |
| --- | --- | --- | --- | --- | --- | --- | --- | --- | --- | --- |
| 168 | 5.2.7.4 | **Pièce 11101-15_0011** | 3d | 2027-01-28 | 2027-02-01 |  | 343d |  |  | 42h |
| 169 | 5.2.7.4.1 | Ajout CFO | 3d | 2027-01-28 | 2027-02-01 | 76 | 343d |  | Lot 01 : Courants forts | 21h |
| 170 | 5.2.7.4.2 | Ajout CFA | 3d | 2027-01-28 | 2027-02-01 | 76 | 343d |  | Lot 02 : Courants faibles | 21h |
| 171 | 5.2.8 | Réception phase 2.3 | 1d | 2027-03-17 | 2027-03-18 | 124 | 311.5d | 0d |  |  |
| 172 | 5.2.9 | **Phase 2.4 Déménagements** | 3d | 2027-03-18 | 2027-03-23 |  | 311.5d |  |  | 91h |
| 173 | 5.2.9.1 | Nettoyage avant installation installation (11101-15_0013 / 34 / 35) | 1d | 2027-03-18 | 2027-03-19 | 171 | 311.5d | 0d | Prestataire entretien des locaux | 7h |
| 174 | 5.2.9.2 | 15_0011 Eménagement pièce | 1d | 2027-03-19 | 2027-03-22 | 173 | 426d |  | Déménagement externe; Déménagement interne; Direction du laboratoire | 21h |
| 175 | 5.2.9.3 | 11101-15_0031 vers 11101-15_0034 (Alinity m) | 2d | 2027-03-19 | 2027-03-23 | 173 | 311.5d | 0d | Déménagement externe; Déménagement interne; Direction du laboratoire | 42h |
| 176 | 5.2.9.4 | 11101-15_0032 vers 11101-15_0035 | 1d | 2027-03-19 | 2027-03-22 | 173 | 426d |  | Déménagement externe; Déménagement interne; Direction du laboratoire | 21h |
| 177 | 5.3 | **SP05 - Phase 3** | 38.5d | 2027-03-23 | 2027-05-19 |  | 311.5d |  |  | 528.5h |
| 178 | 5.3.1 | **Phase 3.1** | 34.5d | 2027-03-23 | 2027-05-12 |  | 311.5d | 0d |  | 437.5h |
| 179 | 5.3.1.1 | **Pièces 11101-15_10 et 31** | 34.5d | 2027-03-23 | 2027-05-12 |  | 311.5d |  |  | 437.5h |
| 180 | 5.3.1.1.1 | Neutralisation réseaux (consignations) | 0.5d | 2027-03-23 | 2027-03-23 | 105, 175 | 311.5d | 0d | Services techniques | 3.5h |
| 181 | 5.3.1.1.2 | Déconnexion paillasse plomberie, dépose équipements de plomberie et CVC | 2d | 2027-03-24 | 2027-03-25 | 180 | 311.5d | 0d | Lot 03 : Chauffage, climatisation, ventilation, plomberie | 14h |
| 182 | 5.3.1.1.3 | Déconnexion paillasse CFO et luminaires | 2d | 2027-03-24 | 2027-03-25 | 180 | 311.5d | 0d | Lot 01 : Courants forts | 14h |
| 183 | 5.3.1.1.4 | Déconnexion paillasse CFA | 2d | 2027-03-24 | 2027-03-25 | 180 | 311.5d | 0d | Lot 02 : Courants faibles | 14h |
| 184 | 5.3.1.1.5 | Renfort plafonds | 2d | 2027-03-24 | 2027-03-25 | 180 | 313.5d | 2d | Lot 10 : Cloisons et plafonds agroalimentaires | 14h |
| 185 | 5.3.1.1.6 | Enlèvement paillasse | 2d | 2027-03-26 | 2027-03-30 | 181, 182, 183 | 311.5d | 0d | Lot 08 : Curage, démolitions, platrerie, peinture, faux-plafonds | 14h |
| 186 | 5.3.1.1.7 | Curage FP, Sol, dépose cloisons | 3d | 2027-03-31 | 2027-04-02 | 184, 185 | 311.5d | 0d | Lot 08 : Curage, démolitions, platrerie, peinture, faux-plafonds | 21h |
| 187 | 5.3.1.1.8 | Création d'une porte dans la cloison | 3d | 2027-04-05 | 2027-04-07 | 186 | 311.5d | 0d | Lot 08 : Curage, démolitions, platrerie, peinture, faux-plafonds | 21h |
| 188 | 5.3.1.1.9 | Réseaux neufs CFO | 10d | 2027-04-12 | 2027-04-23 | 187FS+2d | 311.5d | 0d | Lot 01 : Courants forts | 70h |
| 189 | 5.3.1.1.10 | Réseaux neufs CFA | 10d | 2027-04-12 | 2027-04-23 | 187FS+2d | 311.5d | 0d | Lot 02 : Courants faibles | 70h |
| 190 | 5.3.1.1.11 | Réseaux neufs CVC, plomberie | 10d | 2027-04-12 | 2027-04-23 | 187FS+2d | 311.5d | 0d | Lot 03 : Chauffage, climatisation, ventilation, plomberie | 70h |
| 191 | 5.3.1.1.12 | Pose plafonds agro | 3d | 2027-04-26 | 2027-04-28 | 188, 189, 190 | 311.5d | 0d | Lot 08 : Curage, démolitions, platrerie, peinture, faux-plafonds | 21h |
| 192 | 5.3.1.1.13 | Finitions murales | 2d | 2027-04-29 | 2027-04-30 | 191 | 311.5d | 0d | Lot 10 : Cloisons et plafonds agroalimentaires | 14h |
| 193 | 5.3.1.1.14 | Pose équipement CFO | 2d | 2027-05-03 | 2027-05-04 | 192 | 311.5d | 0d | Lot 01 : Courants forts | 14h |
| 194 | 5.3.1.1.15 | Pose équipements CVC | 2d | 2027-05-03 | 2027-05-04 | 192 | 311.5d | 0d | Lot 03 : Chauffage, climatisation, ventilation, plomberie | 14h |
| 195 | 5.3.1.1.16 | Pose équipements CFA | 2d | 2027-05-03 | 2027-05-04 | 192 | 311.5d | 0d | Lot 02 : Courants faibles | 14h |
| 196 | 5.3.1.1.17 | Pose sol | 3d | 2027-05-05 | 2027-05-10 | 193, 194, 195 | 311.5d | 0d | Lot 07 : Sols souples, protections murales | 21h |
| 197 | 5.3.1.1.18 | Installation paillasses | 2d | 2027-05-11 | 2027-05-12 | 196 | 311.5d |  | Lot 06 : Paillasses, matériel de laboratoire | 14h |
| 198 | 5.3.2 | Réception phase | 1d | 2027-05-13 | 2027-05-13 | 178 | 311.5d | 0d |  |  |

| ID | WBS | Task | Duration | Start | Finish | Predecessors | Total slack | Free slack | Resources | Work |
| --- | --- | --- | --- | --- | --- | --- | --- | --- | --- | --- |
| 199 | 5.3.3 | **Phase 3.2 Déménagements** | 3d | 2027-05-14 | 2027-05-19 |  | 311.5d | 0d |  | 91h |
| 200 | 5.3.3.1 | Nettoyage avant installation installation (11101-15_0010 / 31) | 1d | 2027-05-14 | 2027-05-14 | 198 | 311.5d | 0d | Prestataire entretien des locaux | 7h |
| 201 | 5.3.3.2 | 15_0031 Déménagement fin de phase 3 ( pièces 32,33 vers 31) | 2d | 2027-05-18 | 2027-05-19 | 200 | 311.5d |  | Déménagement externe; Déménagement interne; Direction du laboratoire | 42h |
| 202 | 5.3.3.3 | 11101-15_0033 vers 11101-15_00331 | 2d | 2027-05-18 | 2027-05-19 | 200 | 311.5d |  | Déménagement externe; Déménagement interne; Direction du laboratoire | 42h |
| 203 | 5.4 | **SP05 - Phase 4** | 38.5d | 2027-05-20 | 2027-07-13 |  | 311.5d |  |  | 528.5h |
| 204 | 5.4.1 | **Phase 4.1** | 35.5d | 2027-05-20 | 2027-07-08 |  | 311.5d |  |  | 437.5h |
| 205 | 5.4.1.1 | **Pièces 11101-15_32, et 33** | 34.5d | 2027-05-20 | 2027-07-07 |  | 311.5d | 0d |  | 437.5h |
| 206 | 5.4.1.1.1 | Neutralisation réseaux (consignations) | 0.5d | 2027-05-20 | 2027-05-20 | 199 | 311.5d | 0d | Services techniques | 3.5h |
| 207 | 5.4.1.1.2 | Démontage cloison provisoire | 1d | 2027-05-20 | 2027-05-21 | 206 | 344.5d |  | Lot 08 : Curage, démolitions, platrerie, peinture, faux-plafonds | 7h |
| 208 | 5.4.1.1.3 | Déconnexion paillasse plomberie, dépose équipements de plomberie et CVC | 2d | 2027-05-20 | 2027-05-24 | 206 | 311.5d | 0d | Lot 03 : Chauffage, climatisation, ventilation, plomberie | 14h |
| 209 | 5.4.1.1.4 | Déconnexion paillasse CFO et luminaires | 2d | 2027-05-20 | 2027-05-24 | 206 | 311.5d | 0d | Lot 01 : Courants forts | 14h |
| 210 | 5.4.1.1.5 | Déconnexion paillasse CFA | 2d | 2027-05-20 | 2027-05-24 | 206 | 311.5d | 0d | Lot 02 : Courants faibles | 14h |
| 211 | 5.4.1.1.6 | Enlèvement paillasse | 2d | 2027-05-24 | 2027-05-26 | 208, 209, 210 | 311.5d | 0d | Lot 08 : Curage, démolitions, platrerie, peinture, faux-plafonds | 14h |
| 212 | 5.4.1.1.7 | Curage FP, Sol, dépose cloisons | 3d | 2027-05-26 | 2027-05-31 | 211 | 311.5d | 0d | Lot 08 : Curage, démolitions, platrerie, peinture, faux-plafonds | 21h |
| 213 | 5.4.1.1.8 | Renfort cloisons | 1d | 2027-05-31 | 2027-06-01 | 212 | 337.5d |  | Lot 10 : Cloisons et plafonds agroalimentaires | 7h |
| 214 | 5.4.1.1.9 | Création de cloison et étoupements | 3d | 2027-05-31 | 2027-06-03 | 212 | 311.5d | 0d | Lot 08 : Curage, démolitions, platrerie, peinture, faux-plafonds | 21h |
| 215 | 5.4.1.1.10 | Réseaux neufs CFO | 10d | 2027-06-07 | 2027-06-21 | 214FS+2d | 311.5d | 0d | Lot 01 : Courants forts | 70h |
| 216 | 5.4.1.1.11 | Réseaux neufs CFA | 10d | 2027-06-07 | 2027-06-21 | 214FS+2d | 311.5d | 0d | Lot 02 : Courants faibles | 70h |
| 217 | 5.4.1.1.12 | Réseaux neufs CVC, plomberie | 10d | 2027-06-07 | 2027-06-21 | 214FS+2d | 311.5d | 0d | Lot 03 : Chauffage, climatisation, ventilation, plomberie | 70h |
| 218 | 5.4.1.1.13 | Pose faux plafonds | 3d | 2027-06-21 | 2027-06-24 | 215, 216, 217 | 311.5d | 0d | Lot 08 : Curage, démolitions, platrerie, peinture, faux-plafonds | 21h |
| 219 | 5.4.1.1.14 | Finitions murales | 2d | 2027-06-24 | 2027-06-28 | 218 | 311.5d | 0d | Lot 07 : Sols souples, protections murales | 14h |
| 220 | 5.4.1.1.15 | Pose équipement CFO | 2d | 2027-06-28 | 2027-06-30 | 219 | 311.5d | 0d | Lot 01 : Courants forts | 14h |
| 221 | 5.4.1.1.16 | Pose équipements CVC | 2d | 2027-06-28 | 2027-06-30 | 219 | 311.5d | 0d | Lot 03 : Chauffage, climatisation, ventilation, plomberie | 14h |
| 222 | 5.4.1.1.17 | Pose équipements CFA | 2d | 2027-06-28 | 2027-06-30 | 219 | 311.5d | 0d | Lot 02 : Courants faibles | 14h |
| 223 | 5.4.1.1.18 | Pose sol | 3d | 2027-06-30 | 2027-07-05 | 220, 221, 222 | 311.5d | 0d | Lot 07 : Sols souples, protections murales | 21h |
| 224 | 5.4.1.1.19 | Installation paillasses | 2d | 2027-07-05 | 2027-07-07 | 223 | 311.5d |  | Lot 06 : Paillasses, matériel de laboratoire | 14h |
| 225 | 5.4.1.2 | Réception pièces | 1d | 2027-07-07 | 2027-07-08 | 205 | 311.5d | 0d |  |  |

| ID | WBS | Task | Duration | Start | Finish | Predecessors | Total slack | Free slack | Resources | Work |
| --- | --- | --- | --- | --- | --- | --- | --- | --- | --- | --- |
| 226 | 5.4.2 | **Phase 4.2 déménagements** | 3d | 2027-07-08 | 2027-07-13 |  | 311.5d | 0d |  | 91h |
| 227 | 5.4.2.1 | **Déménagement de fin de phase 4** | 3d | 2027-07-08 | 2027-07-13 |  | 311.5d |  |  | 91h |
| 228 | 5.4.2.1.1 | Nettoyage avant installation installation (11101-15_0032 / 33) | 1d | 2027-07-08 | 2027-07-09 | 225 | 311.5d | 0d | Prestataire entretien des locaux | 7h |
| 229 | 5.4.2.1.2 | 11101-15_00 vers 11101-15_32 (sérologies) | 2d | 2027-07-09 | 2027-07-13 | 228 | 311.5d |  | Déménagement externe; Déménagement interne; Direction du laboratoire | 42h |
| 230 | 5.4.2.1.3 | 11101-15_007 vers 11101-15_33 (Begenius et Ingénius) | 2d | 2027-07-09 | 2027-07-13 | 228 | 311.5d |  | Déménagement externe; Déménagement interne; Direction du laboratoire | 42h |
| 231 | 5.5 | **SP05 - Phase 5** | 29.5d | 2027-07-13 | 2027-08-24 |  | 311.5d |  |  | 402.5h |
| 232 | 5.5.1 | **Pièces 11101-15_07** | 29.5d | 2027-07-13 | 2027-08-24 |  | 311.5d | 0d |  | 402.5h |
| 233 | 5.5.1.1 | Neutralisation réseaux (consignations) | 0.5d | 2027-07-13 | 2027-07-13 | 226 | 311.5d | 0d | Services techniques | 3.5h |
| 234 | 5.5.1.2 | Déconnexion paillasse plomberie, dépose équipements de plomberie et CVC | 2d | 2027-07-15 | 2027-07-16 | 233 | 311.5d | 0d | Lot 03 : Chauffage, climatisation, ventilation, plomberie | 14h |
| 235 | 5.5.1.3 | Déconnexion paillasse CFO et luminaires | 2d | 2027-07-15 | 2027-07-16 | 233 | 311.5d | 0d | Lot 01 : Courants forts | 14h |
| 236 | 5.5.1.4 | Déconnexion paillasse CFA | 2d | 2027-07-15 | 2027-07-16 | 233 | 311.5d | 0d | Lot 02 : Courants faibles | 14h |
| 237 | 5.5.1.5 | Enlèvement paillasse | 2d | 2027-07-19 | 2027-07-20 | 234, 235, 236 | 311.5d | 0d | Lot 08 : Curage, démolitions, platrerie, peinture, faux-plafonds | 14h |
| 238 | 5.5.1.6 | Curage FP, Sol, dépose cloisons | 3d | 2027-07-21 | 2027-07-23 | 237 | 311.5d | 0d | Lot 08 : Curage, démolitions, platrerie, peinture, faux-plafonds | 21h |
| 239 | 5.5.1.7 | Réseaux neufs CFO | 10d | 2027-07-26 | 2027-08-06 | 238 | 311.5d | 0d | Lot 01 : Courants forts | 70h |
| 240 | 5.5.1.8 | Réseaux neufs CFA | 10d | 2027-07-26 | 2027-08-06 | 238 | 311.5d | 0d | Lot 02 : Courants faibles | 70h |
| 241 | 5.5.1.9 | Réseaux neufs CVC, plomberie | 10d | 2027-07-26 | 2027-08-06 | 238 | 311.5d | 0d | Lot 03 : Chauffage, climatisation, ventilation, plomberie | 70h |
| 242 | 5.5.1.10 | Pose plafonds agro | 3d | 2027-08-09 | 2027-08-11 | 239, 240, 241 | 311.5d | 0d | Lot 10 : Cloisons et plafonds agroalimentaires | 21h |
| 243 | 5.5.1.11 | Finitions murales | 2d | 2027-08-12 | 2027-08-13 | 242 | 311.5d | 0d | Lot 07 : Sols souples, protections murales | 14h |
| 244 | 5.5.1.12 | Pose équipement CFO | 2d | 2027-08-16 | 2027-08-17 | 243 | 311.5d | 0d | Lot 01 : Courants forts | 14h |
| 245 | 5.5.1.13 | Pose équipements CVC | 2d | 2027-08-16 | 2027-08-17 | 243 | 311.5d | 0d | Lot 03 : Chauffage, climatisation, ventilation, plomberie | 14h |
| 246 | 5.5.1.14 | Pose équipements CFA | 2d | 2027-08-16 | 2027-08-17 | 243 | 311.5d | 0d | Lot 02 : Courants faibles | 14h |
| 247 | 5.5.1.15 | Pose sol | 3d | 2027-08-18 | 2027-08-20 | 244, 245, 246 | 311.5d | 0d | Lot 07 : Sols souples, protections murales | 21h |
| 248 | 5.5.1.16 | Installation paillasses | 2d | 2027-08-23 | 2027-08-24 | 247 | 311.5d |  | Lot 06 : Paillasses, matériel de laboratoire | 14h |
| 249 | 5.6 | Réception pièces | 1d | 2027-08-25 | 2027-08-25 | 232 | 311.5d | 0d | Direction des Travaux, de l'Environnement et de la Sécurité; Direction du laboratoire; Lot 01 : Courants forts; Lot 02 : Courants faibles; Lot 03 : Chauffage, climatisation, ventilation, plomberie; Lot 07 : Sols souples, protections murales; Lot 08 : Curage, démolitions, platrerie, peinture, faux-plafonds; Lot 06 : Paillasses, matériel de laboratoire; Lot 10 : Cloisons et plafonds agroalimentaires | 63h |

| ID | WBS | Task | Type | Duration | Start | Finish | Predecessors | Total slack | Free slack | Resources | Work |
| --- | --- | --- | --- | --- | --- | --- | --- | --- | --- | --- | --- |
| 250 | 5.7 | **Phase 5 Déménagements** |  | 6d | 2027-08-26 | 2027-09-02 |  | 311.5d |  |  | 112h |
| 251 | 5.7.1 | Nettoyage avant installation installation (11101-15_0007) |  | 1d | 2027-08-26 | 2027-08-26 | 249 | 311.5d | 0d | Prestataire entretien des locaux | 7h |
| 252 | 5.7.2 | 15_0007 Déménagement de fin de phase 5 (EasyMag) |  | 5d | 2027-08-27 | 2027-09-02 | 251 | 311.5d |  | Déménagement externe; Déménagement interne; Direction du laboratoire | 105h |
| 254 | 6 | **SP6 : RDC, 4ème et 6ème étages** |  | 371.5d | 2026-09-15 | 2028-02-29 |  | 55.5d |  |  | 13202h |
| 255 | 6.1 | **6e étage** |  | 8d | 2026-12-02 | 2026-12-14 |  | 365d |  |  | 308h |
| 256 | 6.1.1 | **SP06 - 6ème Pièces 11101-16_0011a, 11b et 12 - Aménagement transitoire pour UHH** |  | 4d | 2026-12-02 | 2026-12-08 |  | 365d | 0d |  | 56h |
| 257 | 6.1.1.1 | Déménagements 6ème | milestone | 0d | 2026-12-02 | 2026-12-02 | 697, 3 | 365d | 0d |  |  |
| 258 | 6.1.1.2 | Consignation |  | 1d | 2026-12-02 | 2026-12-03 | 257 | 365d | 0d | Services techniques | 7h |
| 259 | 6.1.1.3 | Ajouts CFO |  | 2d | 2026-12-03 | 2026-12-07 | 258 | 365d | 0d | Lot 01 : Courants forts | 14h |
| 260 | 6.1.1.4 | Ajouts CFA |  | 2d | 2026-12-03 | 2026-12-07 | 258 | 365d | 0d | Lot 02 : Courants faibles | 14h |
| 261 | 6.1.1.5 | Plomberie |  | 2d | 2026-12-03 | 2026-12-07 | 258 | 365d | 0d | Lot 03 : Chauffage, climatisation, ventilation, plomberie | 14h |
| 262 | 6.1.1.6 | Récupération paillasses (2 humides et 2 sèches) dans pièces à déterminer puis montage et raccordementdans pièces 11a, 11b et 12 (uniquement pièces 11a 11b) |  | 1d | 2026-12-07 | 2026-12-08 | 259, 260, 261 | 365d |  | Services techniques | 7h |
| 263 | 6.1.2 | Réception de phase transitoire |  | 1d | 2026-12-08 | 2026-12-09 | 256 | 365d | 0d | Lot 01 : Courants forts; Lot 02 : Courants faibles; Direction des Travaux, de l'Environnement et de la Sécurité; Direction du laboratoire; Lot 03 : Chauffage, climatisation, ventilation, plomberie | 35h |
| 264 | 6.1.3 | **Déménagements 6ème dans locaux transitoires de l'UHH** |  | 3d | 2026-12-09 | 2026-12-14 |  | 365d | 0d |  | 217h |
| 265 | 6.1.3.1 | Nettoyage avant installation installation (11101-16_11a, 11b, 12) |  | 1d | 2026-12-09 | 2026-12-10 | 263 | 365d | 0d | Prestataire entretien des locaux | 7h |
| 266 | 6.1.3.2 | 11101-16_0026 (réunion) vers ? |  | 2d | 2026-12-10 | 2026-12-14 | 265 | 365d |  | Déménagement externe; Déménagement interne; Direction du laboratoire | 42h |
| 267 | 6.1.3.3 | 11101-16_0027 vers 11101-16_0011b |  | 2d | 2026-12-10 | 2026-12-14 | 265 | 365d |  | Déménagement externe; Déménagement interne; Direction du laboratoire | 42h |
| 268 | 6.1.3.4 | 11101-16_0028 vers 11101-16_0011a |  | 2d | 2026-12-10 | 2026-12-14 | 265 | 365d |  | Déménagement externe; Déménagement interne; Direction du laboratoire | 42h |
| 269 | 6.1.3.5 | 11101-16_0029 vers 11101-16_0012 |  | 2d | 2026-12-10 | 2026-12-14 | 265 | 365d |  | Déménagement externe; Déménagement interne; Direction du laboratoire | 42h |
| 270 | 6.1.3.6 | 11101-16_0046 vers 11101-16_0012 |  | 2d | 2026-12-10 | 2026-12-14 | 265 | 365d |  | Déménagement externe; Déménagement interne; Direction du laboratoire | 42h |
| 271 | 6.2 | **Rez-de-chaussée** |  | 90d | 2026-12-02 | 2027-04-12 |  | 360d | 0d |  | 3080h |
| 272 | 6.2.1 | **SP06 - RDC - Phase 1** |  | 42.5d | 2026-12-02 | 2027-02-02 |  | 360d |  |  | 1582h |
| 273 | 6.2.1.1 | **Déménagements RDC** |  | 1d | 2026-12-02 | 2026-12-03 |  | 360d | 0d |  | 231h |
| 274 | 6.2.1.1.1 | RDC - Hall (distibuteurs boissons et aliments) |  | 1d | 2026-12-02 | 2026-12-03 | 3 | 360d |  | Déménagement externe; Déménagement interne; Direction du laboratoire | 21h |
| 275 | 6.2.1.1.2 | 11103-10_0012 box CDP vers ? |  | 1d | 2026-12-02 | 2026-12-03 | 3 | 360d |  | Déménagement externe; Déménagement interne; Direction du laboratoire | 21h |
| 276 | 6.2.1.1.3 | 11101-10_0001 vers stockage 11101-SS_ ? |  | 1d | 2026-12-02 | 2026-12-03 | 3 | 360d |  | Déménagement externe; Déménagement interne; Direction du laboratoire | 21h |
| 277 | 6.2.1.1.4 | 11101-10_0002 vers stockage 11101-SS_ ? |  | 1d | 2026-12-02 | 2026-12-03 | 3 | 360d |  | Déménagement externe; Déménagement interne; Direction du laboratoire | 21h |
| 278 | 6.2.1.1.5 | 11101-10_0003 vers stockage 11101-SS_ ? |  | 1d | 2026-12-02 | 2026-12-03 | 3 | 360d |  | Déménagement externe; Déménagement interne; Direction du laboratoire | 21h |
| 279 | 6.2.1.1.6 | 11101-10_0006 vers stockage 11101-SS_ ? |  | 1d | 2026-12-02 | 2026-12-03 | 3 | 360d |  | Déménagement externe; Déménagement interne; Direction du laboratoire | 21h |
| 280 | 6.2.1.1.7 | 11101-10_0007 vers stockage 11101-SS_ ? |  | 1d | 2026-12-02 | 2026-12-03 | 3 | 360d |  | Déménagement externe; Déménagement interne; Direction du laboratoire | 21h |
| 281 | 6.2.1.1.8 | 11101-10_0008 vers stockage 11101-SS_ ? |  | 1d | 2026-12-02 | 2026-12-03 | 3 | 360d |  | Déménagement externe; Déménagement interne; Direction du laboratoire | 21h |
| 282 | 6.2.1.1.9 | 11101-10_0009 vers stockage 11101-SS_ ? |  | 1d | 2026-12-02 | 2026-12-03 | 3 | 360d |  | Déménagement externe; Déménagement interne; Direction du laboratoire | 21h |
| 283 | 6.2.1.1.10 | 11101-10_0052 vers stockage 11101-SS_ ? |  | 1d | 2026-12-02 | 2026-12-03 | 3 | 360d |  | Déménagement externe; Déménagement interne; Direction du laboratoire | 21h |
| 284 | 6.2.1.1.11 | 11101-10_0053 vers stockage 11101-SS_ ? |  | 1d | 2026-12-02 | 2026-12-03 | 3 | 360d |  | Déménagement externe; Déménagement interne; Direction du laboratoire | 21h |

Notes:
- 257: A lier au déménagement du Pr Godefrain

| ID | WBS | Task | Duration | Start | Finish | Predecessors | Total slack | Free slack | Resources | Work |
| --- | --- | --- | --- | --- | --- | --- | --- | --- | --- | --- |
| 285 | 6.2.1.2 | **Pièces 11103-10_0011** | 28d | 2026-12-03 | 2027-01-14 |  | 373.5d | 13.5d |  | 490h |
| 286 | 6.2.1.2.1 | Consignation | 1d | 2026-12-03 | 2026-12-04 | 273 | 373.5d | 0d | Services techniques | 7h |
| 287 | 6.2.1.2.2 | Dépose équipements CFO | 3d | 2026-12-04 | 2026-12-09 | 286 | 373.5d | 0d | Lot 01 : Courants forts | 21h |
| 288 | 6.2.1.2.3 | Dépose équipements CFA | 3d | 2026-12-04 | 2026-12-09 | 286 | 373.5d | 0d | Lot 02 : Courants faibles | 21h |
| 289 | 6.2.1.2.4 | Dépose radiateurs, éléments de plomberie | 3d | 2026-12-04 | 2026-12-09 | 286 | 373.5d | 0d | Lot 03 : Chauffage, climatisation, ventilation, plomberie | 21h |
| 290 | 6.2.1.2.5 | Dépose faux-plafond, curage sol et dépose cloison | 5d | 2026-12-09 | 2026-12-16 | 287, 288, 289 | 373.5d | 0d | Lot 08 : Curage, démolitions, platrerie, peinture, faux-plafonds | 35h |
| 291 | 6.2.1.2.6 | Dépose élements menuiserie extérieur | 1d | 2026-12-16 | 2026-12-17 | 290 | 373.5d | 0d | Lot 09 : Menuiseries extérieures, cloisons vitrées, protections solaires | 7h |
| 292 | 6.2.1.2.7 | Pose fenêtres hall | 5d | 2026-12-17 | 2026-12-24 | 291 | 373.5d | 0d | Lot 09 : Menuiseries extérieures, cloisons vitrées, protections solaires | 35h |
| 293 | 6.2.1.2.8 | Cloisons neuves | 5d | 2026-12-21 | 2026-12-29 | 292SS+2d | 373.5d | 0d | Lot 08 : Curage, démolitions, platrerie, peinture, faux-plafonds | 35h |
| 294 | 6.2.1.2.9 | Pose menuiseries intérieures | 5d | 2026-12-21 | 2026-12-29 | 292SS+2d | 384.5d |  | Lot 08 : Curage, démolitions, platrerie, peinture, faux-plafonds | 35h |
| 295 | 6.2.1.2.10 | Dépose / repose porte automatique | 5d | 2026-12-21 | 2026-12-29 | 292SS+2d | 384.5d |  | Lot 05 : Portes automatiques | 35h |
| 296 | 6.2.1.2.11 | Pose nouveaux réseaux CFO | 5d | 2026-12-21 | 2026-12-29 | 292SS+2d | 373.5d | 0d | Lot 01 : Courants forts | 35h |
| 297 | 6.2.1.2.12 | Pose nouveaux réseaux CFA | 5d | 2026-12-21 | 2026-12-29 | 292SS+2d | 373.5d | 0d | Lot 02 : Courants faibles | 35h |
| 298 | 6.2.1.2.13 | Pose nouveau réseau CVC | 5d | 2026-12-21 | 2026-12-29 | 292SS+2d | 384.5d |  | Lot 03 : Chauffage, climatisation, ventilation, plomberie | 35h |
| 299 | 6.2.1.2.14 | Pose faux plafonds neuf | 5d | 2026-12-29 | 2027-01-06 | 293, 296, 297 | 373.5d | 0d | Lot 08 : Curage, démolitions, platrerie, peinture, faux-plafonds | 35h |
| 300 | 6.2.1.2.15 | Pose équipements CFO | 2d | 2026-12-31 | 2027-01-05 | 299SS+2d | 378.5d | 5d | Lot 01 : Courants forts | 14h |
| 301 | 6.2.1.2.16 | Pose équipements CFA | 2d | 2026-12-31 | 2027-01-05 | 299SS+2d | 378.5d | 5d | Lot 02 : Courants faibles | 14h |
| 302 | 6.2.1.2.17 | Pose équipements CVC | 2d | 2026-12-31 | 2027-01-05 | 299SS+2d | 378.5d | 5d | Lot 02 : Courants faibles | 14h |
| 303 | 6.2.1.2.18 | Finitions murales | 5d | 2027-01-05 | 2027-01-12 | 299SS+4d | 373.5d | 0d | Lot 08 : Curage, démolitions, platrerie, peinture, faux-plafonds | 35h |
| 304 | 6.2.1.2.19 | Pose stores | 2d | 2027-01-12 | 2027-01-14 | 299, 300, 302, 303, 301 | 373.5d |  | Lot 09 : Menuiseries extérieures, cloisons vitrées, protections solaires | 14h |
| 305 | 6.2.1.2.20 | Pose radiateurs | 1d | 2027-01-12 | 2027-01-13 | 299, 300, 302, 303, 301 | 374.5d |  | Lot 03 : Chauffage, climatisation, ventilation, plomberie | 7h |
| 306 | 6.2.1.3 | **Pièces 11103-10_0012** | 18.5d | 2026-12-03 | 2026-12-30 |  | 383d | 23d |  | 185.5h |
| 307 | 6.2.1.3.1 | Consignation | 0.5d | 2026-12-03 | 2026-12-03 | 273 | 383d | 0d | Services techniques | 3.5h |
| 308 | 6.2.1.3.2 | Dépose équipements CFO | 1d | 2026-12-04 | 2026-12-04 | 307 | 384d | 1d | Lot 01 : Courants forts | 7h |
| 309 | 6.2.1.3.3 | Dépose équipements CFA | 1d | 2026-12-04 | 2026-12-04 | 307 | 384d | 1d | Lot 02 : Courants faibles | 7h |
| 310 | 6.2.1.3.4 | Dépose radiateurs, éléments de plomberie | 2d | 2026-12-04 | 2026-12-07 | 307 | 383d | 0d | Lot 03 : Chauffage, climatisation, ventilation, plomberie | 14h |
| 311 | 6.2.1.3.5 | Dépose faux-plafond, curage sol et dépose cloison | 1d | 2026-12-08 | 2026-12-08 | 308, 309, 310 | 383d | 0d | Lot 08 : Curage, démolitions, platrerie, peinture, faux-plafonds | 7h |
| 312 | 6.2.1.3.6 | Création de fenêtre | 2d | 2026-12-09 | 2026-12-10 | 311 | 383d | 0d | Lot 08 : Curage, démolitions, platrerie, peinture, faux-plafonds | 14h |
| 313 | 6.2.1.3.7 | Pose fenêtre | 2d | 2026-12-11 | 2026-12-14 | 312 | 394d |  | Lot 09 : Menuiseries extérieures, cloisons vitrées, protections solaires | 14h |
| 314 | 6.2.1.3.8 | Doublage phonnique + coffret habillage | 3d | 2026-12-11 | 2026-12-15 | 312SS+2d | 383d | 0d | Lot 08 : Curage, démolitions, platrerie, peinture, faux-plafonds | 21h |
| 315 | 6.2.1.3.9 | Pose nouveaux réseaux CFO | 2d | 2026-12-11 | 2026-12-14 | 312SS+2d | 384d | 1d | Lot 01 : Courants forts | 14h |
| 316 | 6.2.1.3.10 | Pose nouveaux réseaux CFA | 2d | 2026-12-11 | 2026-12-14 | 312SS+2d | 384d | 1d | Lot 02 : Courants faibles | 14h |
| 317 | 6.2.1.3.11 | Pose faux plafonds neuf | 1d | 2026-12-16 | 2026-12-16 | 314, 315, 316 | 383d | 0d | Lot 08 : Curage, démolitions, platrerie, peinture, faux-plafonds | 7h |
| 318 | 6.2.1.3.12 | Pose équipements CFO | 1d | 2026-12-18 | 2026-12-18 | 317SS+2d | 387d | 4d | Lot 01 : Courants forts | 7h |
| 319 | 6.2.1.3.13 | Pose équipements CFA | 1d | 2026-12-18 | 2026-12-18 | 317SS+2d | 387d | 4d | Lot 02 : Courants faibles | 7h |
| 320 | 6.2.1.3.14 | Finitions murales | 3d | 2026-12-22 | 2026-12-24 | 317SS+4d | 383d | 0d | Lot 08 : Curage, démolitions, platrerie, peinture, faux-plafonds | 21h |
| 321 | 6.2.1.3.15 | Pose stores | 1d | 2026-12-28 | 2026-12-28 | 317, 318, 319, 320 | 383d | 0d | Lot 09 : Menuiseries extérieures, cloisons vitrées, protections solaires | 7h |
| 322 | 6.2.1.3.16 | Repose radiateurs | 1d | 2026-12-28 | 2026-12-28 | 317, 318, 319, 320 | 383d | 0d | Lot 03 : Chauffage, climatisation, ventilation, plomberie | 7h |
| 323 | 6.2.1.3.17 | Pose sol | 2d | 2026-12-29 | 2026-12-30 | 321, 322 | 383d |  | Lot 07 : Sols souples, protections murales | 14h |

| ID | WBS | Task | Duration | Start | Finish | Predecessors | Total slack | Free slack | Resources | Work |
| --- | --- | --- | --- | --- | --- | --- | --- | --- | --- | --- |
| 324 | 6.2.1.4 | **Pièces 11101-10_0001; 02; 03; 06; 07; 08; 51; 52; 53** | 41.5d | 2026-12-03 | 2027-02-02 |  | 360d | 0d |  | 675.5h |
| 325 | 6.2.1.4.1 | Consignation | 0.5d | 2026-12-03 | 2026-12-03 | 273 | 360d | 0d | Services techniques | 3.5h |
| 326 | 6.2.1.4.2 | Dépose équipements CFO | 2d | 2026-12-04 | 2026-12-07 | 325 | 360d | 0d | Lot 01 : Courants forts | 14h |
| 327 | 6.2.1.4.3 | Dépose équipements CFA | 2d | 2026-12-04 | 2026-12-07 | 325 | 360d | 0d | Lot 02 : Courants faibles | 14h |
| 328 | 6.2.1.4.4 | Dépose équipements CVC | 2d | 2026-12-04 | 2026-12-07 | 325 | 360d | 0d | Lot 03 : Chauffage, climatisation, ventilation, plomberie | 14h |
| 329 | 6.2.1.4.5 | Dépose radiateurs, éléments de plomberie | 2d | 2026-12-04 | 2026-12-07 | 325 | 360d | 0d | Lot 03 : Chauffage, climatisation, ventilation, plomberie | 14h |
| 330 | 6.2.1.4.6 | Dépose faux-plafond, curage sol et dépose cloison | 5d | 2026-12-08 | 2026-12-14 | 326, 328, 329, 327 | 360d | 0d | Lot 08 : Curage, démolitions, platrerie, peinture, faux-plafonds | 35h |
| 331 | 6.2.1.4.7 | Cloisons neuves + caisson habillage | 10d | 2026-12-15 | 2026-12-29 | 330 | 360d | 0d | Lot 08 : Curage, démolitions, platrerie, peinture, faux-plafonds | 70h |
| 332 | 6.2.1.4.8 | Pose nouveaux réseaux CFO | 10d | 2026-12-15 | 2026-12-29 | 330 | 360d | 0d | Lot 01 : Courants forts | 70h |
| 333 | 6.2.1.4.9 | Pose nouveaux réseaux CFA | 10d | 2026-12-15 | 2026-12-29 | 330 | 360d | 0d | Lot 02 : Courants faibles | 70h |
| 334 | 6.2.1.4.10 | Pose nouveaux réseaux CVC + Plomberie | 10d | 2026-12-15 | 2026-12-29 | 330 | 360d | 0d | Lot 03 : Chauffage, climatisation, ventilation, plomberie | 70h |
| 335 | 6.2.1.4.11 | Pose faux plafonds neuf | 5d | 2026-12-30 | 2027-01-06 | 331, 332, 333, 334 | 360d | 0d | Lot 08 : Curage, démolitions, platrerie, peinture, faux-plafonds | 35h |
| 336 | 6.2.1.4.12 | Pose équipements CFO | 5d | 2027-01-04 | 2027-01-08 | 335SS+2d | 367d | 7d | Lot 01 : Courants forts | 35h |
| 337 | 6.2.1.4.13 | Pose équipements CFA | 5d | 2027-01-04 | 2027-01-08 | 335SS+2d | 367d | 7d | Lot 02 : Courants faibles | 35h |
| 338 | 6.2.1.4.14 | Pose équipements CVC + plomberie | 5d | 2027-01-04 | 2027-01-08 | 335SS+2d | 367d | 7d | Lot 03 : Chauffage, climatisation, ventilation, plomberie | 35h |
| 339 | 6.2.1.4.15 | Finitions murales | 10d | 2027-01-06 | 2027-01-19 | 335SS+4d | 360d | 0d | Lot 08 : Curage, démolitions, platrerie, peinture, faux-plafonds | 70h |
| 340 | 6.2.1.4.16 | Pose stores | 2d | 2027-01-20 | 2027-01-21 | 335, 336, 337, 339, 338 | 360d | 0d | Lot 09 : Menuiseries extérieures, cloisons vitrées, protections solaires | 14h |
| 341 | 6.2.1.4.17 | Repose radiateurs | 2d | 2027-01-20 | 2027-01-21 | 335, 336, 337, 339, 338 | 360d | 0d | Lot 03 : Chauffage, climatisation, ventilation, plomberie | 14h |
| 342 | 6.2.1.4.18 | Pose sol | 5d | 2027-01-22 | 2027-01-28 | 340, 341 | 360d | 0d | Lot 07 : Sols souples, protections murales | 35h |
| 343 | 6.2.1.4.19 | Meunuiserie intérieur - kitchinette | 2d | 2027-01-29 | 2027-02-01 | 342 | 360d | 0d | Lot 08 : Curage, démolitions, platrerie, peinture, faux-plafonds | 14h |
| 344 | 6.2.1.4.20 | Installation paillasses | 1d | 2027-01-29 | 2027-01-29 | 342 | 361d | 1d | Lot 06 : Paillasses, matériel de laboratoire | 7h |
| 345 | 6.2.1.4.21 | Raccordement kitchinette plomberie | 1d | 2027-02-02 | 2027-02-02 | 343, 344 | 360d |  | Lot 03 : Chauffage, climatisation, ventilation, plomberie | 7h |
| 346 | 6.2.2 | Réception Phase 1 | 1d | 2027-02-03 | 2027-02-03 | 285, 306, 324 | 360d | 0d | Lot 01 : Courants forts; Lot 02 : Courants faibles; Lot 03 : Chauffage, climatisation, ventilation, plomberie; Lot 06 : Paillasses, matériel de laboratoire; Lot 07 : Sols souples, protections murales; Lot 08 : Curage, démolitions, platrerie, peinture, faux-plafonds; Lot 09 : Menuiseries extérieures, cloisons vitrées, protections solaires | 49h |
| 347 | 6.2.3 | **Déménagement de fin de phase 1 (Etalonnage pipettes / Agent Péri. / Salle de pause / Maud / FF)** | 2d | 2027-02-04 | 2027-02-05 |  | 360d | 0d |  | 154h |
| 348 | 6.2.3.1 | Nettoyage avant installation installation | 1d | 2027-02-04 | 2027-02-04 | 346 | 360d | 0d | Prestataire entretien des locaux | 7h |
| 349 | 6.2.3.2 | 11101-10_0004 (MD) vers 11103-10_0012 vers ? | 1d | 2027-02-05 | 2027-02-05 | 348 | 360d |  | Déménagement externe; Déménagement interne; Direction du laboratoire | 21h |
| 350 | 6.2.3.3 | 11101-10_0005 (FF) vers 11101-10_0061 ? | 1d | 2027-02-05 | 2027-02-05 | 348 | 360d |  | Déménagement externe; Déménagement interne; Direction du laboratoire | 21h |
| 351 | 6.2.3.4 | 11101-10_0010 (Pipettes) vers 11101-10_0007 | 1d | 2027-02-05 | 2027-02-05 | 348 | 360d |  | Déménagement externe; Déménagement interne; Direction du laboratoire | 21h |
| 352 | 6.2.3.5 | 11101-10_0014 (Biomed) vers 11101-10_0006 / 62 Transitoirement ? | 1d | 2027-02-05 | 2027-02-05 | 348 | 360d |  | Déménagement externe; Déménagement interne; Direction du laboratoire | 21h |
| 353 | 6.2.3.6 | 11101-10_0025 (Stk Biomed) vers 11101-10_0006 | 1d | 2027-02-05 | 2027-02-05 | 348 | 360d |  | Déménagement externe; Déménagement interne; Direction du laboratoire | 21h |
| 354 | 6.2.3.7 | 11101-10_0054 (Peri) vers 11101-10_0052 | 1d | 2027-02-05 | 2027-02-05 | 348 | 360d |  | Déménagement externe; Déménagement interne; Direction du laboratoire | 21h |
| 355 | 6.2.3.8 | 11101-10_0055 vers 11101-10_0001 (détente) | 1d | 2027-02-05 | 2027-02-05 | 348 | 360d |  | Déménagement externe; Déménagement interne; Direction du laboratoire | 21h |

| ID | WBS | Task | Duration | Start | Finish | Predecessors | Total slack | Free slack | Resources | Work |
| --- | --- | --- | --- | --- | --- | --- | --- | --- | --- | --- |
| 356 | 6.2.4 | **SP06 - RDC - Phase 2** | 41.5d | 2027-02-08 | 2027-04-07 |  | 360d | 0d |  | 1008h |
| 357 | 6.2.4.1 | **Pièces 11101-10_0003, 04, 05, 08, 09, 10, 54, 55 et 69** | 41.5d | 2027-02-08 | 2027-04-07 |  | 360d |  |  | 759.5h |
| 358 | 6.2.4.1.1 | Consignation | 0.5d | 2027-02-08 | 2027-02-08 | 347 | 360d | 0d | Services techniques | 3.5h |
| 359 | 6.2.4.1.2 | Dépose équipements CFO | 2d | 2027-02-08 | 2027-02-10 | 358 | 360d | 0d | Lot 01 : Courants forts | 14h |
| 360 | 6.2.4.1.3 | Dépose équipements CFA | 2d | 2027-02-08 | 2027-02-10 | 358 | 360d | 0d | Lot 02 : Courants faibles | 14h |
| 361 | 6.2.4.1.4 | Dépose équipements CFC | 2d | 2027-02-08 | 2027-02-10 | 358 | 360d | 0d | Lot 03 : Chauffage, climatisation, ventilation, plomberie | 14h |
| 362 | 6.2.4.1.5 | Dépose radiateurs, éléments de plomberie | 2d | 2027-02-08 | 2027-02-10 | 358 | 360d | 0d | Lot 03 : Chauffage, climatisation, ventilation, plomberie | 14h |
| 363 | 6.2.4.1.6 | Dépose faux-plafond, curage sol et dépose cloison | 5d | 2027-02-10 | 2027-02-17 | 359, 361, 362, 360 | 360d | 0d | Lot 08 : Curage, démolitions, platrerie, peinture, faux-plafonds | 35h |
| 364 | 6.2.4.1.7 | Cloisons neuves | 10d | 2027-02-17 | 2027-03-03 | 363 | 360d | 0d | Lot 08 : Curage, démolitions, platrerie, peinture, faux-plafonds | 70h |
| 365 | 6.2.4.1.8 | Pose nouveaux réseaux CFO | 10d | 2027-02-19 | 2027-03-05 | 364SS+2d | 360d | 0d | Lot 01 : Courants forts | 70h |
| 366 | 6.2.4.1.9 | Pose nouveaux réseaux CFA | 10d | 2027-02-19 | 2027-03-05 | 364SS+2d | 360d | 0d | Lot 02 : Courants faibles | 70h |
| 367 | 6.2.4.1.10 | Pose nouveaux réseaux CVC | 10d | 2027-02-19 | 2027-03-05 | 364SS+2d | 360d | 0d | Lot 03 : Chauffage, climatisation, ventilation, plomberie | 70h |
| 368 | 6.2.4.1.11 | Pose faux plafonds neuf | 10d | 2027-03-05 | 2027-03-19 | 364, 365, 367, 366 | 360d | 0d | Lot 08 : Curage, démolitions, platrerie, peinture, faux-plafonds | 70h |
| 369 | 6.2.4.1.12 | Pose équipements CFO | 5d | 2027-03-09 | 2027-03-16 | 368SS+2d | 367d | 7d | Lot 01 : Courants forts | 35h |
| 370 | 6.2.4.1.13 | Pose équipements CFA | 5d | 2027-03-09 | 2027-03-16 | 368SS+2d | 367d | 7d | Lot 02 : Courants faibles | 35h |
| 371 | 6.2.4.1.14 | Pose équipements CVC | 5d | 2027-03-09 | 2027-03-16 | 368SS+2d | 367d | 7d | Lot 02 : Courants faibles | 35h |
| 372 | 6.2.4.1.15 | Finitions murales | 10d | 2027-03-11 | 2027-03-25 | 368SS+4d | 360d | 0d | Lot 08 : Curage, démolitions, platrerie, peinture, faux-plafonds | 70h |
| 373 | 6.2.4.1.16 | Peinture radiateurs | 10d | 2027-03-11 | 2027-03-25 | 368SS+4d | 368d |  | Lot 08 : Curage, démolitions, platrerie, peinture, faux-plafonds | 70h |
| 374 | 6.2.4.1.17 | Pose stores | 2d | 2027-03-25 | 2027-03-30 | 368, 369, 371, 372, 370 | 360d | 0d | Lot 09 : Menuiseries extérieures, cloisons vitrées, protections solaires | 14h |
| 375 | 6.2.4.1.18 | Repose radiateurs | 2d | 2027-03-25 | 2027-03-30 | 368, 369, 371, 372, 370 | 360d | 0d | Lot 03 : Chauffage, climatisation, ventilation, plomberie | 14h |
| 376 | 6.2.4.1.19 | Pose sol | 5d | 2027-03-30 | 2027-04-06 | 374, 375 | 360d | 0d | Lot 07 : Sols souples, protections murales | 35h |
| 377 | 6.2.4.1.20 | Installation paillasses | 1d | 2027-04-06 | 2027-04-07 | 376 | 360d |  | Lot 06 : Paillasses, matériel de laboratoire | 7h |
| 378 | 6.2.4.2 | **Pièces 11101-14, 25** | 15d | 2027-02-08 | 2027-02-26 |  | 383.5d | 0d |  | 171.5h |
| 379 | 6.2.4.2.1 | Consignation | 0.5d | 2027-02-08 | 2027-02-08 | 347 | 383.5d | 0d | Services techniques | 3.5h |
| 380 | 6.2.4.2.2 | Dépose équipements CFO | 0.5d | 2027-02-08 | 2027-02-08 | 379 | 383.5d | 0d | Lot 01 : Courants forts | 3.5h |
| 381 | 6.2.4.2.3 | Dépose équipements CFA | 0.5d | 2027-02-08 | 2027-02-08 | 379 | 383.5d | 0d | Lot 02 : Courants faibles | 3.5h |
| 382 | 6.2.4.2.4 | Dépose équipements CVC | 0.5d | 2027-02-08 | 2027-02-08 | 379 | 383.5d | 0d | Lot 03 : Chauffage, climatisation, ventilation, plomberie | 3.5h |
| 383 | 6.2.4.2.5 | Dépose radiateurs, éléments de plomberie | 0.5d | 2027-02-08 | 2027-02-08 | 379 | 383.5d | 0d | Lot 03 : Chauffage, climatisation, ventilation, plomberie | 3.5h |
| 384 | 6.2.4.2.6 | Dépose faux-plafond | 1d | 2027-02-09 | 2027-02-09 | 380, 382, 383, 381 | 383.5d | 0d | Lot 08 : Curage, démolitions, platrerie, peinture, faux-plafonds | 7h |
| 385 | 6.2.4.2.7 | Depose éléments vitrés ext. | 1d | 2027-02-09 | 2027-02-09 | 384SS | 396.5d |  | Lot 09 : Menuiseries extérieures, cloisons vitrées, protections solaires | 7h |
| 386 | 6.2.4.2.8 | Pose porte vitrée exterieur | 2d | 2027-02-10 | 2027-02-11 | 384 | 394.5d |  | Lot 09 : Menuiseries extérieures, cloisons vitrées, protections solaires | 14h |
| 387 | 6.2.4.2.9 | Ouverture voile beton | 2d | 2027-02-10 | 2027-02-11 | 384 | 383.5d | 0d | Lot 08 : Curage, démolitions, platrerie, peinture, faux-plafonds | 14h |
| 388 | 6.2.4.2.10 | Cloisons neuves | 3d | 2027-02-12 | 2027-02-16 | 387 | 383.5d | 0d | Lot 08 : Curage, démolitions, platrerie, peinture, faux-plafonds | 21h |
| 389 | 6.2.4.2.11 | Pose nouveaux réseaux CFO | 1d | 2027-02-12 | 2027-02-12 | 387 | 385.5d | 2d | Lot 01 : Courants forts | 7h |
| 390 | 6.2.4.2.12 | Pose nouveaux réseaux CFA | 1d | 2027-02-12 | 2027-02-12 | 387 | 385.5d | 2d | Lot 02 : Courants faibles | 7h |
| 391 | 6.2.4.2.13 | Pose nouveaux réseaux CVC | 1d | 2027-02-12 | 2027-02-12 | 387 | 385.5d | 2d | Lot 03 : Chauffage, climatisation, ventilation, plomberie | 7h |
| 392 | 6.2.4.2.14 | Pose faux plafonds neuf | 2d | 2027-02-17 | 2027-02-18 | 388, 389, 391, 390 | 383.5d | 0d | Lot 08 : Curage, démolitions, platrerie, peinture, faux-plafonds | 14h |
| 393 | 6.2.4.2.15 | Pose équipements CFO | 1d | 2027-02-19 | 2027-02-19 | 392 | 383.5d | 0d | Lot 01 : Courants forts | 7h |
| 394 | 6.2.4.2.16 | Pose équipements CFA | 1d | 2027-02-19 | 2027-02-19 | 392 | 383.5d | 0d | Lot 02 : Courants faibles | 7h |
| 395 | 6.2.4.2.17 | Pose équipements CVC | 1d | 2027-02-19 | 2027-02-19 | 392 | 383.5d | 0d | Lot 03 : Chauffage, climatisation, ventilation, plomberie | 7h |
| 396 | 6.2.4.2.18 | Finitions murales | 2d | 2027-02-22 | 2027-02-23 | 393, 395, 394 | 383.5d | 0d | Lot 08 : Curage, démolitions, platrerie, peinture, faux-plafonds | 14h |
| 397 | 6.2.4.2.19 | Repose radiateurs | 1d | 2027-02-24 | 2027-02-24 | 396 | 383.5d | 0d | Lot 03 : Chauffage, climatisation, ventilation, plomberie | 7h |
| 398 | 6.2.4.2.20 | Pose sol | 2d | 2027-02-25 | 2027-02-26 | 397 | 383.5d |  | Lot 07 : Sols souples, protections murales | 14h |
| 399 | 6.2.4.3 | réception phase 2 - RDC | 1d | 2027-03-01 | 2027-03-01 | 378 | 383.5d | 0d | Lot 01 : Courants forts; Lot 02 : Courants faibles; Lot 03 : Chauffage, climatisation, ventilation, plomberie; Lot 06 : Paillasses, matériel de laboratoire; Lot 07 : Sols souples, protections murales; Lot 08 : Curage, démolitions, platrerie, peinture, faux-plafonds; Lot 09 : Menuiseries extérieures, cloisons vitrées, protections solaires | 49h |
| 400 | 6.2.4.4 | Nettoyage avant installation installation | 1d | 2027-03-02 | 2027-03-02 | 399 | 383.5d | 0d | Prestataire entretien des locaux | 7h |
| 401 | 6.2.4.5 | 11101-10_0062 ? (BioMed T) vers 11101-10_0014 | 1d | 2027-03-03 | 2027-03-03 | 400 | 383.5d |  | Déménagement externe; Déménagement interne; Direction du laboratoire | 21h |
| 402 | 6.2.5 | réception phase 2 - RDC | 1d | 2027-04-07 | 2027-04-08 | 356 | 360d | 0d | Lot 01 : Courants forts; Lot 02 : Courants faibles; Lot 03 : Chauffage, climatisation, ventilation, plomberie; Lot 06 : Paillasses, matériel de laboratoire; Lot 07 : Sols souples, protections murales; Lot 08 : Curage, démolitions, platrerie, peinture, faux-plafonds; Lot 09 : Menuiseries extérieures, cloisons vitrées, protections solaires | 49h |

| ID | WBS | Task | Duration | Start | Finish | Predecessors | Total slack | Free slack | Resources | Work |
| --- | --- | --- | --- | --- | --- | --- | --- | --- | --- | --- |
| 403 | 6.2.6 | **Déménagements de fin de phase 2 bureau FF ? 4ème Bât A ? UHH CPIAS** | 2d | 2027-04-08 | 2027-04-12 |  | 360d |  |  | 238h |
| 404 | 6.2.6.1 | Nettoyage avant installation installation | 1d | 2027-04-08 | 2027-04-09 | 402 | 360d | 0d | Prestataire entretien des locaux | 7h |
| 405 | 6.2.6.2 | 11101-10_0061 (FF) vers 11101-14 ? | 1d | 2027-04-09 | 2027-04-12 | 404 | 360d |  | Déménagement externe; Déménagement interne; Direction du laboratoire | 21h |
| 406 | 6.2.6.3 | 11101-16_0044 (Métrologie) vers 11101-10_0008 | 1d | 2027-04-09 | 2027-04-12 | 404 | 360d |  | Déménagement externe; Déménagement interne; Direction du laboratoire | 21h |
| 407 | 6.2.6.4 | 11101-16_0024 (IDE) vers 11101-10_0003 | 1d | 2027-04-09 | 2027-04-12 | 404 | 360d |  | Déménagement externe; Déménagement interne; Direction du laboratoire | 21h |
| 408 | 6.2.6.5 | 11101-16_0025 (IDE) vers 11101-10_0003 | 1d | 2027-04-09 | 2027-04-12 | 404 | 360d |  | Déménagement externe; Déménagement interne; Direction du laboratoire | 21h |
| 409 | 6.2.6.6 | 11101-16_0020 (Chef Service) vers 11101-10_0004 | 1d | 2027-04-09 | 2027-04-12 | 404 | 360d |  | Déménagement externe; Déménagement interne; Direction du laboratoire | 21h |
| 410 | 6.2.6.7 | 11101-16_0022 (Bur. Med.) vers 11101-10_0005 | 1d | 2027-04-09 | 2027-04-12 | 404 | 360d |  | Déménagement externe; Déménagement interne; Direction du laboratoire | 21h |
| 411 | 6.2.6.8 | 11101-16_00 (Stk UHH) vers 11101-10_0009 | 1d | 2027-04-09 | 2027-04-12 | 404 | 360d |  | Déménagement externe; Déménagement interne; Direction du laboratoire | 21h |
| 412 | 6.2.6.9 | 11101-16_0023 (Bur. Med.) vers 11101-10_0054 | 1d | 2027-04-09 | 2027-04-12 | 404 | 360d |  | Déménagement externe; Déménagement interne; Direction du laboratoire | 21h |
| 413 | 6.2.6.10 | 11101-16_0021 (Secrét.) vers 11101-10_0055 | 1d | 2027-04-09 | 2027-04-12 | 404 | 360d |  | Déménagement externe; Déménagement interne; Direction du laboratoire | 21h |
| 414 | 6.2.6.11 | 11103-16_0004 (Bur. Med.) vers 11103-10_0061 | 1d | 2027-04-09 | 2027-04-12 | 404 | 360d |  | Déménagement externe; Déménagement interne; Direction du laboratoire | 21h |
| 415 | 6.2.6.12 | 11103-16_0001 (Secrét.) vers 11103-10_0062 | 1d | 2027-04-09 | 2027-04-12 | 404 | 360d |  | Déménagement externe; Déménagement interne; Direction du laboratoire | 21h |
| 416 | 6.3 | **4e étage** | 371.5d | 2026-09-15 | 2028-02-29 |  | 55.5d |  |  | 9814h |
| 417 | 6.3.1 | **SP06 - 4ème - Phase 1** | 54d | 2026-12-02 | 2027-02-18 |  | 0d |  |  | 2019.5h |
| 418 | 6.3.1.1 | **Déménagements** | 2d | 2026-12-02 | 2026-12-04 |  | 0d |  |  | 224h |
| 419 | 6.3.1.1.1 | 11101-14_0014 vers ? | 2d | 2026-12-02 | 2026-12-04 | 3 | 0d |  | Déménagement externe; Déménagement interne | 28h |
| 420 | 6.3.1.1.2 | 11101-14_0015 vers ? | 2d | 2026-12-02 | 2026-12-04 | 3 | 0d |  | Déménagement externe; Déménagement interne | 28h |
| 421 | 6.3.1.1.3 | 11101-14_0016 vers ? | 2d | 2026-12-02 | 2026-12-04 | 3 | 0d |  | Déménagement externe; Déménagement interne | 28h |
| 422 | 6.3.1.1.4 | 11101-14_0007 vers ? | 2d | 2026-12-02 | 2026-12-04 | 3 | 0d |  | Déménagement externe; Déménagement interne | 28h |
| 423 | 6.3.1.1.5 | 11101-14_0028 vers ? | 2d | 2026-12-02 | 2026-12-04 | 3 | 0d |  | Déménagement externe; Déménagement interne | 28h |
| 424 | 6.3.1.1.6 | 11101-14_0031 (paillasse) vers ? | 2d | 2026-12-02 | 2026-12-04 | 3 | 0d |  | Déménagement externe; Déménagement interne | 28h |
| 425 | 6.3.1.1.7 | 11101-14_0032 vers ? | 2d | 2026-12-02 | 2026-12-04 | 3 | 0d |  | Déménagement externe; Déménagement interne | 28h |
| 426 | 6.3.1.1.8 | 11101-14_0034 vers ? | 2d | 2026-12-02 | 2026-12-04 | 3 | 0d |  | Déménagement externe; Déménagement interne | 28h |

| ID | WBS | Task | Duration | Start | Finish | Predecessors | Total slack | Resources | Work |
| --- | --- | --- | --- | --- | --- | --- | --- | --- | --- |
| 427 | 6.3.1.2 | **Phase 1.1** | 22.5d | 2026-12-04 | 2027-01-07 |  | 0d |  | 325.5h |
| 428 | 6.3.1.2.1 | **Pièces 11101-14_0014 (création 14 et 14bis), 15 et 16** | 22.5d | 2026-12-04 | 2027-01-07 |  | 0d |  | 325.5h |
| 429 | 6.3.1.2.1.1 | Neutralisation réseaux (consignations) | 0.5d | 2026-12-04 | 2026-12-04 | 418 | 0d | Services techniques | 3.5h |
| 430 | 6.3.1.2.1.2 | Déconnexion paillasse plomberie, dépose équipements de plomberie et CVC | 2d | 2026-12-07 | 2026-12-08 | 429 | 0d | Lot 03 : Chauffage, climatisation, ventilation, plomberie | 14h |
| 431 | 6.3.1.2.1.3 | Déconnexion paillasse CFO et luminaires | 2d | 2026-12-07 | 2026-12-08 | 429 | 0d | Lot 01 : Courants forts | 14h |
| 432 | 6.3.1.2.1.4 | Déconnexion paillasse CFA | 2d | 2026-12-07 | 2026-12-08 | 429 | 0d | Lot 02 : Courants faibles | 14h |
| 433 | 6.3.1.2.1.5 | Dépose sorbonne | 1d | 2026-12-07 | 2026-12-07 | 429 | 21d | Lot 06 : Paillasses, matériel de laboratoire | 7h |
| 434 | 6.3.1.2.1.6 | Renforts cloisons et dépose plafonds | 2d | 2026-12-07 | 2026-12-08 | 429 | 2d | Lot 10 : Cloisons et plafonds agroalimentaires | 14h |
| 435 | 6.3.1.2.1.7 | Enlèvement paillasse | 2d | 2026-12-09 | 2026-12-10 | 430, 431, 432 | 0d | Lot 08 : Curage, démolitions, platrerie, peinture, faux-plafonds | 14h |
| 436 | 6.3.1.2.1.8 | Curage FP, Sol, création d'ouverture cloisons | 3d | 2026-12-11 | 2026-12-15 | 435, 434 | 0d | Lot 08 : Curage, démolitions, platrerie, peinture, faux-plafonds | 21h |
| 437 | 6.3.1.2.1.9 | Création de cloison | 3d | 2026-12-16 | 2026-12-18 | 436 | 0d | Lot 10 : Cloisons et plafonds agroalimentaires | 21h |
| 438 | 6.3.1.2.1.10 | Réseaux neufs CFO | 3d | 2026-12-16 | 2026-12-18 | 436 | 0d | Lot 01 : Courants forts | 21h |
| 439 | 6.3.1.2.1.11 | Réseaux neufs CFA | 3d | 2026-12-16 | 2026-12-18 | 436 | 0d | Lot 02 : Courants faibles | 21h |
| 440 | 6.3.1.2.1.12 | Réseaux neufs CVC, plomberie | 3d | 2026-12-16 | 2026-12-18 | 436 | 0d | Lot 03 : Chauffage, climatisation, ventilation, plomberie | 21h |
| 441 | 6.3.1.2.1.13 | Cloisons et portes vitrées | 3d | 2026-12-16 | 2026-12-18 | 436 | 0d | Lot 09 : Menuiseries extérieures, cloisons vitrées, protections solaires | 21h |
| 442 | 6.3.1.2.1.14 | Pose plafonds agro | 3d | 2026-12-21 | 2026-12-23 | 437, 438, 439, 440, 441 | 0d | Lot 10 : Cloisons et plafonds agroalimentaires | 21h |
| 443 | 6.3.1.2.1.15 | Finitions murales | 2d | 2026-12-24 | 2026-12-28 | 442 | 0d | Lot 07 : Sols souples, protections murales | 14h |
| 444 | 6.3.1.2.1.16 | Pose équipement CFO | 2d | 2026-12-29 | 2026-12-30 | 443 | 0d | Lot 01 : Courants forts | 14h |
| 445 | 6.3.1.2.1.17 | Pose équipements CVC | 2d | 2026-12-29 | 2026-12-30 | 443 | 0d | Lot 03 : Chauffage, climatisation, ventilation, plomberie | 14h |
| 446 | 6.3.1.2.1.18 | Pose équipements CFA | 2d | 2026-12-29 | 2026-12-30 | 443 | 0d | Lot 02 : Courants faibles | 14h |
| 447 | 6.3.1.2.1.19 | Pose sol | 3d | 2026-12-31 | 2027-01-05 | 444, 445, 446 | 0d | Lot 07 : Sols souples, protections murales | 21h |
| 448 | 6.3.1.2.1.20 | Installation paillasses | 2d | 2027-01-06 | 2027-01-07 | 447 | 0d | Lot 06 : Paillasses, matériel de laboratoire | 14h |
| 449 | 6.3.1.2.1.21 | Repose sorbonne | 1d | 2027-01-06 | 2027-01-06 | 447 | 1d | Lot 06 : Paillasses, matériel de laboratoire | 7h |
| 450 | 6.3.1.3 | Réception phase 1.1 | 3d | 2027-01-08 | 2027-01-12 | 427 | 0d | Lot 01 : Courants forts; Lot 02 : Courants faibles; Lot 03 : Chauffage, climatisation, ventilation, plomberie; Lot 06 : Paillasses, matériel de laboratoire; Lot 07 : Sols souples, protections murales; Lot 08 : Curage, démolitions, platrerie, peinture, faux-plafonds; Lot 09 : Menuiseries extérieures, cloisons vitrées, protections solaires; Lot 10 : Cloisons et plafonds agroalimentaires | 168h |

| ID | WBS | Task | Duration | Start | Finish | Predecessors | Total slack | Free slack | Resources | Work |
| --- | --- | --- | --- | --- | --- | --- | --- | --- | --- | --- |
| 451 | 6.3.1.4 | **Déménagements** | 3d | 2027-01-13 | 2027-01-15 |  | 0d |  |  | 119h |
| 452 | 6.3.1.4.1 | Nettoyage avant installation installation (14/14b/15/15b/16) | 1d | 2027-01-13 | 2027-01-13 | 450 | 0d |  | Prestataire entretien des locaux | 7h |
| 453 | 6.3.1.4.2 | 11101-14_0011 vers 11101-11_0015b | 1d | 2027-01-14 | 2027-01-14 | 452 | 1d |  | Déménagement externe; Déménagement interne | 14h |
| 454 | 6.3.1.4.3 | 11101-14_0012 vers 11101-11_0014b | 1d | 2027-01-14 | 2027-01-14 | 452 | 1d |  | Déménagement externe; Déménagement interne | 14h |
| 455 | 6.3.1.4.4 | ? Vers 11101-14_0014 | 2d | 2027-01-14 | 2027-01-15 | 452 | 0d |  | Déménagement externe; Déménagement interne | 28h |
| 456 | 6.3.1.4.5 | ? Vers 11101-14_0015 | 2d | 2027-01-14 | 2027-01-15 | 452 | 0d |  | Déménagement externe; Déménagement interne | 28h |
| 457 | 6.3.1.4.6 | ? Vers 11101-14_0016 | 2d | 2027-01-14 | 2027-01-15 | 452 | 0d |  | Déménagement externe; Déménagement interne | 28h |
| 458 | 6.3.1.5 | **Phase 1.2** | 50.5d | 2026-12-04 | 2027-02-16 |  | 0.5d |  |  | 892.5h |
| 459 | 6.3.1.5.1 | **Pièces 11101-14_07, 28, 31, 32 et 34** | 50.5d | 2026-12-04 | 2027-02-16 |  | 0.5d |  |  | 731.5h |
| 460 | 6.3.1.5.1.1 | Neutralisation réseaux (consignations) | 0.5d | 2026-12-04 | 2026-12-04 | 418 | 0.5d | 0d | Services techniques | 3.5h |
| 461 | 6.3.1.5.1.2 | Déconnexion pneumatique | 1d | 2026-12-04 | 2026-12-07 | 418 | 50d |  | Lot 01 : Courants forts | 7h |
| 462 | 6.3.1.5.1.3 | Création d'une cloison de séparation temporaire dans la pièce 4B31 | 2d | 2026-12-07 | 2026-12-08 | 460 | 48.5d |  | Lot 08 : Curage, démolitions, platrerie, peinture, faux-plafonds | 14h |
| 463 | 6.3.1.5.1.4 | Déconnexion paillasse plomberie, dépose équipements de plomberie et CVC | 2d | 2026-12-07 | 2026-12-08 | 460 | 0.5d | 0d | Lot 03 : Chauffage, climatisation, ventilation, plomberie | 14h |
| 464 | 6.3.1.5.1.5 | Déconnexion paillasse et sorbonne CFO et luminaires | 2d | 2026-12-07 | 2026-12-08 | 460 | 0.5d | 0d | Lot 01 : Courants forts | 14h |
| 465 | 6.3.1.5.1.6 | Déconnexion paillasse et sorbonne CFA | 2d | 2026-12-07 | 2026-12-08 | 460 | 0.5d | 0d | Lot 02 : Courants faibles | 14h |
| 466 | 6.3.1.5.1.7 | Renforts plafond | 2d | 2026-12-07 | 2026-12-08 | 460 | 3.5d | 3d | Lot 10 : Cloisons et plafonds agroalimentaires | 14h |
| 467 | 6.3.1.5.1.8 | Dépose Sorbonne | 1d | 2026-12-09 | 2026-12-09 | 463, 464, 465 | 47.5d |  | Lot 08 : Curage, démolitions, platrerie, peinture, faux-plafonds | 7h |
| 468 | 6.3.1.5.1.9 | Enlèvement paillasse | 3d | 2026-12-09 | 2026-12-11 | 463, 464, 465 | 0.5d | 0d | Lot 08 : Curage, démolitions, platrerie, peinture, faux-plafonds | 21h |
| 469 | 6.3.1.5.1.10 | Curage FP, Sol, création d'ouverture cloisons | 5d | 2026-12-14 | 2026-12-18 | 466, 468 | 0.5d | 0d | Lot 08 : Curage, démolitions, platrerie, peinture, faux-plafonds | 35h |
| 470 | 6.3.1.5.1.11 | Création de cloison et étoupements | 5d | 2026-12-21 | 2026-12-28 | 469 | 5.5d | 5d | Lot 10 : Cloisons et plafonds agroalimentaires | 35h |
| 471 | 6.3.1.5.1.12 | Crétion niche de stockage dans couloir central | 2d | 2026-12-21 | 2026-12-22 | 469 | 38.5d |  | Lot 08 : Curage, démolitions, platrerie, peinture, faux-plafonds | 14h |
| 472 | 6.3.1.5.1.13 | Intallation chambre froide | 5d | 2026-12-21 | 2026-12-28 | 469 | 5.5d | 5d | Lot 03 : Chauffage, climatisation, ventilation, plomberie | 35h |
| 473 | 6.3.1.5.1.14 | Réseaux neufs CFO | 10d | 2026-12-21 | 2027-01-05 | 469 | 0.5d | 0d | Lot 01 : Courants forts | 70h |
| 474 | 6.3.1.5.1.15 | Réseaux neufs CFA | 10d | 2026-12-21 | 2027-01-05 | 469 | 0.5d | 0d | Lot 02 : Courants faibles | 70h |
| 475 | 6.3.1.5.1.16 | Réseaux neufs CVC, plomberie | 10d | 2026-12-21 | 2027-01-05 | 469 | 0.5d | 0d | Lot 03 : Chauffage, climatisation, ventilation, plomberie | 70h |
| 476 | 6.3.1.5.1.17 | Cloisons et portes vitrées | 5d | 2026-12-21 | 2026-12-28 | 469 | 5.5d | 5d | Lot 09 : Menuiseries extérieures, cloisons vitrées, protections solaires | 35h |
| 477 | 6.3.1.5.1.18 | Pose FP | 5d | 2027-01-06 | 2027-01-12 | 470, 473, 474, 475, 476, 472 | 0.5d | 0d | Lot 08 : Curage, démolitions, platrerie, peinture, faux-plafonds | 35h |
| 478 | 6.3.1.5.1.19 | Installation porte automatisée | 2d | 2027-01-13 | 2027-01-14 | 477 | 23.5d |  | Lot 05 : Portes automatiques | 14h |
| 479 | 6.3.1.5.1.20 | Finitions murales | 5d | 2027-01-13 | 2027-01-19 | 477 | 0.5d | 0d | Lot 07 : Sols souples, protections murales | 35h |
| 480 | 6.3.1.5.1.21 | Pose équipements CVC | 5d | 2027-01-20 | 2027-01-26 | 479 | 0.5d | 0d | Lot 03 : Chauffage, climatisation, ventilation, plomberie | 35h |
| 481 | 6.3.1.5.1.22 | Pose sol | 5d | 2027-01-27 | 2027-02-02 | 480, 479 | 0.5d | 0d | Lot 07 : Sols souples, protections murales | 35h |
| 482 | 6.3.1.5.1.23 | Installation paillasses | 5d | 2027-02-03 | 2027-02-09 | 481 | 0.5d | 0d | Lot 06 : Paillasses, matériel de laboratoire | 35h |
| 483 | 6.3.1.5.1.24 | Pose équipement CFO | 5d | 2027-02-10 | 2027-02-16 | 482 | 0.5d |  | Lot 01 : Courants forts | 35h |
| 484 | 6.3.1.5.1.25 | Pose équipements CFA | 5d | 2027-02-10 | 2027-02-16 | 482 | 0.5d |  | Lot 02 : Courants faibles | 35h |

| ID | WBS | Task | Duration | Start | Finish | Predecessors | Total slack | Free slack | Resources | Work |
| --- | --- | --- | --- | --- | --- | --- | --- | --- | --- | --- |
| 485 | 6.3.1.5.2 | **Pièce 11103-14_0001 et 10** | 13.5d | 2026-12-04 | 2026-12-23 |  | 37.5d |  |  | 143.5h |
| 486 | 6.3.1.5.2.1 | Consignation | 0.5d | 2026-12-04 | 2026-12-04 | 418 | 37.5d | 0d | Services techniques | 3.5h |
| 487 | 6.3.1.5.2.2 | Dépose CFO et luminaires | 1d | 2026-12-07 | 2026-12-07 | 486 | 37.5d | 0d | Lot 01 : Courants forts | 7h |
| 488 | 6.3.1.5.2.3 | Dépose CFA | 1d | 2026-12-07 | 2026-12-07 | 486 | 37.5d | 0d | Lot 02 : Courants faibles | 7h |
| 489 | 6.3.1.5.2.4 | Dépose CVC | 1d | 2026-12-07 | 2026-12-07 | 486 | 37.5d | 0d | Lot 03 : Chauffage, climatisation, ventilation, plomberie | 7h |
| 490 | 6.3.1.5.2.5 | Curage FP, Sol, création d'ouverture cloisons | 2d | 2026-12-08 | 2026-12-09 | 487, 488, 489 | 37.5d | 0d | Lot 08 : Curage, démolitions, platrerie, peinture, faux-plafonds | 14h |
| 491 | 6.3.1.5.2.6 | Réseaux neufs CFO | 2d | 2026-12-10 | 2026-12-11 | 490 | 37.5d | 0d | Lot 01 : Courants forts | 14h |
| 492 | 6.3.1.5.2.7 | Réseaux neufs CFA | 2d | 2026-12-10 | 2026-12-11 | 490 | 37.5d | 0d | Lot 02 : Courants faibles | 14h |
| 493 | 6.3.1.5.2.8 | Réseaux neufs CVC, plomberie | 2d | 2026-12-10 | 2026-12-11 | 490 | 37.5d | 0d | Lot 03 : Chauffage, climatisation, ventilation, plomberie | 14h |
| 494 | 6.3.1.5.2.9 | Finitions murales | 5d | 2026-12-14 | 2026-12-18 | 491, 492, 493, 487, 488, 489 | 37.5d | 0d | Lot 07 : Sols souples, protections murales | 35h |
| 495 | 6.3.1.5.2.10 | Pose sol | 2d | 2026-12-21 | 2026-12-22 | 494 | 37.5d | 0d | Lot 07 : Sols souples, protections murales | 14h |
| 496 | 6.3.1.5.2.11 | Pose équipement CFO | 1d | 2026-12-23 | 2026-12-23 | 495 | 37.5d |  | Lot 01 : Courants forts | 7h |
| 497 | 6.3.1.5.2.12 | Pose équipements CFA | 1d | 2026-12-23 | 2026-12-23 | 495 | 37.5d |  | Lot 02 : Courants faibles | 7h |
| 498 | 6.3.1.5.3 | **Pièce 11103-14_0005** | 1.5d | 2026-12-04 | 2026-12-07 |  | 49.5d |  |  | 17.5h |
| 499 | 6.3.1.5.3.1 | Consignation | 0.5d | 2026-12-04 | 2026-12-04 | 418 | 49.5d | 0d | Services techniques | 3.5h |
| 500 | 6.3.1.5.3.2 | Ajout CFO | 1d | 2026-12-07 | 2026-12-07 | 499 | 49.5d |  | Lot 01 : Courants forts | 7h |
| 501 | 6.3.1.5.3.3 | Ajout CFA | 1d | 2026-12-07 | 2026-12-07 | 499 | 49.5d |  | Lot 02 : Courants faibles | 7h |
| 502 | 6.3.1.6 | **Phase 1.3** | 22.5d | 2027-01-18 | 2027-02-17 |  | 0d |  |  | 290.5h |
| 503 | 6.3.1.6.1 | **Pièces 11101-14_0011, 12** | 22.5d | 2027-01-18 | 2027-02-17 |  | 0d |  |  | 290.5h |
| 504 | 6.3.1.6.1.1 | Neutralisation réseaux (consignations) | 0.5d | 2027-01-18 | 2027-01-18 | 451 | 0d |  | Services techniques | 3.5h |
| 505 | 6.3.1.6.1.2 | Déconnexion paillasse plomberie, dépose équipements de plomberie et CVC | 2d | 2027-01-18 | 2027-01-20 | 504 | 0d |  | Lot 03 : Chauffage, climatisation, ventilation, plomberie | 14h |
| 506 | 6.3.1.6.1.3 | Déconnexion paillasse CFO et luminaires | 2d | 2027-01-18 | 2027-01-20 | 504 | 0d |  | Lot 01 : Courants forts | 14h |
| 507 | 6.3.1.6.1.4 | Déconnexion paillasse CFA | 2d | 2027-01-18 | 2027-01-20 | 504 | 0d |  | Lot 02 : Courants faibles | 14h |
| 508 | 6.3.1.6.1.5 | Renfort plafonds | 2d | 2027-01-18 | 2027-01-20 | 504 | 2d |  | Lot 10 : Cloisons et plafonds agroalimentaires | 14h |
| 509 | 6.3.1.6.1.6 | Enlèvement paillasse | 2d | 2027-01-20 | 2027-01-22 | 505, 506, 507 | 0d |  | Lot 08 : Curage, démolitions, platrerie, peinture, faux-plafonds | 14h |
| 510 | 6.3.1.6.1.7 | Curage FP, Sol, création d'ouverture cloisons | 3d | 2027-01-22 | 2027-01-27 | 508, 509 | 0d |  | Lot 08 : Curage, démolitions, platrerie, peinture, faux-plafonds | 21h |
| 511 | 6.3.1.6.1.8 | Création de cloison | 3d | 2027-01-27 | 2027-02-01 | 510 | 0d |  | Lot 10 : Cloisons et plafonds agroalimentaires | 21h |
| 512 | 6.3.1.6.1.9 | Réseaux neufs CFO | 3d | 2027-01-27 | 2027-02-01 | 510 | 0d |  | Lot 01 : Courants forts | 21h |
| 513 | 6.3.1.6.1.10 | Réseaux neufs CFA | 3d | 2027-01-27 | 2027-02-01 | 510 | 0d |  | Lot 02 : Courants faibles | 21h |
| 514 | 6.3.1.6.1.11 | Réseaux neufs CVC, plomberie | 3d | 2027-01-27 | 2027-02-01 | 510 | 0d |  | Lot 03 : Chauffage, climatisation, ventilation, plomberie | 21h |
| 515 | 6.3.1.6.1.12 | Pose plafonds agro | 3d | 2027-02-01 | 2027-02-04 | 511, 512, 513, 514 | 0d |  | Lot 10 : Cloisons et plafonds agroalimentaires | 21h |
| 516 | 6.3.1.6.1.13 | Finitions murales | 2d | 2027-02-04 | 2027-02-08 | 515 | 0d |  | Lot 07 : Sols souples, protections murales | 14h |
| 517 | 6.3.1.6.1.14 | Pose équipement CFO | 2d | 2027-02-08 | 2027-02-10 | 516 | 0d |  | Lot 01 : Courants forts | 14h |
| 518 | 6.3.1.6.1.15 | Pose équipements CVC | 2d | 2027-02-08 | 2027-02-10 | 516 | 0d |  | Lot 03 : Chauffage, climatisation, ventilation, plomberie | 14h |
| 519 | 6.3.1.6.1.16 | Pose équipements CFA | 2d | 2027-02-08 | 2027-02-10 | 516 | 0d |  | Lot 02 : Courants faibles | 14h |
| 520 | 6.3.1.6.1.17 | Pose sol | 3d | 2027-02-10 | 2027-02-15 | 517, 518, 519 | 0d |  | Lot 07 : Sols souples, protections murales | 21h |
| 521 | 6.3.1.6.1.18 | Installation paillasses | 2d | 2027-02-15 | 2027-02-17 | 520 | 0d |  | Lot 06 : Paillasses, matériel de laboratoire | 14h |
| 522 | 6.3.1.7 | Réception phase 1.2 & 1.3 | 1d | 2027-02-17 | 2027-02-18 | 458, 502 | 0d |  |  |  |

| ID | WBS | Task | Duration | Start | Finish | Predecessors | Total slack | Resources | Work |
| --- | --- | --- | --- | --- | --- | --- | --- | --- | --- |
| 523 | 6.3.2 | **Déménagements** | 3d | 2027-02-18 | 2027-02-23 |  | 0d |  | 343h |
| 524 | 6.3.2.1 | Nettoyage avant installation installation (11103-14_0001 / 05 / 11101-14_0007/09/10/ 28) | 1d | 2027-02-18 | 2027-02-19 | 522 | 0d | Prestataire entretien des locaux | 7h |
| 525 | 6.3.2.2 | 11101-14_00 Vers 11101-14_0007 (réception prétraitement) | 2d | 2027-02-19 | 2027-02-23 | 524 | 0d | Déménagement externe; Déménagement interne; Direction du laboratoire | 42h |
| 526 | 6.3.2.3 | Bureau FF T ? Vers 11103-14_0002 (Bureau UHH) | 2d | 2027-02-19 | 2027-02-23 | 524 | 0d | Déménagement externe; Déménagement interne; Direction du laboratoire | 42h |
| 527 | 6.3.2.4 | 11101-14_0001 vers ? | 2d | 2027-02-19 | 2027-02-23 | 524 | 0d | Déménagement externe; Déménagement interne; Direction du laboratoire | 42h |
| 528 | 6.3.2.5 | 11101-14_0002 vers ? | 2d | 2027-02-19 | 2027-02-23 | 524 | 0d | Déménagement externe; Déménagement interne; Direction du laboratoire | 42h |
| 529 | 6.3.2.6 | 11101-14_0003 vers ? | 2d | 2027-02-19 | 2027-02-23 | 524 | 0d | Déménagement externe; Déménagement interne; Direction du laboratoire | 42h |
| 530 | 6.3.2.7 | 11101-14_0004 vers ? | 2d | 2027-02-19 | 2027-02-23 | 524 | 0d | Déménagement externe; Déménagement interne; Direction du laboratoire | 42h |
| 531 | 6.3.2.8 | 11101-14_0009 vers 11101-11_0011 | 2d | 2027-02-19 | 2027-02-23 | 524 | 0d | Déménagement externe; Déménagement interne; Direction du laboratoire | 42h |
| 532 | 6.3.2.9 | 11101-14_0010 vers 11101-14_0012 | 2d | 2027-02-19 | 2027-02-23 | 524 | 0d | Déménagement externe; Déménagement interne; Direction du laboratoire | 42h |
| 533 | 6.3.3 | **SP06 - 4ème - Phase 2** | 45.5d | 2027-02-23 | 2027-04-28 |  | 0d |  | 682.5h |
| 534 | 6.3.3.1 | **Pièces 11101-14_0001, 02, 03, 04** | 45.5d | 2027-02-23 | 2027-04-28 |  | 0d |  | 682.5h |
| 535 | 6.3.3.1.1 | Neutralisation réseaux (consignations) | 0.5d | 2027-02-23 | 2027-02-23 | 523 | 0d | Services techniques | 3.5h |
| 536 | 6.3.3.1.2 | Déconnexion paillasse plomberie, dépose équipements de plomberie et CVC | 2d | 2027-02-24 | 2027-02-25 | 535 | 0d | Lot 03 : Chauffage, climatisation, ventilation, plomberie | 14h |
| 537 | 6.3.3.1.3 | Déconnexion paillasse CFO et luminaires | 2d | 2027-02-24 | 2027-02-25 | 535 | 0d | Lot 01 : Courants forts | 14h |
| 538 | 6.3.3.1.4 | Déconnexion paillasse CFA | 2d | 2027-02-24 | 2027-02-25 | 535 | 0d | Lot 02 : Courants faibles | 14h |
| 539 | 6.3.3.1.5 | Renforts plafond | 2d | 2027-02-24 | 2027-02-25 | 535 | 3d | Lot 10 : Cloisons et plafonds agroalimentaires | 14h |
| 540 | 6.3.3.1.6 | Enlèvement paillasse | 3d | 2027-02-26 | 2027-03-02 | 536, 537, 538 | 0d | Lot 08 : Curage, démolitions, platrerie, peinture, faux-plafonds | 21h |
| 541 | 6.3.3.1.7 | Dépose sorbonne | 1d | 2027-02-26 | 2027-02-26 | 536, 537, 538 | 2d |  |  |
| 542 | 6.3.3.1.8 | Curage FP, Sol, création d'ouverture cloisons | 10d | 2027-03-03 | 2027-03-16 | 539, 540, 541 | 0d | Lot 08 : Curage, démolitions, platrerie, peinture, faux-plafonds | 70h |
| 543 | 6.3.3.1.9 | Création de cloison et étoupements | 10d | 2027-03-17 | 2027-03-31 | 542 | 0d | Lot 10 : Cloisons et plafonds agroalimentaires | 70h |
| 544 | 6.3.3.1.10 | Réseaux neufs CFO | 10d | 2027-03-17 | 2027-03-31 | 542 | 0d | Lot 01 : Courants forts | 70h |
| 545 | 6.3.3.1.11 | Réseaux neufs CFA | 10d | 2027-03-17 | 2027-03-31 | 542 | 0d | Lot 02 : Courants faibles | 70h |
| 546 | 6.3.3.1.12 | Réseaux neufs CVC, plomberie | 10d | 2027-03-17 | 2027-03-31 | 542 | 0d | Lot 03 : Chauffage, climatisation, ventilation, plomberie | 70h |
| 547 | 6.3.3.1.13 | Cloisons et portes vitrées (remplacemnet vitrage pièce noire - couloir) | 5d | 2027-03-17 | 2027-03-23 | 542 | 5d | Lot 09 : Menuiseries extérieures, cloisons vitrées, protections solaires | 35h |
| 548 | 6.3.3.1.14 | Pose FP | 5d | 2027-04-01 | 2027-04-07 | 543, 544, 545, 546, 547 | 0d | Lot 09 : Menuiseries extérieures, cloisons vitrées, protections solaires | 35h |
| 549 | 6.3.3.1.15 | Finitions murales | 5d | 2027-04-05 | 2027-04-09 | 548SS+2d | 2d | Lot 07 : Sols souples, protections murales | 35h |
| 550 | 6.3.3.1.16 | Pose équipements CVC | 5d | 2027-04-07 | 2027-04-13 | 548SS+4d | 0d | Lot 03 : Chauffage, climatisation, ventilation, plomberie | 35h |
| 551 | 6.3.3.1.17 | Pose sol | 3d | 2027-04-14 | 2027-04-16 | 549, 550 | 0d | Lot 07 : Sols souples, protections murales | 21h |
| 552 | 6.3.3.1.18 | Installation paillasses | 3d | 2027-04-19 | 2027-04-21 | 551 | 0d | Lot 06 : Paillasses, matériel de laboratoire | 21h |
| 553 | 6.3.3.1.19 | Repose sorbonne | 1d | 2027-04-19 | 2027-04-19 | 551 | 2d |  |  |
| 554 | 6.3.3.1.20 | Pose équipement CFO | 5d | 2027-04-22 | 2027-04-28 | 552, 553 | 0d | Lot 01 : Courants forts | 35h |
| 555 | 6.3.3.1.21 | Pose équipements CFA | 5d | 2027-04-22 | 2027-04-28 | 552, 553 | 0d | Lot 02 : Courants faibles | 35h |
| 556 | 6.3.4 | Réception phase 2 | 1d | 2027-04-29 | 2027-04-29 | 533 | 0d |  |  |

| ID | WBS | Task | Duration | Start | Finish | Predecessors | Total slack | Free slack | Resources | Work |
| --- | --- | --- | --- | --- | --- | --- | --- | --- | --- | --- |
| 557 | 6.3.5 | **Déménagements fin de phase 2** | 54.5d | 2027-02-19 | 2027-05-10 |  | 0d |  |  | 385h |
| 558 | 6.3.5.1 | Nettoyage avant installation installation (11101-14_0001/02/03) | 1d | 2027-04-30 | 2027-04-30 | 556 | 0d |  | Prestataire entretien des locaux | 7h |
| 559 | 6.3.5.2 | 11101-14_0008 vers 11101-11_0001 (Bactec) | 2d | 2027-05-03 | 2027-05-04 | 558 | 1d | 0d | Déménagement externe; Déménagement interne; Direction du laboratoire | 42h |
| 560 | 6.3.5.3 | 11101-14_00 ? Vers 11101-11_0002 (P Noire) | 5d | 2027-05-03 | 2027-05-10 | 558 | 0d |  | Déménagement externe; Déménagement interne; Direction du laboratoire | 105h |
| 561 | 6.3.5.4 | 11101-14_00 ? Vers 11101-11_0003 (Hémoc) | 5d | 2027-05-03 | 2027-05-10 | 558 | 0d |  | Déménagement externe; Déménagement interne; Direction du laboratoire | 105h |
| 562 | 6.3.5.5 | 11101-14_0005 vers 11101-14_0008 | 2d | 2027-05-05 | 2027-05-07 | 559 | 1d |  | Déménagement externe; Déménagement interne; Direction du laboratoire | 42h |
| 563 | 6.3.5.6 | 11101-14_0006 vers ? | 4d | 2027-02-19 | 2027-02-25 | 524 | 50.5d |  | Déménagement externe; Déménagement interne; Direction du laboratoire | 84h |
| 564 | 6.3.6 | **SP06 - 4ème - Phase 3** | 53.5d | 2027-05-11 | 2027-07-27 |  | 0d |  |  | 689.5h |
| 565 | 6.3.6.1 | **Pièces 11101-14_0005, 06** | 53.5d | 2027-05-11 | 2027-07-27 |  | 0d |  |  | 689.5h |
| 566 | 6.3.6.1.1 | Neutralisation réseaux (consignations) | 0.5d | 2027-05-11 | 2027-05-11 | 557 | 0d |  | Services techniques | 3.5h |
| 567 | 6.3.6.1.2 | Déconnexion paillasse plomberie, dépose équipements de plomberie et CVC | 5d | 2027-05-11 | 2027-05-19 | 566 | 0d |  | Lot 03 : Chauffage, climatisation, ventilation, plomberie | 35h |
| 568 | 6.3.6.1.3 | Déconnexion paillasse CFO et luminaires | 5d | 2027-05-11 | 2027-05-19 | 566 | 0d |  | Lot 01 : Courants forts | 35h |
| 569 | 6.3.6.1.4 | Déconnexion paillasse CFA | 5d | 2027-05-11 | 2027-05-19 | 566 | 0d |  | Lot 02 : Courants faibles | 35h |
| 570 | 6.3.6.1.5 | Renforts plafond | 5d | 2027-05-11 | 2027-05-19 | 566 | 3d |  | Lot 10 : Cloisons et plafonds agroalimentaires | 35h |
| 571 | 6.3.6.1.6 | Enlèvement paillasse | 3d | 2027-05-19 | 2027-05-24 | 567, 568, 569 | 0d |  | Lot 08 : Curage, démolitions, platrerie, peinture, faux-plafonds | 21h |
| 572 | 6.3.6.1.7 | Curage FP, Sol, création d'ouverture cloisons | 5d | 2027-05-24 | 2027-05-31 | 570, 571 | 0d |  | Lot 08 : Curage, démolitions, platrerie, peinture, faux-plafonds | 35h |
| 573 | 6.3.6.1.8 | Création de cloison et étoupements | 5d | 2027-05-31 | 2027-06-07 | 572 | 5d |  | Lot 10 : Cloisons et plafonds agroalimentaires | 35h |
| 574 | 6.3.6.1.9 | Réseaux neufs CFO | 10d | 2027-05-31 | 2027-06-14 | 572 | 0d |  | Lot 01 : Courants forts | 70h |
| 575 | 6.3.6.1.10 | Réseaux neufs CFA | 10d | 2027-05-31 | 2027-06-14 | 572 | 0d |  | Lot 02 : Courants faibles | 70h |
| 576 | 6.3.6.1.11 | Réseaux neufs CVC, plomberie | 10d | 2027-05-31 | 2027-06-14 | 572 | 0d |  | Lot 03 : Chauffage, climatisation, ventilation, plomberie | 70h |
| 577 | 6.3.6.1.12 | Pose FP | 5d | 2027-06-14 | 2027-06-21 | 573, 574, 575, 576 | 0d |  | Lot 09 : Menuiseries extérieures, cloisons vitrées, protections solaires | 35h |
| 578 | 6.3.6.1.13 | Finitions murales | 5d | 2027-06-21 | 2027-06-28 | 577 | 0d |  | Lot 07 : Sols souples, protections murales | 35h |
| 579 | 6.3.6.1.14 | Pose équipements CVC | 5d | 2027-06-28 | 2027-07-05 | 578 | 0d |  | Lot 03 : Chauffage, climatisation, ventilation, plomberie | 35h |
| 580 | 6.3.6.1.15 | Pose sol | 5d | 2027-07-05 | 2027-07-12 | 578, 579 | 0d |  | Lot 07 : Sols souples, protections murales | 35h |
| 581 | 6.3.6.1.16 | Installation paillasses | 5d | 2027-07-12 | 2027-07-20 | 580 | 0d |  | Lot 06 : Paillasses, matériel de laboratoire | 35h |
| 582 | 6.3.6.1.17 | Pose équipement CFO | 5d | 2027-07-20 | 2027-07-27 | 581 | 0d |  | Lot 01 : Courants forts | 35h |
| 583 | 6.3.6.1.18 | Pose équipements CFA | 5d | 2027-07-20 | 2027-07-27 | 581 | 0d |  | Lot 02 : Courants faibles | 35h |
| 584 | 6.3.7 | Réception phase 3 | 1d | 2027-07-27 | 2027-07-28 | 564 | 0d |  |  |  |

| ID | WBS | Task | Duration | Start | Finish | Predecessors | Total slack | Free slack | Resources | Work |
| --- | --- | --- | --- | --- | --- | --- | --- | --- | --- | --- |
| 585 | 6.3.8 | **Déménagements phase 3** | 4d | 2027-07-28 | 2027-08-03 |  | 0d |  |  | 385h |
| 586 | 6.3.8.1 | Nettoyage avant installation installation (11101-14_0005/06) | 1d | 2027-07-28 | 2027-07-29 | 584 | 0d |  | Prestataire entretien des locaux | 7h |
| 587 | 6.3.8.2 | 11101-14_0026 vers ? | 3d | 2027-07-29 | 2027-08-03 | 586 | 0d |  | Déménagement externe; Déménagement interne; Direction du laboratoire | 63h |
| 588 | 6.3.8.3 | 11101-14_0026 vers ? | 3d | 2027-07-29 | 2027-08-03 | 586 | 0d |  | Déménagement externe; Déménagement interne; Direction du laboratoire | 63h |
| 589 | 6.3.8.4 | 11101-14_0027 vers 11101-11_0005 | 3d | 2027-07-29 | 2027-08-03 | 586 | 0d |  | Déménagement externe; Déménagement interne; Direction du laboratoire | 63h |
| 590 | 6.3.8.5 | 11101-14_0029 vers ? | 3d | 2027-07-29 | 2027-08-03 | 586 | 0d |  | Déménagement externe; Déménagement interne; Direction du laboratoire | 63h |
| 591 | 6.3.8.6 | 11101-14_0030 vers 11101-14_0005 (Etuves CO2 + Ana) | 3d | 2027-07-29 | 2027-08-03 | 586 | 0d |  | Déménagement externe; Déménagement interne; Direction du laboratoire | 63h |
| 592 | 6.3.8.7 | 11101-14_0031 vers ? | 3d | 2027-07-29 | 2027-08-03 | 586 | 0d |  | Déménagement externe; Déménagement interne; Direction du laboratoire | 63h |
| 593 | 6.3.9 | **SP06 - 4ème - Phase 4** | 301d | 2026-09-15 | 2027-11-22 |  | 0d |  |  | 3304h |
| 594 | 6.3.9.1 | **Pièces 11101-14_26, 27** | 284d | 2026-09-15 | 2027-10-26 |  | 17d |  |  | 1410.5h |
| 595 | 6.3.9.1.1 | Neutralisation réseaux (consignations) | 0.5d | 2027-08-03 | 2027-08-03 | 585 | 17d | 0d | Services techniques | 3.5h |
| 596 | 6.3.9.1.2 | Déconnexion paillasse plomberie, dépose équipements de plomberie et CVC | 5d | 2027-08-04 | 2027-08-10 | 595 | 17d | 0d | Lot 03 : Chauffage, climatisation, ventilation, plomberie | 35h |
| 597 | 6.3.9.1.3 | Déconnexion paillasse CFO et luminaires | 5d | 2027-08-04 | 2027-08-10 | 595 | 17d | 0d | Lot 01 : Courants forts | 35h |
| 598 | 6.3.9.1.4 | Déconnexion paillasse CFA | 5d | 2027-08-04 | 2027-08-10 | 595 | 17d | 0d | Lot 02 : Courants faibles | 35h |
| 599 | 6.3.9.1.5 | Enlèvement paillasse | 5d | 2027-08-11 | 2027-08-17 | 596, 597, 598 | 17d | 0d | Lot 08 : Curage, démolitions, platrerie, peinture, faux-plafonds | 35h |
| 600 | 6.3.9.1.6 | Curage FP, Sol, création d'ouverture cloisons | 10d | 2027-08-18 | 2027-08-31 | 599 | 17d | 0d | Lot 08 : Curage, démolitions, platrerie, peinture, faux-plafonds | 70h |
| 601 | 6.3.9.1.7 | Renforts cloison | 1d | 2027-09-01 | 2027-09-01 | 600 | 56d |  | Lot 10 : Cloisons et plafonds agroalimentaires | 7h |
| 602 | 6.3.9.1.8 | Réseaux neufs CFO | 30d | 2027-09-01 | 2027-10-12 | 600 | 17d | 0d | Lot 01 : Courants forts | 210h |
| 603 | 6.3.9.1.9 | Réseaux neufs CFA | 30d | 2027-09-01 | 2027-10-12 | 600 | 17d | 0d | Lot 02 : Courants faibles | 210h |
| 604 | 6.3.9.1.10 | Réseaux neufs CVC, plomberie, chambre froide | 30d | 2027-09-01 | 2027-10-12 | 600 | 17d | 0d | Lot 03 : Chauffage, climatisation, ventilation, plomberie | 210h |
| 605 | 6.3.9.1.11 | Réseaux Fluides médicaux | 10d | 2027-09-01 | 2027-09-14 | 600 | 47d |  | Lot 04 : Fluides de laboratoire | 70h |
| 606 | 6.3.9.1.12 | Pose Plafond Agro | 10d | 2027-10-13 | 2027-10-26 | 602, 603, 604 | 17d |  | Lot 10 : Cloisons et plafonds agroalimentaires | 70h |
| 607 | 6.3.9.1.13 | Pose équipement CFO | 10d | 2026-09-15 | 2026-09-28 |  | 281d | 0d | Lot 01 : Courants forts | 70h |
| 608 | 6.3.9.1.14 | Pose équipements CVC | 10d | 2026-09-15 | 2026-09-28 |  | 281d | 0d | Lot 03 : Chauffage, climatisation, ventilation, plomberie | 70h |
| 609 | 6.3.9.1.15 | Pose équipements CFA | 10d | 2026-09-15 | 2026-09-28 |  | 291d |  | Lot 02 : Courants faibles | 70h |
| 610 | 6.3.9.1.16 | Finitions murales | 10d | 2026-09-15 | 2026-09-28 |  | 281d | 0d | Lot 07 : Sols souples, protections murales | 70h |
| 611 | 6.3.9.1.17 | Pose sol | 10d | 2026-09-15 | 2026-09-28 |  | 281d | 0d | Lot 07 : Sols souples, protections murales | 70h |
| 612 | 6.3.9.1.18 | Installation paillasses | 10d | 2026-09-29 | 2026-10-12 | 607, 608, 610, 611 | 281d |  | Lot 06 : Paillasses, matériel de laboratoire | 70h |

| ID | WBS | Task | Duration | Start | Finish | Predecessors | Total slack | Free slack | Resources | Work |
| --- | --- | --- | --- | --- | --- | --- | --- | --- | --- | --- |
| 613 | 6.3.9.2 | **Pièces 11101-14_29, 30 et 31** | 77.5d | 2027-08-03 | 2027-11-22 |  | 0d |  |  | 1697.5h |
| 614 | 6.3.9.2.1 | Neutralisation réseaux (consignations) | 0.5d | 2027-08-03 | 2027-08-03 | 585 | 0d |  | Services techniques | 3.5h |
| 615 | 6.3.9.2.2 | Dépose de la cloison de séparation temporaire dans la pièce 4B31 et protection de la porte automatique | 1d | 2027-08-04 | 2027-08-04 | 614 | 76d |  | Lot 08 : Curage, démolitions, platrerie, peinture, faux-plafonds | 7h |
| 616 | 6.3.9.2.3 | Déconnexion paillasse plomberie, dépose équipements de plomberie et CVC | 5d | 2027-08-04 | 2027-08-10 | 614 | 0d |  | Lot 03 : Chauffage, climatisation, ventilation, plomberie | 35h |
| 617 | 6.3.9.2.4 | Déconnexion paillasse CFO et luminaires | 5d | 2027-08-04 | 2027-08-10 | 614 | 0d |  | Lot 01 : Courants forts | 35h |
| 618 | 6.3.9.2.5 | Déconnexion paillasse CFA | 5d | 2027-08-04 | 2027-08-10 | 614 | 0d |  | Lot 02 : Courants faibles | 35h |
| 619 | 6.3.9.2.6 | Enlèvement paillasse | 5d | 2027-08-11 | 2027-08-17 | 616, 617, 618 | 0d |  | Lot 08 : Curage, démolitions, platrerie, peinture, faux-plafonds | 35h |
| 620 | 6.3.9.2.7 | Dépose Sorbonne | 1d | 2027-08-11 | 2027-08-11 | 616, 617, 618 | 71d |  | Lot 06 : Paillasses, matériel de laboratoire | 7h |
| 621 | 6.3.9.2.8 | Curage FP, Sol, création d'ouverture cloisons | 10d | 2027-08-18 | 2027-08-31 | 619 | 0d |  | Lot 08 : Curage, démolitions, platrerie, peinture, faux-plafonds | 70h |
| 622 | 6.3.9.2.9 | Renforts cloisons | 10d | 2027-08-18 | 2027-08-31 | 619 | 0d |  | Lot 10 : Cloisons et plafonds agroalimentaires | 70h |
| 623 | 6.3.9.2.10 | Création de cloison et étoupements | 30d | 2027-09-01 | 2027-10-12 | 621, 622 | 0d |  | Lot 08 : Curage, démolitions, platrerie, peinture, faux-plafonds | 210h |
| 624 | 6.3.9.2.11 | Réseaux neufs CFO | 30d | 2027-09-01 | 2027-10-12 | 621, 622 | 0d |  | Lot 01 : Courants forts | 210h |
| 625 | 6.3.9.2.12 | Réseaux neufs CFA | 30d | 2027-09-01 | 2027-10-12 | 621, 622 | 0d |  | Lot 02 : Courants faibles | 210h |
| 626 | 6.3.9.2.13 | Réseaux neufs CVC, plomberie | 30d | 2027-09-01 | 2027-10-12 | 621, 622 | 0d |  | Lot 03 : Chauffage, climatisation, ventilation, plomberie | 210h |
| 627 | 6.3.9.2.14 | Réseaux Fluides médicaux | 10d | 2027-09-01 | 2027-09-14 | 621, 622 | 47d |  | Lot 04 : Fluides de laboratoire | 70h |
| 628 | 6.3.9.2.15 | Pose FP | 10d | 2027-10-13 | 2027-10-26 | 623, 624, 625, 626 | 0d |  | Lot 08 : Curage, démolitions, platrerie, peinture, faux-plafonds | 70h |
| 629 | 6.3.9.2.16 | Pose équipement CFO | 10d | 2027-10-15 | 2027-10-28 | 628SS+2d | 5d |  | Lot 01 : Courants forts | 70h |
| 630 | 6.3.9.2.17 | Pose équipements CVC | 10d | 2027-10-15 | 2027-10-28 | 628SS+2d | 5d |  | Lot 03 : Chauffage, climatisation, ventilation, plomberie | 70h |
| 631 | 6.3.9.2.18 | Pose équipements CFA | 10d | 2027-10-15 | 2027-10-28 | 628SS+2d | 15d |  | Lot 02 : Courants faibles | 70h |
| 632 | 6.3.9.2.19 | Finitions murales | 10d | 2027-10-19 | 2027-11-02 | 628SS+4d | 3d |  | Lot 07 : Sols souples, protections murales | 70h |
| 633 | 6.3.9.2.20 | Pose sol | 10d | 2027-10-22 | 2027-11-05 | 628SS+7d | 0d |  | Lot 07 : Sols souples, protections murales | 70h |
| 634 | 6.3.9.2.21 | Installation paillasses | 10d | 2027-11-08 | 2027-11-22 | 629, 630, 632, 633 | 0d |  | Lot 06 : Paillasses, matériel de laboratoire | 70h |
| 635 | 6.3.9.3 | **Pièces 11103-14_17 (Serveur)** | 12d | 2027-08-03 | 2027-08-19 |  | 65.5d |  |  | 196h |
| 636 | 6.3.9.3.1 | Consignation | 1d | 2027-08-03 | 2027-08-04 | 585 | 65.5d | 0d | Services techniques | 7h |
| 637 | 6.3.9.3.2 | Dépose équipements CFO | 1d | 2027-08-04 | 2027-08-05 | 636 | 65.5d | 0d | Lot 01 : Courants forts | 7h |
| 638 | 6.3.9.3.3 | Dépose faux-plafond, curage sol et dépose cloison | 2d | 2027-08-05 | 2027-08-09 | 637 | 65.5d | 0d | Lot 08 : Curage, démolitions, platrerie, peinture, faux-plafonds | 14h |
| 639 | 6.3.9.3.4 | Cloisons neuves | 5d | 2027-08-09 | 2027-08-16 | 638 | 65.5d | 0d | Lot 08 : Curage, démolitions, platrerie, peinture, faux-plafonds | 35h |
| 640 | 6.3.9.3.5 | Pose nouveaux réseaux CFO | 5d | 2027-08-09 | 2027-08-16 | 638 | 65.5d | 0d | Lot 01 : Courants forts | 35h |
| 641 | 6.3.9.3.6 | Pose nouveaux réseaux CFA | 5d | 2027-08-09 | 2027-08-16 | 638 | 65.5d | 0d | Lot 02 : Courants faibles | 35h |
| 642 | 6.3.9.3.7 | Pose faux plafonds neuf | 3d | 2027-08-09 | 2027-08-12 | 638 | 67.5d | 2d | Lot 08 : Curage, démolitions, platrerie, peinture, faux-plafonds | 21h |
| 643 | 6.3.9.3.8 | Pose équipements CFA | 3d | 2027-08-09 | 2027-08-12 | 638 | 67.5d | 2d | Lot 02 : Courants faibles | 21h |
| 644 | 6.3.9.3.9 | Finitions murales | 3d | 2027-08-16 | 2027-08-19 | 639, 640, 641, 642, 643 | 65.5d |  | Lot 08 : Curage, démolitions, platrerie, peinture, faux-plafonds | 21h |
| 645 | 6.3.10 | Réception phase | 1d | 2027-11-23 | 2027-11-23 | 593 | 0d |  |  |  |

| ID | WBS | Task | Duration | Start | Finish | Predecessors | Total slack | Resources | Work |
| --- | --- | --- | --- | --- | --- | --- | --- | --- | --- |
| 646 | 6.3.11 | **Déménagements phase 4** | 11d | 2027-11-24 | 2027-12-08 |  | 0d |  | 658h |
| 647 | 6.3.11.1 | Nettoyage avant installation installation (11103-14_c1 / 11101-14_0026/27/29/30) | 1d | 2027-11-24 | 2027-11-24 | 645 | 0d | Prestataire entretien des locaux | 7h |
| 648 | 6.3.11.2 | 11101-14_00 ? Vers 11101-11_00… | 10d | 2027-11-25 | 2027-12-08 | 647 | 0d | Déménagement externe; Déménagement interne; Direction du laboratoire | 210h |
| 649 | 6.3.11.3 | 11101-14_0008 vers ? | 3d | 2027-11-25 | 2027-11-29 | 647 | 7d | Déménagement externe; Déménagement interne; Direction du laboratoire | 63h |
| 650 | 6.3.11.4 | 11101-14_0009 vers ? | 3d | 2027-11-25 | 2027-11-29 | 647 | 7d | Déménagement externe; Déménagement interne; Direction du laboratoire | 63h |
| 651 | 6.3.11.5 | 11101-14_0010 vers ? | 3d | 2027-11-25 | 2027-11-29 | 647 | 7d | Déménagement externe; Déménagement interne; Direction du laboratoire | 63h |
| 652 | 6.3.11.6 | 11101-14_0040 vers ? | 3d | 2027-11-25 | 2027-11-29 | 647 | 7d | Déménagement externe; Déménagement interne; Direction du laboratoire | 63h |
| 653 | 6.3.11.7 | ? Vers 11101-14_0027 | 3d | 2027-11-25 | 2027-11-29 | 647 | 7d | Déménagement externe; Déménagement interne; Direction du laboratoire | 63h |
| 654 | 6.3.11.8 | ? Vers 11101-14_0029 | 3d | 2027-11-25 | 2027-11-29 | 647 | 7d | Déménagement externe; Déménagement interne; Direction du laboratoire | 63h |
| 655 | 6.3.11.9 | ? Vers 11101-14_0030 | 3d | 2027-11-25 | 2027-11-29 | 647 | 7d | Déménagement externe; Déménagement interne; Direction du laboratoire | 63h |
| 656 | 6.3.12 | Arrivée chaine de bactériologie et emménagement | 10d | 2027-11-25 | 2027-12-08 | 647 | 244.5d |  |  |
| 657 | 6.3.13 | **SP06 - 4ème - Phase 5** | 53.5d | 2027-12-09 | 2028-02-22 |  | 0d |  | 710.5h |
| 658 | 6.3.13.1 | **Pièces 11101-14_0008, 09, 10 et 40 (UHH)** | 53.5d | 2027-12-09 | 2028-02-22 |  | 0d |  | 710.5h |
| 659 | 6.3.13.1.1 | Neutralisation réseaux (consignations) | 0.5d | 2027-12-09 | 2027-12-09 | 646 | 0d | Services techniques | 3.5h |
| 660 | 6.3.13.1.2 | Déconnexion paillasse plomberie, dépose équipements de plomberie et CVC | 5d | 2027-12-09 | 2027-12-16 | 659 | 0d | Lot 03 : Chauffage, climatisation, ventilation, plomberie | 35h |
| 661 | 6.3.13.1.3 | Déconnexion paillasse CFO et luminaires | 5d | 2027-12-09 | 2027-12-16 | 659 | 0d | Lot 01 : Courants forts | 35h |
| 662 | 6.3.13.1.4 | Déconnexion paillasse CFA | 5d | 2027-12-09 | 2027-12-16 | 659 | 0d | Lot 02 : Courants faibles | 35h |
| 663 | 6.3.13.1.5 | Renforts plafond | 5d | 2027-12-09 | 2027-12-16 | 659 | 3d | Lot 10 : Cloisons et plafonds agroalimentaires | 35h |
| 664 | 6.3.13.1.6 | Enlèvement paillasse | 3d | 2027-12-16 | 2027-12-21 | 660, 661, 662 | 0d | Lot 08 : Curage, démolitions, platrerie, peinture, faux-plafonds | 21h |
| 665 | 6.3.13.1.7 | Curage FP, Sol, création d'ouverture cloisons | 5d | 2027-12-21 | 2027-12-28 | 663, 664 | 0d | Lot 08 : Curage, démolitions, platrerie, peinture, faux-plafonds | 35h |
| 666 | 6.3.13.1.8 | Création de cloison | 5d | 2027-12-28 | 2028-01-04 | 665 | 5d | Lot 10 : Cloisons et plafonds agroalimentaires | 35h |
| 667 | 6.3.13.1.9 | Pose porte et/ou cloison vitrée | 3d | 2027-12-28 | 2027-12-31 | 665 | 37d | Lot 09 : Menuiseries extérieures, cloisons vitrées, protections solaires | 21h |
| 668 | 6.3.13.1.10 | Réseaux neufs CFO | 10d | 2027-12-28 | 2028-01-11 | 665 | 0d | Lot 01 : Courants forts | 70h |
| 669 | 6.3.13.1.11 | Réseaux neufs CFA | 10d | 2027-12-28 | 2028-01-11 | 665 | 0d | Lot 02 : Courants faibles | 70h |
| 670 | 6.3.13.1.12 | Réseaux neufs CVC, plomberie | 10d | 2027-12-28 | 2028-01-11 | 665 | 0d | Lot 03 : Chauffage, climatisation, ventilation, plomberie | 70h |
| 671 | 6.3.13.1.13 | Pose plafond agro | 5d | 2028-01-11 | 2028-01-18 | 666, 668, 669, 670 | 0d | Lot 10 : Cloisons et plafonds agroalimentaires | 35h |
| 672 | 6.3.13.1.14 | Finitions murales | 5d | 2028-01-18 | 2028-01-25 | 671 | 0d | Lot 07 : Sols souples, protections murales | 35h |
| 673 | 6.3.13.1.15 | Pose équipements CVC | 5d | 2028-01-25 | 2028-02-01 | 672 | 0d | Lot 03 : Chauffage, climatisation, ventilation, plomberie | 35h |
| 674 | 6.3.13.1.16 | Pose sol | 5d | 2028-02-01 | 2028-02-08 | 672, 673 | 0d | Lot 07 : Sols souples, protections murales | 35h |
| 675 | 6.3.13.1.17 | Installation paillasses | 5d | 2028-02-08 | 2028-02-15 | 674 | 0d | Lot 06 : Paillasses, matériel de laboratoire | 35h |
| 676 | 6.3.13.1.18 | Pose équipement CFO | 5d | 2028-02-15 | 2028-02-22 | 675 | 0d | Lot 01 : Courants forts | 35h |
| 677 | 6.3.13.1.19 | Pose équipements CFA | 5d | 2028-02-15 | 2028-02-22 | 675 | 0d | Lot 02 : Courants faibles | 35h |
| 678 | 6.3.14 | Réception phase | 1d | 2028-02-22 | 2028-02-23 | 657 | 0d |  |  |

| ID | WBS | Task | Type | Duration | Start | Finish | Predecessors | Total slack | Free slack | Resources | Work |
| --- | --- | --- | --- | --- | --- | --- | --- | --- | --- | --- | --- |
| 679 | 6.3.15 | **Déménagements phase 5** |  | 4d | 2028-02-23 | 2028-02-29 |  | 0d |  |  | 574h |
| 680 | 6.3.15.1 | Nettoyage avant installation installation (11101-14_0008/09/10/40) |  | 1d | 2028-02-23 | 2028-02-24 | 678 | 0d |  | Prestataire entretien des locaux | 7h |
| 681 | 6.3.15.2 | 11101-16_0018 vers 11101-14_0008 (Alimentaire) |  | 3d | 2028-02-24 | 2028-02-29 | 680 | 186d |  | Déménagement externe; Déménagement interne; Direction du laboratoire | 63h |
| 682 | 6.3.15.3 | 11101-16_0011b vers 11101-14_0009 (Champi) |  | 3d | 2028-02-24 | 2028-02-29 | 680 | 186d |  | Déménagement externe; Déménagement interne; Direction du laboratoire | 63h |
| 683 | 6.3.15.4 | 11101-16_0019 vers 11101-14_0010 (Stérilité) |  | 3d | 2028-02-24 | 2028-02-29 | 680 | 186d |  | Déménagement externe; Déménagement interne; Direction du laboratoire | 63h |
| 684 | 6.3.15.5 | 11101-16_0016 vers 11101-14_0040 (Secteur Eau/Environnement) |  | 3d | 2028-02-24 | 2028-02-29 | 680 | 186d |  | Déménagement externe; Déménagement interne; Direction du laboratoire | 63h |
| 685 | 6.3.15.6 | 11101-16_0011a vers 11101-14_0006 (Alimentaire pesée) |  | 3d | 2028-02-24 | 2028-02-29 | 680 | 186d |  | Déménagement externe; Déménagement interne; Direction du laboratoire | 63h |
| 686 | 6.3.15.7 | 11101-16_0012 vers 11103-14_0010 |  | 3d | 2028-02-24 | 2028-02-29 | 680 | 186d |  | Déménagement externe; Déménagement interne; Direction du laboratoire | 63h |
| 687 | 6.3.15.8 | 11101-16_0015 vers 11101-14_0022 (Ch Fraoide) |  | 3d | 2028-02-24 | 2028-02-29 | 680 | 186d |  | Déménagement externe; Déménagement interne; Direction du laboratoire | 63h |
| 688 | 6.3.15.9 | 11101-16_0014 vers 11101-14_0016 |  | 3d | 2028-02-24 | 2028-02-29 | 680 | 186d |  | Déménagement externe; Déménagement interne; Direction du laboratoire | 63h |
| 689 | 6.3.15.10 | 11101-16_0013 vers 11101-14_0014a |  | 3d | 2028-02-24 | 2028-02-29 | 680 | 186d |  | Déménagement externe; Déménagement interne; Direction du laboratoire | 63h |
| 690 | 6.3.16 | Emménagement HH dans locaux définitifs |  | 3d | 2028-02-24 | 2028-02-29 | 680 | 0d |  | Déménagement externe; Déménagement interne; Direction du laboratoire | 63h |
| 692 | 7 | **SP9 : 6ème étage** |  | 387.5d | 2026-11-18 | 2028-05-30 |  | 124.5d |  |  | 8179.5h |
| 693 | 7.1 | RAPPEL : SP6 fin d'aménagement provisoire pour UHH | milestone | 0d | 2026-12-14 | 2026-12-14 | 264 | 365d | 0d |  |  |
| 694 | 7.2 | **Déménagements (ACP)** |  | 2d | 2026-11-18 | 2026-11-20 |  | 360d | 8d |  | 1008h |
| 695 | 7.2.1 | 11101-16_0001 vers ? |  | 2d | 2026-11-18 | 2026-11-20 | 3FS-10d | 360d |  | Déménagement externe; Déménagement interne; Direction du laboratoire | 42h |
| 696 | 7.2.2 | 11101-16_0002 vers ? |  | 2d | 2026-11-18 | 2026-11-20 | 3FS-10d | 360d |  | Déménagement externe; Déménagement interne; Direction du laboratoire | 42h |
| 697 | 7.2.3 | 11101-16_0003 vers ? |  | 2d | 2026-11-18 | 2026-11-20 | 3FS-10d | 360d | 8d | Déménagement externe; Déménagement interne; Direction du laboratoire | 42h |
| 698 | 7.2.4 | 11101-16_0004 vers ? |  | 2d | 2026-11-18 | 2026-11-20 | 3FS-10d | 360d |  | Déménagement externe; Déménagement interne; Direction du laboratoire | 42h |
| 699 | 7.2.5 | 11101-16_0005 vers ? |  | 2d | 2026-11-18 | 2026-11-20 | 3FS-10d | 360d |  | Déménagement externe; Déménagement interne; Direction du laboratoire | 42h |
| 700 | 7.2.6 | 11101-16_0006 vers ? |  | 2d | 2026-11-18 | 2026-11-20 | 3FS-10d | 360d |  | Déménagement externe; Déménagement interne; Direction du laboratoire | 42h |
| 701 | 7.2.7 | 11101-16_0007 vers ? |  | 2d | 2026-11-18 | 2026-11-20 | 3FS-10d | 360d |  | Déménagement externe; Déménagement interne; Direction du laboratoire | 42h |
| 702 | 7.2.8 | 11101-16_0008 vers ? |  | 2d | 2026-11-18 | 2026-11-20 | 3FS-10d | 360d |  | Déménagement externe; Déménagement interne; Direction du laboratoire | 42h |
| 703 | 7.2.9 | 11101-16_0009 vers ? |  | 2d | 2026-11-18 | 2026-11-20 | 3FS-10d | 360d |  | Déménagement externe; Déménagement interne; Direction du laboratoire | 42h |
| 704 | 7.2.10 | 11101-16_0010 vers ? |  | 2d | 2026-11-18 | 2026-11-20 | 3FS-10d | 360d |  | Déménagement externe; Déménagement interne; Direction du laboratoire | 42h |
| 705 | 7.2.11 | 11101-16_0011a vers ? |  | 2d | 2026-11-18 | 2026-11-20 | 3FS-10d | 360d |  | Déménagement externe; Déménagement interne; Direction du laboratoire | 42h |
| 706 | 7.2.12 | 11101-16_0011b vers ? |  | 2d | 2026-11-18 | 2026-11-20 | 3FS-10d | 360d |  | Déménagement externe; Déménagement interne; Direction du laboratoire | 42h |
| 707 | 7.2.13 | 11101-16_0012 vers ? |  | 2d | 2026-11-18 | 2026-11-20 | 3FS-10d | 360d |  | Déménagement externe; Déménagement interne; Direction du laboratoire | 42h |
| 708 | 7.2.14 | 11101-16_0030 vers ? |  | 2d | 2026-11-18 | 2026-11-20 | 3FS-10d | 360d |  | Déménagement externe; Déménagement interne; Direction du laboratoire | 42h |
| 709 | 7.2.15 | 11101-16_0031 vers ? |  | 2d | 2026-11-18 | 2026-11-20 | 3FS-10d | 360d |  | Déménagement externe; Déménagement interne; Direction du laboratoire | 42h |
| 710 | 7.2.16 | 11101-16_0032 vers ? |  | 2d | 2026-11-18 | 2026-11-20 | 3FS-10d | 360d |  | Déménagement externe; Déménagement interne; Direction du laboratoire | 42h |
| 711 | 7.2.17 | 11101-16_0033 vers ? |  | 2d | 2026-11-18 | 2026-11-20 | 3FS-10d | 360d |  | Déménagement externe; Déménagement interne; Direction du laboratoire | 42h |
| 712 | 7.2.18 | 11101-16_0034 vers ? |  | 2d | 2026-11-18 | 2026-11-20 | 3FS-10d | 360d |  | Déménagement externe; Déménagement interne; Direction du laboratoire | 42h |
| 713 | 7.2.19 | 11101-16_0035 vers ? |  | 2d | 2026-11-18 | 2026-11-20 | 3FS-10d | 360d |  | Déménagement externe; Déménagement interne; Direction du laboratoire | 42h |
| 714 | 7.2.20 | 11101-16_0036 vers ? (Stk) |  | 2d | 2026-11-18 | 2026-11-20 | 3FS-10d | 360d |  | Déménagement externe; Déménagement interne; Direction du laboratoire | 42h |
| 715 | 7.2.21 | 11101-16_0037 vers ? (Extempo) |  | 2d | 2026-11-18 | 2026-11-20 | 3FS-10d | 360d |  | Déménagement externe; Déménagement interne; Direction du laboratoire | 42h |
| 716 | 7.2.22 | 11101-16_0038 vers ? (Extempo) |  | 2d | 2026-11-18 | 2026-11-20 | 3FS-10d | 360d |  | Déménagement externe; Déménagement interne; Direction du laboratoire | 42h |
| 717 | 7.2.23 | 11101-16_0039 vers ? (Extempo) |  | 2d | 2026-11-18 | 2026-11-20 | 3FS-10d | 360d |  | Déménagement externe; Déménagement interne; Direction du laboratoire | 42h |
| 718 | 7.2.24 | 11101-16_0040 vers ? (Extempo) |  | 2d | 2026-11-18 | 2026-11-20 | 3FS-10d | 360d |  | Déménagement externe; Déménagement interne; Direction du laboratoire | 42h |

| ID | WBS | Task | Duration | Start | Finish | Predecessors | Total slack | Free slack | Resources | Work |
| --- | --- | --- | --- | --- | --- | --- | --- | --- | --- | --- |
| 719 | 7.3 | **SP09 - Phase 1** | 77d | 2026-12-14 | 2027-04-05 |  | 365d |  |  | 3923.5h |
| 720 | 7.3.1 | **SP09 - Phase 1.1** | 68d | 2026-12-14 | 2027-03-22 |  | 365d |  |  | 1414h |
| 721 | 7.3.1.1 | **Pièces 11101-16_01, 02, 03, 04, 05, 06, 26, 27, 28, 29, 30, 31, 32, 33, 34, 35, 36, 37, 38, 39, 40 et 46** | 68d | 2026-12-14 | 2027-03-22 |  | 365d | 0d |  | 1414h |
| 722 | 7.3.1.1.1 | Neutralisation réseaux (consignations) | 1d | 2026-12-14 | 2026-12-15 | 693, 694 | 365d | 0d | Services techniques | 7h |
| 723 | 7.3.1.1.2 | Déconnexion paillasse plomberie, dépose équipements de plomberie et CVC | 5d | 2026-12-15 | 2026-12-22 | 722 | 365d | 0d | Lot 03 : Chauffage, climatisation, ventilation, plomberie | 35h |
| 724 | 7.3.1.1.3 | Déconnexion paillasse CFO et luminaires | 5d | 2026-12-15 | 2026-12-22 | 722 | 365d | 0d | Lot 01 : Courants forts | 35h |
| 725 | 7.3.1.1.4 | Déconnexion paillasse CFA | 5d | 2026-12-15 | 2026-12-22 | 722 | 365d | 0d | Lot 02 : Courants faibles | 35h |
| 726 | 7.3.1.1.5 | Enlèvement paillasse | 5d | 2026-12-22 | 2026-12-30 | 723, 724, 725 | 365d | 0d | Lot 08 : Curage, démolitions, platrerie, peinture, faux-plafonds | 35h |
| 727 | 7.3.1.1.6 | Curage FP, Sol, création d'ouverture cloisons, niche couloir central | 10d | 2026-12-30 | 2027-01-14 | 726 | 365d | 0d | Lot 08 : Curage, démolitions, platrerie, peinture, faux-plafonds | 70h |
| 728 | 7.3.1.1.7 | Renforts cloison | 1d | 2026-12-30 | 2026-12-31 | 726 | 421d |  | Lot 10 : Cloisons et plafonds agroalimentaires | 7h |
| 729 | 7.3.1.1.8 | Création de cloison et étoupements | 20d | 2027-01-14 | 2027-02-11 | 727 | 365d | 0d | Lot 08 : Curage, démolitions, platrerie, peinture, faux-plafonds | 140h |
| 730 | 7.3.1.1.9 | Réseaux neufs CFO | 20d | 2027-01-14 | 2027-02-11 | 727 | 365d | 0d | Lot 01 : Courants forts | 140h |
| 731 | 7.3.1.1.10 | Réseaux neufs CFA | 20d | 2027-01-14 | 2027-02-11 | 727 | 365d | 0d | Lot 02 : Courants faibles | 140h |
| 732 | 7.3.1.1.11 | Réseaux neufs CVC, plomberie | 20d | 2027-01-14 | 2027-02-11 | 727 | 365d | 0d | Lot 03 : Chauffage, climatisation, ventilation, plomberie | 140h |
| 733 | 7.3.1.1.12 | Réseaux Fluides médicaux | 15d | 2027-01-14 | 2027-02-04 | 727 | 397d |  | Lot 04 : Fluides de laboratoire | 105h |
| 734 | 7.3.1.1.13 | Cloisons et portes vitrées | 5d | 2027-01-14 | 2027-01-21 | 727 | 380d | 15d | Lot 09 : Menuiseries extérieures, cloisons vitrées, protections solaires | 35h |
| 735 | 7.3.1.1.14 | Pose FP | 10d | 2027-02-11 | 2027-02-25 | 729, 730, 731, 732, 734 | 365d | 0d | Lot 08 : Curage, démolitions, platrerie, peinture, faux-plafonds | 70h |
| 736 | 7.3.1.1.15 | Pose équipement CFO | 10d | 2027-02-15 | 2027-03-01 | 735SS+2d | 370d | 5d | Lot 01 : Courants forts | 70h |
| 737 | 7.3.1.1.16 | Pose équipements CVC | 10d | 2027-02-15 | 2027-03-01 | 735SS+2d | 370d | 5d | Lot 03 : Chauffage, climatisation, ventilation, plomberie | 70h |
| 738 | 7.3.1.1.17 | Pose équipements CFA | 10d | 2027-02-15 | 2027-03-01 | 735SS+2d | 380d |  | Lot 02 : Courants faibles | 70h |
| 739 | 7.3.1.1.18 | Finitions murales | 10d | 2027-02-17 | 2027-03-03 | 735SS+4d | 368d | 3d | Lot 07 : Sols souples, protections murales | 70h |
| 740 | 7.3.1.1.19 | Pose sol | 10d | 2027-02-22 | 2027-03-08 | 735SS+7d | 365d | 0d | Lot 07 : Sols souples, protections murales | 70h |
| 741 | 7.3.1.1.20 | Installation paillasses | 10d | 2027-03-08 | 2027-03-22 | 740, 736, 737, 739 | 365d |  | Lot 06 : Paillasses, matériel de laboratoire | 70h |
| 742 | 7.3.2 | **SP09 - Phase 1.2** | 46.5d | 2027-01-26 | 2027-04-01 |  | 419d |  |  | 1081.5h |
| 743 | 7.3.2.1 | **Pièces 11101-16_06, 07, 08, 09 et 10** | 46.5d | 2027-01-26 | 2027-04-01 |  | 419d |  |  | 1081.5h |
| 744 | 7.3.2.1.1 | Neutralisation réseaux (consignations) | 0.5d | 2027-01-26 | 2027-01-26 | 106 | 419d | 0d | Services techniques | 3.5h |
| 745 | 7.3.2.1.2 | Déconnexion paillasse plomberie, dépose équipements de plomberie et CVC | 2d | 2027-01-26 | 2027-01-28 | 744 | 419d | 0d | Lot 03 : Chauffage, climatisation, ventilation, plomberie | 14h |
| 746 | 7.3.2.1.3 | Déconnexion paillasse CFO et luminaires | 2d | 2027-01-26 | 2027-01-28 | 744 | 419d | 0d | Lot 01 : Courants forts | 14h |
| 747 | 7.3.2.1.4 | Déconnexion paillasse CFA | 2d | 2027-01-26 | 2027-01-28 | 744 | 419d | 0d | Lot 02 : Courants faibles | 14h |
| 748 | 7.3.2.1.5 | Enlèvement paillasse | 2d | 2027-01-28 | 2027-02-01 | 745, 746, 747 | 419d | 0d | Lot 08 : Curage, démolitions, platrerie, peinture, faux-plafonds | 14h |
| 749 | 7.3.2.1.6 | Curage FP, Sol, création d'ouverture cloisons | 5d | 2027-02-01 | 2027-02-08 | 748 | 419d | 0d | Lot 08 : Curage, démolitions, platrerie, peinture, faux-plafonds | 35h |
| 750 | 7.3.2.1.7 | Renforts cloison | 1d | 2027-02-01 | 2027-02-02 | 748 | 460d |  | Lot 10 : Cloisons et plafonds agroalimentaires | 7h |
| 751 | 7.3.2.1.8 | Création de cloison et étoupements | 15d | 2027-02-08 | 2027-03-01 | 749 | 419d | 0d | Lot 08 : Curage, démolitions, platrerie, peinture, faux-plafonds | 105h |
| 752 | 7.3.2.1.9 | Réseaux neufs CFO | 15d | 2027-02-08 | 2027-03-01 | 749 | 419d | 0d | Lot 01 : Courants forts | 105h |
| 753 | 7.3.2.1.10 | Réseaux neufs CFA | 15d | 2027-02-08 | 2027-03-01 | 749 | 419d | 0d | Lot 02 : Courants faibles | 105h |
| 754 | 7.3.2.1.11 | Réseaux neufs CVC, plomberie | 15d | 2027-02-08 | 2027-03-01 | 749 | 419d | 0d | Lot 03 : Chauffage, climatisation, ventilation, plomberie | 105h |
| 755 | 7.3.2.1.12 | Cloisons et portes vitrées | 15d | 2027-02-08 | 2027-03-01 | 749 | 419d | 0d | Lot 09 : Menuiseries extérieures, cloisons vitrées, protections solaires | 105h |
| 756 | 7.3.2.1.13 | Pose FP | 10d | 2027-03-01 | 2027-03-15 | 751, 752, 753, 754, 755 | 419d | 0d | Lot 08 : Curage, démolitions, platrerie, peinture, faux-plafonds | 70h |
| 757 | 7.3.2.1.14 | Pose équipement CFO | 10d | 2027-03-03 | 2027-03-17 | 756SS+2d | 424d | 5d | Lot 01 : Courants forts | 70h |
| 758 | 7.3.2.1.15 | Pose équipements CVC | 10d | 2027-03-03 | 2027-03-17 | 756SS+2d | 424d | 5d | Lot 03 : Chauffage, climatisation, ventilation, plomberie | 70h |
| 759 | 7.3.2.1.16 | Pose équipements CFA | 10d | 2027-03-03 | 2027-03-17 | 756SS+2d | 429d |  | Lot 02 : Courants faibles | 70h |
| 760 | 7.3.2.1.17 | Finitions murales | 10d | 2027-03-05 | 2027-03-19 | 756SS+4d | 422d | 3d | Lot 07 : Sols souples, protections murales | 70h |
| 761 | 7.3.2.1.18 | Pose sol | 10d | 2027-03-10 | 2027-03-24 | 756SS+7d | 419d | 0d | Lot 07 : Sols souples, protections murales | 70h |
| 762 | 7.3.2.1.19 | Installation paillasses | 5d | 2027-03-24 | 2027-04-01 | 757, 758, 760, 761 | 419d |  | Lot 06 : Paillasses, matériel de laboratoire | 35h |
| 763 | 7.3.3 | Réception phase 1 | 3d | 2027-03-22 | 2027-03-25 | 721 | 365d | 0d | Lot 01 : Courants forts; Lot 02 : Courants faibles; Lot 03 : Chauffage, climatisation, ventilation, plomberie; Lot 04 : Fluides de laboratoire; Lot 06 : Paillasses, matériel de laboratoire; Lot 07 : Sols souples, protections murales; Lot 08 : Curage, démolitions, platrerie, peinture, faux-plafonds; Lot 09 : Menuiseries extérieures, cloisons vitrées, protections solaires | 168h |

| ID | WBS | Task | Type | Duration | Start | Finish | Predecessors | Total slack | Free slack | Resources | Work |
| --- | --- | --- | --- | --- | --- | --- | --- | --- | --- | --- | --- |
| 764 | 7.3.4 | **Déménagements phase 1** |  | 6d | 2027-03-25 | 2027-04-05 |  | 365d | 5d |  | 1260h |
| 765 | 7.3.4.1 | Nettoyage avant installation installation (11101-16_0001/02) |  | 1d | 2027-03-25 | 2027-03-26 | 763 | 368d | 0d | Prestataire entretien des locaux | 7h |
| 766 | 7.3.4.2 | 11101-16_00 ? Vers 11101-16_0002 (Bureau Pr. Godf.) |  | 2d | 2027-03-26 | 2027-03-31 | 765 | 368d |  | Déménagement externe; Déménagement interne; Direction du laboratoire | 42h |
| 767 | 7.3.4.3 | 11101-16_00 ? Vers 11101-16_0006 (Extempo.) |  | 2d | 2027-03-26 | 2027-03-31 | 765 | 368d | 0d | Déménagement externe; Déménagement interne; Direction du laboratoire | 42h |
| 768 | 7.3.4.4 | 11101-16_00 ? Vers 11101-16_0001 (Bureau Extempo.) |  | 2d | 2027-03-26 | 2027-03-31 | 765 | 368d |  | Déménagement externe; Déménagement interne; Direction du laboratoire | 42h |
| 769 | 7.3.4.5 | Emménagement Extemporané | milestone | 0d | 2027-03-31 | 2027-03-31 | 767 | 368d |  | Déménagement externe; Déménagement interne; Direction du laboratoire |  |
| 770 | 7.3.4.6 | **Déménagement laboratoire Hématologie HE vers GM** |  | 6d | 2027-03-25 | 2027-04-05 |  | 365d | 0d |  | 1127h |
| 771 | 7.3.4.6.1 | Nettoyage avant installation installation (11101-16_0003/04/05/07/10/26/28/30/33/34/35/36/37/38/39/40) |  | 1d | 2027-03-25 | 2027-03-26 | 763 | 365d | 0d | Prestataire entretien des locaux | 7h |
| 772 | 7.3.4.6.2 | HE ? Vers 11101-16_0026 (CMF) |  | 5d | 2027-03-26 | 2027-04-05 | 771 | 365d |  | Déménagement externe; Direction du laboratoire | 70h |
| 773 | 7.3.4.6.3 | HE ? Vers 11101-16_0033 (Congèl -80°C) |  | 5d | 2027-03-26 | 2027-04-05 | 771 | 365d |  | Déménagement externe; Direction du laboratoire | 70h |
| 774 | 7.3.4.6.4 | HE ? Vers 11101-16_0034 (Culture C) |  | 5d | 2027-03-26 | 2027-04-05 | 771 | 365d |  | Déménagement externe; Direction du laboratoire | 70h |
| 775 | 7.3.4.6.5 | HE ? Vers 11101-16_0035 (Secteur 1) |  | 5d | 2027-03-26 | 2027-04-05 | 771 | 365d |  | Déménagement externe; Direction du laboratoire | 70h |
| 776 | 7.3.4.6.6 | HE ? Vers 11101-16_0036 (SAS) |  | 5d | 2027-03-26 | 2027-04-05 | 771 | 365d |  | Déménagement externe; Direction du laboratoire | 70h |
| 777 | 7.3.4.6.7 | HE ? Vers 11101-16_0037 (Num. Aliquot.) |  | 5d | 2027-03-26 | 2027-04-05 | 771 | 365d |  | Déménagement externe; Direction du laboratoire | 70h |
| 778 | 7.3.4.6.8 | HE ? Vers 11101-16_0038 (B. Internes) |  | 5d | 2027-03-26 | 2027-04-05 | 771 | 365d |  | Déménagement externe; Direction du laboratoire | 70h |
| 779 | 7.3.4.6.9 | HE ? Vers 11101-16_0028 (B. Ing. Hémato/HMO) |  | 5d | 2027-03-26 | 2027-04-05 | 771 | 365d |  | Déménagement externe; Direction du laboratoire | 70h |
| 780 | 7.3.4.6.10 | HE ? Vers 11101-16_0030 (B. TL ONH/HMO) |  | 5d | 2027-03-26 | 2027-04-05 | 771 | 365d |  | Déménagement externe; Direction du laboratoire | 70h |
| 781 | 7.3.4.6.11 | HE ? Vers 11101-16_0039 (Secrétariat) |  | 5d | 2027-03-26 | 2027-04-05 | 771 | 365d |  | Déménagement externe; Direction du laboratoire | 70h |
| 782 | 7.3.4.6.12 | HE ? Vers 11101-16_0040 (PRA) |  | 5d | 2027-03-26 | 2027-04-05 | 771 | 365d |  | Déménagement externe; Direction du laboratoire | 70h |
| 783 | 7.3.4.6.13 | HE ? Vers 11101-16_0003 (PCR) |  | 5d | 2027-03-26 | 2027-04-05 | 771 | 365d |  | Déménagement externe; Direction du laboratoire | 70h |
| 784 | 7.3.4.6.14 | HE ? Vers 11101-16_0004 (Pièce Noire) |  | 5d | 2027-03-26 | 2027-04-05 | 771 | 365d |  | Déménagement externe; Direction du laboratoire | 70h |
| 785 | 7.3.4.6.15 | HE ? Vers 11101-16_0005 (Pré PCR) |  | 5d | 2027-03-26 | 2027-04-05 | 771 | 365d |  | Déménagement externe; Direction du laboratoire | 70h |
| 786 | 7.3.4.6.16 | HE ? Vers 11101-16_0007 (Secteur 3) |  | 5d | 2027-03-26 | 2027-04-05 | 771 | 365d |  | Déménagement externe; Direction du laboratoire | 70h |
| 787 | 7.3.4.6.17 | HE ? Vers 11101-16_0010 (Secteur 2) |  | 5d | 2027-03-26 | 2027-04-05 | 771 | 365d |  | Déménagement externe; Direction du laboratoire | 70h |
| 788 | 7.3.4.7 | Laboratoire Hématologie HE regroupé sur GM | milestone | 0d | 2027-04-05 | 2027-04-05 | 770 | 365d |  |  |  |

| ID | WBS | Task | Type | Duration | Start | Finish | Predecessors | Total slack | Free slack | Resources | Work |
| --- | --- | --- | --- | --- | --- | --- | --- | --- | --- | --- | --- |
| 789 | 7.4 | **SP09 - Phase 2 (zones tertiaires)** |  | 46d | 2027-04-12 | 2027-06-17 |  | 360d | 0d |  | 780.5h |
| 790 | 7.4.1 | **Pièces 11101-16_17, 20, 21, 22, 23, 24, 25, 41, 43 et 44 et pièces 11103-16_01, 04, 10 et 11** |  | 46d | 2027-04-12 | 2027-06-17 |  | 360d |  |  | 763h |
| 791 | 7.4.1.1 | Déménagements Bureaux UHH | milestone | 0d | 2027-04-12 | 2027-04-12 | 271, 764 | 360d | 0d | Déménagement externe; Déménagement interne; Direction du laboratoire |  |
| 792 | 7.4.1.2 | Consignation |  | 1d | 2027-04-12 | 2027-04-13 | 791 | 360d | 0d | Services techniques | 7h |
| 793 | 7.4.1.3 | Dépose équipements CFO |  | 3d | 2027-04-13 | 2027-04-16 | 792 | 360d | 0d | Lot 01 : Courants forts | 21h |
| 794 | 7.4.1.4 | Dépose faux-plafond, curage sol et dépose cloison |  | 10d | 2027-04-16 | 2027-04-30 | 793 | 360d | 0d | Lot 08 : Curage, démolitions, platrerie, peinture, faux-plafonds | 70h |
| 795 | 7.4.1.5 | Cloisons neuves |  | 5d | 2027-04-20 | 2027-04-27 | 794SS+2d | 367d | 7d | Lot 08 : Curage, démolitions, platrerie, peinture, faux-plafonds | 35h |
| 796 | 7.4.1.6 | Pose nouveaux réseaux CFO |  | 10d | 2027-04-22 | 2027-05-07 | 794SS+4d | 360d | 0d | Lot 01 : Courants forts | 70h |
| 797 | 7.4.1.7 | Pose nouveaux réseaux CFA |  | 10d | 2027-04-22 | 2027-05-07 | 794SS+4d | 360d | 0d | Lot 02 : Courants faibles | 70h |
| 798 | 7.4.1.8 | Dépose radiateurs, déplacement réseau radiateur |  | 5d | 2027-05-07 | 2027-05-14 | 795, 796, 797 | 360d | 0d | Lot 03 : Chauffage, climatisation, ventilation, plomberie | 35h |
| 799 | 7.4.1.9 | Pose faux plafonds neuf |  | 10d | 2027-05-14 | 2027-05-31 | 798 | 360d | 0d | Lot 08 : Curage, démolitions, platrerie, peinture, faux-plafonds | 70h |
| 800 | 7.4.1.10 | Pose équipements CFO |  | 10d | 2027-05-11 | 2027-05-26 | 798SS+2d | 363d | 3d | Lot 01 : Courants forts | 70h |
| 801 | 7.4.1.11 | Pose équipements CFA |  | 10d | 2027-05-11 | 2027-05-26 | 798SS+2d | 363d | 3d | Lot 02 : Courants faibles | 70h |
| 802 | 7.4.1.12 | Peinture radiateurs |  | 10d | 2027-05-13 | 2027-05-28 | 798SS+4d | 361d | 1d | Lot 08 : Curage, démolitions, platrerie, peinture, faux-plafonds | 70h |
| 803 | 7.4.1.13 | Finitions murales |  | 10d | 2027-05-13 | 2027-05-28 | 798SS+4d | 361d | 1d | Lot 08 : Curage, démolitions, platrerie, peinture, faux-plafonds | 70h |
| 804 | 7.4.1.14 | Pose stores |  | 2d | 2027-05-31 | 2027-06-02 | 800, 801, 802, 799, 803 | 361d | 1d | Lot 09 : Menuiseries extérieures, cloisons vitrées, protections solaires | 14h |
| 805 | 7.4.1.15 | Repose radiateurs |  | 3d | 2027-05-31 | 2027-06-03 | 800, 801, 802, 799, 803 | 360d | 0d | Lot 03 : Chauffage, climatisation, ventilation, plomberie | 21h |
| 806 | 7.4.1.16 | Pose sol |  | 10d | 2027-06-03 | 2027-06-17 | 805, 804 | 360d |  | Lot 07 : Sols souples, protections murales | 70h |
| 807 | 7.4.2 | **Pièce 11103-16_0005** |  | 1.5d | 2027-04-12 | 2027-04-13 |  | 404.5d |  |  | 17.5h |
| 808 | 7.4.2.1 | Consignation |  | 0.5d | 2027-04-12 | 2027-04-12 | 791 | 404.5d | 0d | Services techniques | 3.5h |
| 809 | 7.4.2.2 | Ajout CFO |  | 1d | 2027-04-13 | 2027-04-13 | 808 | 404.5d |  | Lot 01 : Courants forts | 7h |
| 810 | 7.4.2.3 | Ajout CFA |  | 1d | 2027-04-13 | 2027-04-13 | 808 | 404.5d |  | Lot 02 : Courants faibles | 7h |
| 811 | 7.5 | Réception phase 2 |  | 1d | 2027-06-17 | 2027-06-18 | 789 | 360d | 0d | Lot 01 : Courants forts; Lot 02 : Courants faibles; Lot 03 : Chauffage, climatisation, ventilation, plomberie; Lot 07 : Sols souples, protections murales; Lot 08 : Curage, démolitions, platrerie, peinture, faux-plafonds; Lot 09 : Menuiseries extérieures, cloisons vitrées, protections solaires | 42h |
| 812 | 7.6 | **Déménagements phase 2** |  | 5d | 2027-06-18 | 2027-06-25 |  | 360d | 0d |  | 959h |
| 813 | 7.6.1 | Nettoyage avant installation installation (11101-16_0017/20/21/22/23/24/25/41/42/43 11103-16_0001/04/05/10/11) |  | 2d | 2027-06-18 | 2027-06-22 | 811 | 360d | 0d | Prestataire entretien des locaux | 14h |
| 814 | 7.6.2 | HE ? Vers 11101-16_0041 (B. Lebecque) |  | 3d | 2027-06-22 | 2027-06-25 | 813 | 360d |  | Déménagement externe; Déménagement interne; Direction du laboratoire | 63h |
| 815 | 7.6.3 | HE ? Vers 11101-16_0042 (J. Besombes) |  | 3d | 2027-06-22 | 2027-06-25 | 813 | 360d |  | Déménagement externe; Déménagement interne; Direction du laboratoire | 63h |
| 816 | 7.6.4 | HE ? Vers 11101-16_0043 (L. Véronèse / T.Tassin) |  | 3d | 2027-06-22 | 2027-06-25 | 813 | 360d |  | Déménagement externe; Déménagement interne; Direction du laboratoire | 63h |
| 817 | 7.6.5 | HE ? Vers 11101-16_0044 (A. Tchirkov) |  | 3d | 2027-06-22 | 2027-06-25 | 813 | 360d |  | Déménagement externe; Déménagement interne; Direction du laboratoire | 63h |
| 818 | 7.6.6 | HE ? Vers 11101-16_0017 (MA.Coudoré/V.Jury/E.Tourret) |  | 3d | 2027-06-22 | 2027-06-25 | 813 | 360d |  | Déménagement externe; Déménagement interne; Direction du laboratoire | 63h |
| 819 | 7.6.7 | HE ? Vers 11101-16_0020 (S. Lamoine/M. Maugis) |  | 3d | 2027-06-22 | 2027-06-25 | 813 | 360d |  | Déménagement externe; Déménagement interne; Direction du laboratoire | 63h |
| 820 | 7.6.8 | HE ? Vers 11101-16_0021 (AF.Sapin/L.Talon) |  | 3d | 2027-06-22 | 2027-06-25 | 813 | 360d |  | Déménagement externe; Déménagement interne; Direction du laboratoire | 63h |
| 821 | 7.6.9 | HE ? Vers 11101-16_0022 (T. Sinègre) |  | 3d | 2027-06-22 | 2027-06-25 | 813 | 360d |  | Déménagement externe; Déménagement interne; Direction du laboratoire | 63h |
| 822 | 7.6.10 | HE ? Vers 11101-16_0023 (A.Lebreton) |  | 3d | 2027-06-22 | 2027-06-25 | 813 | 360d |  | Déménagement externe; Déménagement interne; Direction du laboratoire | 63h |
| 823 | 7.6.11 | HE ? Vers 11101-16_0024 (R.Veyrat-Masson) |  | 3d | 2027-06-22 | 2027-06-25 | 813 | 360d |  | Déménagement externe; Déménagement interne; Direction du laboratoire | 63h |
| 824 | 7.6.12 | HE ? Vers 11101-16_0025 (LT.Dannus) |  | 3d | 2027-06-22 | 2027-06-25 | 813 | 360d |  | Déménagement externe; Déménagement interne; Direction du laboratoire | 63h |
| 825 | 7.6.13 | HE ? Vers 11103-16_0001 (Ingé/Assistant/AHU) |  | 3d | 2027-06-22 | 2027-06-25 | 813 | 360d |  | Déménagement externe; Déménagement interne; Direction du laboratoire | 63h |
| 826 | 7.6.14 | HE ? Vers 11103-16_0004 (M.Berger) |  | 3d | 2027-06-22 | 2027-06-25 | 813 | 360d |  | Déménagement externe; Déménagement interne; Direction du laboratoire | 63h |
| 827 | 7.6.15 | HE ? Vers 11103-16_0010 (ARC/Chef Projet R&D) |  | 3d | 2027-06-22 | 2027-06-25 | 813 | 360d |  | Déménagement externe; Déménagement interne; Direction du laboratoire | 63h |
| 828 | 7.6.16 | HE ? Vers 11103-16_0011 (Cadre) |  | 3d | 2027-06-22 | 2027-06-25 | 813 | 360d |  | Déménagement externe; Déménagement interne; Direction du laboratoire | 63h |
| 829 | 7.7 | Emménagement Hémato Estaing (hors hémostase) | milestone | 0d | 2027-06-25 | 2027-06-25 | 812, 770 | 360d |  | Déménagement externe; Déménagement interne; Direction du laboratoire |  |

| ID | WBS | Task | Type | Duration | Start | Finish | Predecessors | Total slack | Resources | Work |
| --- | --- | --- | --- | --- | --- | --- | --- | --- | --- | --- |
| 830 | 7.8 | **SP09 - Phase 3** |  | 56.5d | 2028-02-29 | 2028-05-22 |  | 0d |  | 1221.5h |
| 831 | 7.8.1 | RAPPEL : Emménagement HH dans les locaux définitifs | milestone | 0d | 2028-02-29 | 2028-02-29 | 690 | 0d |  |  |
| 832 | 7.8.2 | **Pièces 11101-11a, 11b, 12, 13, 14, 16, 18, 19 et 47** |  | 56.5d | 2028-02-29 | 2028-05-22 |  | 0d |  | 1221.5h |
| 833 | 7.8.2.1 | Neutralisation réseaux (consignations) |  | 0.5d | 2028-02-29 | 2028-02-29 | 831 | 0d | Services techniques | 3.5h |
| 834 | 7.8.2.2 | Déconnexion paillasse plomberie, dépose équipements de plomberie et CVC |  | 2d | 2028-03-01 | 2028-03-02 | 833 | 0d | Lot 03 : Chauffage, climatisation, ventilation, plomberie | 14h |
| 835 | 7.8.2.3 | Déconnexion paillasse CFO et luminaires |  | 2d | 2028-03-01 | 2028-03-02 | 833 | 0d | Lot 01 : Courants forts | 14h |
| 836 | 7.8.2.4 | Déconnexion paillasse CFA |  | 2d | 2028-03-01 | 2028-03-02 | 833 | 0d | Lot 02 : Courants faibles | 14h |
| 837 | 7.8.2.5 | Enlèvement paillasse |  | 2d | 2028-03-03 | 2028-03-06 | 834, 835, 836 | 0d | Lot 08 : Curage, démolitions, platrerie, peinture, faux-plafonds | 14h |
| 838 | 7.8.2.6 | Curage FP, Sol, création d'ouverture cloisons |  | 5d | 2028-03-07 | 2028-03-13 | 837 | 0d | Lot 08 : Curage, démolitions, platrerie, peinture, faux-plafonds | 35h |
| 839 | 7.8.2.7 | Renforts cloisons |  | 1d | 2028-03-07 | 2028-03-07 | 837 | 51d | Lot 10 : Cloisons et plafonds agroalimentaires | 7h |
| 840 | 7.8.2.8 | Création de cloison et étoupements |  | 20d | 2028-03-14 | 2028-04-10 | 838 | 0d | Lot 08 : Curage, démolitions, platrerie, peinture, faux-plafonds | 140h |
| 841 | 7.8.2.9 | Réseaux neufs CFO |  | 20d | 2028-03-14 | 2028-04-10 | 838 | 0d | Lot 01 : Courants forts | 140h |
| 842 | 7.8.2.10 | Réseaux neufs CFA |  | 20d | 2028-03-14 | 2028-04-10 | 838 | 0d | Lot 02 : Courants faibles | 140h |
| 843 | 7.8.2.11 | Réseaux neufs CVC, plomberie |  | 20d | 2028-03-14 | 2028-04-10 | 838 | 0d | Lot 03 : Chauffage, climatisation, ventilation, plomberie | 140h |
| 844 | 7.8.2.12 | Cloisons et portes vitrées |  | 10d | 2028-03-14 | 2028-03-27 | 838 | 10d | Lot 09 : Menuiseries extérieures, cloisons vitrées, protections solaires | 70h |
| 845 | 7.8.2.13 | Pose FP |  | 10d | 2028-04-11 | 2028-04-25 | 840, 841, 842, 843, 844 | 0d | Lot 08 : Curage, démolitions, platrerie, peinture, faux-plafonds | 70h |
| 846 | 7.8.2.14 | Pose équipement CFO |  | 10d | 2028-04-13 | 2028-04-27 | 845SS+2d | 5d | Lot 01 : Courants forts | 70h |
| 847 | 7.8.2.15 | Pose équipements CVC |  | 10d | 2028-04-13 | 2028-04-27 | 845SS+2d | 5d | Lot 03 : Chauffage, climatisation, ventilation, plomberie | 70h |
| 848 | 7.8.2.16 | Pose équipements CFA |  | 10d | 2028-04-13 | 2028-04-27 | 845SS+2d | 15d | Lot 02 : Courants faibles | 70h |
| 849 | 7.8.2.17 | Finitions murales |  | 10d | 2028-04-18 | 2028-05-02 | 845SS+4d | 3d | Lot 07 : Sols souples, protections murales | 70h |
| 850 | 7.8.2.18 | Pose sol |  | 10d | 2028-04-21 | 2028-05-05 | 845SS+7d | 0d | Lot 07 : Sols souples, protections murales | 70h |
| 851 | 7.8.2.19 | Installation paillasses |  | 10d | 2028-05-09 | 2028-05-22 | 846, 847, 849, 850 | 0d | Lot 06 : Paillasses, matériel de laboratoire | 70h |
| 852 | 7.9 | Réception phase |  | 1d | 2028-05-23 | 2028-05-23 | 830 | 0d | Lot 01 : Courants forts; Lot 02 : Courants faibles; Lot 03 : Chauffage, climatisation, ventilation, plomberie; Lot 06 : Paillasses, matériel de laboratoire; Lot 07 : Sols souples, protections murales; Lot 08 : Curage, démolitions, platrerie, peinture, faux-plafonds; Lot 09 : Menuiseries extérieures, cloisons vitrées, protections solaires | 49h |
| 853 | 7.10 | **Déménagements phase 2** |  | 4d | 2028-05-24 | 2028-05-30 |  | 0d |  | 196h |
| 854 | 7.10.1 | Nettoyage avant installation installation (11101-16_0012/18/47) |  | 1d | 2028-05-24 | 2028-05-24 | 852 | 0d | Prestataire entretien des locaux | 7h |
| 855 | 7.10.2 | 11101-13_00 vers 11101-16_0012 (Hémostase 1) |  | 3d | 2028-05-26 | 2028-05-30 | 854 | 0d | Déménagement externe; Déménagement interne; Direction du laboratoire | 63h |
| 856 | 7.10.3 | 11101-13_00 vers 11101-16_0018 (Hémostase 2) |  | 3d | 2028-05-26 | 2028-05-30 | 854 | 0d | Déménagement externe; Déménagement interne; Direction du laboratoire | 63h |
| 857 | 7.10.4 | 11101-13_00 vers 11101-16_0047 (Bureau) |  | 3d | 2028-05-26 | 2028-05-30 | 854 | 0d | Déménagement externe; Déménagement interne; Direction du laboratoire | 63h |
| 858 | 7.11 | Emménagement Hématostase | milestone | 0d | 2028-05-30 | 2028-05-30 | 853 | 0d | Déménagement externe; Déménagement interne; Direction du laboratoire |  |

| ID | WBS | Task | Duration | Start | Finish | Predecessors | Total slack | Free slack | Resources | Work |
| --- | --- | --- | --- | --- | --- | --- | --- | --- | --- | --- |
| 860 | 8 | **SP10 : 3ème étage** | 60.5d | 2028-05-31 | 2028-08-28 |  | 0d |  |  | 4581.5h |
| 861 | 8.1 | **Pièces 11101-13_05, 14, 15, 16,18, 19, 20, 20bis, 22 et 23** | 51.5d | 2028-05-31 | 2028-08-14 |  | 0d |  |  | 1144.5h |
| 862 | 8.1.1 | Neutralisation réseaux (consignations) | 0.5d | 2028-05-31 | 2028-05-31 | 858 | 0d |  | Services techniques | 3.5h |
| 863 | 8.1.2 | Renfort des plafonds marchables au 2e étage | 1d | 2028-05-31 | 2028-06-01 | 862 | 0d |  | Lot 10 : Cloisons et plafonds agroalimentaires | 7h |
| 864 | 8.1.3 | Déconnexion paillasse plomberie, dépose équipements de plomberie et CVC | 3d | 2028-06-01 | 2028-06-07 | 863 | 0d |  | Lot 03 : Chauffage, climatisation, ventilation, plomberie | 21h |
| 865 | 8.1.4 | Déconnexion paillasse CFO et luminaires | 1d | 2028-06-01 | 2028-06-02 | 863 | 2d |  | Lot 01 : Courants forts | 7h |
| 866 | 8.1.5 | Déconnexion paillasse CFA | 1d | 2028-06-01 | 2028-06-02 | 863 | 2d |  | Lot 02 : Courants faibles | 7h |
| 867 | 8.1.6 | Enlèvement paillasse | 2d | 2028-06-07 | 2028-06-09 | 864, 865, 866 | 0d |  | Lot 08 : Curage, démolitions, platrerie, peinture, faux-plafonds | 14h |
| 868 | 8.1.7 | Curage FP, Sol, création d'ouverture cloisons | 4d | 2028-06-09 | 2028-06-15 | 867 | 0d |  | Lot 08 : Curage, démolitions, platrerie, peinture, faux-plafonds | 28h |
| 869 | 8.1.8 | Renforts cloisons | 1d | 2028-06-09 | 2028-06-12 | 867 | 44d |  |  |  |
| 870 | 8.1.9 | Création de cloison et étoupements | 20d | 2028-06-15 | 2028-07-13 | 868 | 0d |  | Lot 08 : Curage, démolitions, platrerie, peinture, faux-plafonds | 140h |
| 871 | 8.1.10 | Réseaux neufs CFO | 20d | 2028-06-15 | 2028-07-13 | 868 | 0d |  | Lot 01 : Courants forts | 140h |
| 872 | 8.1.11 | Réseaux neufs CFA | 20d | 2028-06-15 | 2028-07-13 | 868 | 0d |  | Lot 02 : Courants faibles | 140h |
| 873 | 8.1.12 | Réseaux neufs CVC, plomberie | 20d | 2028-06-15 | 2028-07-13 | 868 | 0d |  | Lot 03 : Chauffage, climatisation, ventilation, plomberie | 140h |
| 874 | 8.1.13 | Réseaux neuf fluides médicaux | 20d | 2028-06-15 | 2028-07-13 | 868 | 21d |  | Lot 04 : Fluides de laboratoire | 140h |
| 875 | 8.1.14 | Cloisons et portes vitrées | 20d | 2028-06-15 | 2028-07-13 | 868 | 21d |  | Lot 09 : Menuiseries extérieures, cloisons vitrées, protections solaires | 140h |
| 876 | 8.1.15 | Pose FP | 4d | 2028-07-13 | 2028-07-20 | 870, 871, 872, 873 | 0d |  | Lot 08 : Curage, démolitions, platrerie, peinture, faux-plafonds | 28h |
| 877 | 8.1.16 | Pose équipement CFO | 5d | 2028-07-20 | 2028-07-27 | 876 | 0d |  | Lot 01 : Courants forts | 35h |
| 878 | 8.1.17 | Pose équipements CVC | 5d | 2028-07-20 | 2028-07-27 | 876 | 0d |  | Lot 03 : Chauffage, climatisation, ventilation, plomberie | 35h |
| 879 | 8.1.18 | Pose équipements CFA | 5d | 2028-07-20 | 2028-07-27 | 876 | 0d |  | Lot 02 : Courants faibles | 35h |
| 880 | 8.1.19 | Finitions murales | 5d | 2028-07-27 | 2028-08-03 | 878, 877, 879 | 0d |  | Lot 07 : Sols souples, protections murales | 35h |
| 881 | 8.1.20 | Pose sol | 5d | 2028-08-03 | 2028-08-10 | 880 | 0d |  | Lot 07 : Sols souples, protections murales | 35h |
| 882 | 8.1.21 | Installation paillasses et sorbonnes | 2d | 2028-08-10 | 2028-08-14 | 881 | 0d |  | Lot 06 : Paillasses, matériel de laboratoire | 14h |
| 883 | 8.2 | **Pièces 11101-13_04** | 34.5d | 2028-05-31 | 2028-07-20 |  | 17d |  |  | 605.5h |
| 884 | 8.2.1 | Neutralisation réseaux (consignations) | 0.5d | 2028-05-31 | 2028-05-31 | 858 | 17d | 0d | Services techniques | 3.5h |
| 885 | 8.2.2 | Déconnexion CFO et luminaires | 1d | 2028-05-31 | 2028-06-01 | 884 | 17d | 0d | Lot 01 : Courants forts | 7h |
| 886 | 8.2.3 | Déconnexion CFA | 1d | 2028-05-31 | 2028-06-01 | 884 | 17d | 0d | Lot 02 : Courants faibles | 7h |
| 887 | 8.2.4 | Curage FP | 4d | 2028-06-01 | 2028-06-08 | 885, 886 | 17d | 0d | Lot 08 : Curage, démolitions, platrerie, peinture, faux-plafonds | 28h |
| 888 | 8.2.5 | Etoupements de cloisons CF | 1d | 2028-06-08 | 2028-06-09 | 887 | 45d |  | Lot 08 : Curage, démolitions, platrerie, peinture, faux-plafonds | 7h |
| 889 | 8.2.6 | Réseaux neufs CFO | 20d | 2028-06-08 | 2028-07-06 | 887 | 17d | 0d | Lot 01 : Courants forts | 140h |
| 890 | 8.2.7 | Réseaux neufs CFA | 20d | 2028-06-08 | 2028-07-06 | 887 | 17d | 0d | Lot 02 : Courants faibles | 140h |
| 891 | 8.2.8 | Réseaux neufs CVC, plomberie | 20d | 2028-06-08 | 2028-07-06 | 887 | 17d | 0d | Lot 03 : Chauffage, climatisation, ventilation, plomberie | 140h |
| 892 | 8.2.9 | Pose FP | 4d | 2028-07-06 | 2028-07-12 | 889, 890, 891 | 17d | 0d | Lot 08 : Curage, démolitions, platrerie, peinture, faux-plafonds | 28h |
| 893 | 8.2.10 | Pose équipement CFO | 5d | 2028-07-12 | 2028-07-20 | 892 | 17d |  | Lot 01 : Courants forts | 35h |
| 894 | 8.2.11 | Pose équipements CVC | 5d | 2028-07-12 | 2028-07-20 | 892 | 17d |  | Lot 03 : Chauffage, climatisation, ventilation, plomberie | 35h |
| 895 | 8.2.12 | Pose équipements CFA | 5d | 2028-07-12 | 2028-07-20 | 892 | 17d |  | Lot 02 : Courants faibles | 35h |

| ID | WBS | Task | Duration | Start | Finish | Predecessors | Total slack | Free slack | Resources | Work |
| --- | --- | --- | --- | --- | --- | --- | --- | --- | --- | --- |
| 896 | 8.3 | **Pièces 11101-13_0044 et 49** | 8.5d | 2028-05-31 | 2028-06-13 |  | 42.5d |  |  | 70h |
| 897 | 8.3.1 | Consignations | 0.5d | 2028-05-31 | 2028-05-31 | 858FS+0.5d | 42.5d | 0d | Services techniques | 3.5h |
| 898 | 8.3.2 | Dépose équipement de plomberie | 0.5d | 2028-06-01 | 2028-06-01 | 897 | 42.5d | 0d | Lot 03 : Chauffage, climatisation, ventilation, plomberie | 3.5h |
| 899 | 8.3.3 | Dépose paillasse | 0.5d | 2028-06-01 | 2028-06-01 | 897 | 42.5d | 0d | Lot 08 : Curage, démolitions, platrerie, peinture, faux-plafonds | 3.5h |
| 900 | 8.3.4 | Curage sol dans le SAS | 0.5d | 2028-06-01 | 2028-06-01 | 898, 899 | 42.5d | 0d | Lot 08 : Curage, démolitions, platrerie, peinture, faux-plafonds | 3.5h |
| 901 | 8.3.5 | Création réseau plomberie | 1d | 2028-06-02 | 2028-06-02 | 900 | 48.5d |  | Lot 03 : Chauffage, climatisation, ventilation, plomberie | 7h |
| 902 | 8.3.6 | Ajouts CFO | 2d | 2028-06-02 | 2028-06-06 | 900 | 42.5d | 0d | Lot 01 : Courants forts | 14h |
| 903 | 8.3.7 | Changement porte | 0.5d | 2028-06-07 | 2028-06-07 | 902 | 42.5d | 0d | Lot 10 : Cloisons et plafonds agroalimentaires | 3.5h |
| 904 | 8.3.8 | Finitions mur | 1d | 2028-06-07 | 2028-06-08 | 903 | 42.5d | 0d | Lot 07 : Sols souples, protections murales | 7h |
| 905 | 8.3.9 | Pose sol dans le SAS | 3d | 2028-06-08 | 2028-06-13 | 904 | 42.5d | 0d | Lot 07 : Sols souples, protections murales | 21h |
| 906 | 8.3.10 | Pose paillasse humide | 0.5d | 2028-06-13 | 2028-06-13 | 905 | 42.5d |  | Lot 06 : Paillasses, matériel de laboratoire | 3.5h |
| 907 | 8.4 | **Pièce 11101-13_0041** | 2.5d | 2028-06-01 | 2028-06-06 |  | 48d |  |  | 17.5h |
| 908 | 8.4.1 | Consignation | 0.5d | 2028-06-01 | 2028-06-01 | 858FS+1d | 48d | 0d | Services techniques | 3.5h |
| 909 | 8.4.2 | Deconnexion paillasse humide | 0.5d | 2028-06-01 | 2028-06-01 | 908 | 48d | 0d | Lot 03 : Chauffage, climatisation, ventilation, plomberie | 3.5h |
| 910 | 8.4.3 | Dépose paillasses | 0.5d | 2028-06-02 | 2028-06-02 | 909 | 48d | 0d | Lot 08 : Curage, démolitions, platrerie, peinture, faux-plafonds | 3.5h |
| 911 | 8.4.4 | Pose paillasses neuves | 1d | 2028-06-02 | 2028-06-06 | 910 | 48d |  | Lot 06 : Paillasses, matériel de laboratoire | 7h |
| 912 | 8.5 | **Pièces 11103-13_0001 et 0004** | 9.5d | 2028-06-01 | 2028-06-15 |  | 40.5d |  |  | 80.5h |
| 913 | 8.5.1 | Consignations | 0.5d | 2028-06-01 | 2028-06-01 | 858FS+1.5d | 40.5d | 0d | Services techniques | 3.5h |
| 914 | 8.5.2 | Ajouts CFO | 2d | 2028-06-02 | 2028-06-06 | 913 | 40.5d | 0d | Lot 01 : Courants forts | 14h |
| 915 | 8.5.3 | Ajouts CFA | 2d | 2028-06-02 | 2028-06-06 | 913 | 47.5d |  | Lot 02 : Courants faibles | 14h |
| 916 | 8.5.4 | Dépose sol | 1d | 2028-06-07 | 2028-06-07 | 914 | 40.5d | 0d | Lot 08 : Curage, démolitions, platrerie, peinture, faux-plafonds | 7h |
| 917 | 8.5.5 | Finitions murales | 3d | 2028-06-08 | 2028-06-12 | 916 | 40.5d | 0d | Lot 08 : Curage, démolitions, platrerie, peinture, faux-plafonds | 21h |
| 918 | 8.5.6 | Pose sol | 3d | 2028-06-13 | 2028-06-15 | 917 | 40.5d |  | Lot 07 : Sols souples, protections murales | 21h |
| 919 | 8.6 | **Pièces 11101-13_0006 et 7** | 13.5d | 2028-06-02 | 2028-06-22 |  | 36d |  |  | 154h |
| 920 | 8.6.1 | Consignation | 0.5d | 2028-06-02 | 2028-06-02 | 858FS+2d | 36d | 0d | Services techniques | 3.5h |
| 921 | 8.6.2 | Dépose équipements CFO | 0.5d | 2028-06-02 | 2028-06-02 | 920 | 36d | 0d | Lot 01 : Courants forts | 3.5h |
| 922 | 8.6.3 | Dépose faux-plafond et curage sol | 2d | 2028-06-06 | 2028-06-07 | 921 | 36d | 0d | Lot 08 : Curage, démolitions, platrerie, peinture, faux-plafonds | 14h |
| 923 | 8.6.4 | Pose nouveaux réseaux CFO | 2d | 2028-06-08 | 2028-06-09 | 922 | 36d | 0d | Lot 01 : Courants forts | 14h |
| 924 | 8.6.5 | Pose nouveaux réseaux CFA | 2d | 2028-06-08 | 2028-06-09 | 922 | 36d | 0d | Lot 02 : Courants faibles | 14h |
| 925 | 8.6.6 | Dépose radiateurs, déplacement réseau radiateur | 2d | 2028-06-08 | 2028-06-09 | 922 | 36d | 0d | Lot 03 : Chauffage, climatisation, ventilation, plomberie | 14h |
| 926 | 8.6.7 | Pose faux plafonds neuf | 2d | 2028-06-12 | 2028-06-13 | 923, 924, 925 | 36d | 0d | Lot 08 : Curage, démolitions, platrerie, peinture, faux-plafonds | 14h |
| 927 | 8.6.8 | Pose équipements CFO | 1d | 2028-06-14 | 2028-06-14 | 926 | 38d | 2d | Lot 01 : Courants forts | 7h |
| 928 | 8.6.9 | Pose équipements CFA | 1d | 2028-06-14 | 2028-06-14 | 926 | 38d | 2d | Lot 02 : Courants faibles | 7h |
| 929 | 8.6.10 | Peinture radiateurs | 2d | 2028-06-14 | 2028-06-15 | 926 | 37d | 1d | Lot 08 : Curage, démolitions, platrerie, peinture, faux-plafonds | 14h |
| 930 | 8.6.11 | Finitions murales | 3d | 2028-06-14 | 2028-06-16 | 926 | 36d | 0d | Lot 08 : Curage, démolitions, platrerie, peinture, faux-plafonds | 21h |
| 931 | 8.6.12 | Pose stores | 0.5d | 2028-06-14 | 2028-06-14 | 926 | 38.5d | 2.5d | Lot 09 : Menuiseries extérieures, cloisons vitrées, protections solaires | 3.5h |
| 932 | 8.6.13 | Repose radiateurs | 0.5d | 2028-06-19 | 2028-06-19 | 929, 930, 927, 928, 931 | 36d | 0d | Lot 03 : Chauffage, climatisation, ventilation, plomberie | 3.5h |
| 933 | 8.6.14 | Pose sol | 3d | 2028-06-19 | 2028-06-22 | 932 | 36d |  | Lot 07 : Sols souples, protections murales | 21h |

| ID | WBS | Task | Duration | Start | Finish | Predecessors | Total slack | Free slack | Resources | Work |
| --- | --- | --- | --- | --- | --- | --- | --- | --- | --- | --- |
| 934 | 8.7 | **Pièces 11101-13_0037, 37bis et 38** | 21.5d | 2028-06-02 | 2028-07-04 |  | 27.5d |  |  | 238h |
| 935 | 8.7.1 | Consignation | 0.5d | 2028-06-02 | 2028-06-02 | 858FS+2.5d | 27.5d | 0d | Services techniques | 3.5h |
| 936 | 8.7.2 | Dépose équipements CFO | 0.5d | 2028-06-06 | 2028-06-06 | 935 | 27.5d | 0d | Lot 01 : Courants forts | 3.5h |
| 937 | 8.7.3 | Dépose faux-plafond, curage sol et dépose cloison | 3d | 2028-06-06 | 2028-06-09 | 936 | 27.5d | 0d | Lot 08 : Curage, démolitions, platrerie, peinture, faux-plafonds | 21h |
| 938 | 8.7.4 | Cloisons neuves | 5d | 2028-06-09 | 2028-06-16 | 937 | 27.5d | 0d | Lot 08 : Curage, démolitions, platrerie, peinture, faux-plafonds | 35h |
| 939 | 8.7.5 | Pose nouveaux réseaux CFO | 5d | 2028-06-09 | 2028-06-16 | 937 | 27.5d | 0d | Lot 01 : Courants forts | 35h |
| 940 | 8.7.6 | Pose nouveaux réseaux CFA | 5d | 2028-06-09 | 2028-06-16 | 937 | 27.5d | 0d | Lot 02 : Courants faibles | 35h |
| 941 | 8.7.7 | Dépose radiateurs, déplacement réseau radiateur | 2d | 2028-06-16 | 2028-06-20 | 938, 939, 940 | 27.5d | 0d | Lot 03 : Chauffage, climatisation, ventilation, plomberie | 14h |
| 942 | 8.7.8 | Pose faux plafonds neuf | 2d | 2028-06-20 | 2028-06-22 | 941 | 27.5d | 0d | Lot 08 : Curage, démolitions, platrerie, peinture, faux-plafonds | 14h |
| 943 | 8.7.9 | Pose équipements CFO | 1d | 2028-06-22 | 2028-06-23 | 942 | 28.5d | 1d | Lot 01 : Courants forts | 7h |
| 944 | 8.7.10 | Pose équipements CFA | 1d | 2028-06-22 | 2028-06-23 | 942 | 28.5d | 1d | Lot 02 : Courants faibles | 7h |
| 945 | 8.7.11 | Peinture radiateurs | 2d | 2028-06-22 | 2028-06-26 | 942 | 27.5d | 0d | Lot 08 : Curage, démolitions, platrerie, peinture, faux-plafonds | 14h |
| 946 | 8.7.12 | Finitions murales | 3d | 2028-06-26 | 2028-06-29 | 943, 945, 944 | 27.5d | 0d | Lot 08 : Curage, démolitions, platrerie, peinture, faux-plafonds | 21h |
| 947 | 8.7.13 | Pose stores | 0.5d | 2028-06-26 | 2028-06-26 | 943, 945, 944 | 30d | 2.5d | Lot 09 : Menuiseries extérieures, cloisons vitrées, protections solaires | 3.5h |
| 948 | 8.7.14 | Repose radiateurs | 0.5d | 2028-06-29 | 2028-06-29 | 946, 947 | 27.5d | 0d | Lot 03 : Chauffage, climatisation, ventilation, plomberie | 3.5h |
| 949 | 8.7.15 | Pose sol | 3d | 2028-06-30 | 2028-07-04 | 948 | 27.5d |  | Lot 07 : Sols souples, protections murales | 21h |
| 950 | 8.8 | **Pièce 11101-13_0009** | 7.5d | 2028-05-31 | 2028-06-12 |  | 44d |  |  | 52.5h |
| 951 | 8.8.1 | Ouverture gaine | 0.5d | 2028-05-31 | 2028-05-31 | 858 | 44d | 0d | Lot 08 : Curage, démolitions, platrerie, peinture, faux-plafonds | 3.5h |
| 952 | 8.8.2 | Passage réseau CVC | 2d | 2028-05-31 | 2028-06-02 | 951 | 44d | 0d | Lot 03 : Chauffage, climatisation, ventilation, plomberie | 14h |
| 953 | 8.8.3 | Fermeture gaine | 2d | 2028-06-02 | 2028-06-07 | 952 | 44d | 0d | Lot 08 : Curage, démolitions, platrerie, peinture, faux-plafonds | 14h |
| 954 | 8.8.4 | Finitions gaine | 3d | 2028-06-07 | 2028-06-12 | 953 | 44d |  | Lot 08 : Curage, démolitions, platrerie, peinture, faux-plafonds | 21h |
| 955 | 8.9 | **Pièce 11101-13_0034** | 2d | 2028-05-31 | 2028-06-01 |  | 49.5d |  |  | 31.5h |
| 956 | 8.9.1 | Dépose paillasse | 0.5d | 2028-05-31 | 2028-05-31 | 858 | 51d |  | Lot 08 : Curage, démolitions, platrerie, peinture, faux-plafonds | 3.5h |
| 957 | 8.9.2 | Ajout CFO | 2d | 2028-05-31 | 2028-06-01 | 858 | 49.5d |  | Lot 01 : Courants forts | 14h |
| 958 | 8.9.3 | Ajout CFA | 2d | 2028-05-31 | 2028-06-01 | 858 | 49.5d |  | Lot 02 : Courants faibles | 14h |

| ID | WBS | Task | Duration | Start | Finish | Predecessors | Total slack | Free slack | Resources | Work |
| --- | --- | --- | --- | --- | --- | --- | --- | --- | --- | --- |
| 959 | 8.10 | **Pièces 11101-13_0047 et 48** | 31.5d | 2028-06-02 | 2028-07-19 |  | 17.5d |  |  | 402.5h |
| 960 | 8.10.1 | Neutralisation réseaux (consignations) | 0.5d | 2028-06-02 | 2028-06-02 | 858SF+3d | 17.5d | 0d | Services techniques | 3.5h |
| 961 | 8.10.2 | Déconnexion paillasse plomberie, dépose équipements de plomberie et CVC | 3d | 2028-06-06 | 2028-06-08 | 960 | 17.5d | 0d | Lot 03 : Chauffage, climatisation, ventilation, plomberie | 21h |
| 962 | 8.10.3 | Déconnexion paillasse CFO et luminaires | 1d | 2028-06-06 | 2028-06-06 | 960 | 19.5d | 2d | Lot 01 : Courants forts | 7h |
| 963 | 8.10.4 | Déconnexion paillasse CFA | 1d | 2028-06-06 | 2028-06-06 | 960 | 19.5d | 2d | Lot 02 : Courants faibles | 7h |
| 964 | 8.10.5 | Enlèvement paillasse | 2d | 2028-06-09 | 2028-06-12 | 961, 962, 963 | 17.5d | 0d | Lot 08 : Curage, démolitions, platrerie, peinture, faux-plafonds | 14h |
| 965 | 8.10.6 | Dépose plafonds agro et renforts de cloisons | 4d | 2028-06-13 | 2028-06-16 | 964 | 39.5d |  | Lot 10 : Cloisons et plafonds agroalimentaires | 28h |
| 966 | 8.10.7 | Curage sol et cloisons | 6d | 2028-06-13 | 2028-06-20 | 964 | 17.5d | 0d | Lot 08 : Curage, démolitions, platrerie, peinture, faux-plafonds | 42h |
| 967 | 8.10.8 | Réseaux neufs CFO | 5d | 2028-06-21 | 2028-06-27 | 966 | 17.5d | 0d | Lot 01 : Courants forts | 35h |
| 968 | 8.10.9 | Réseaux neufs CFA | 5d | 2028-06-21 | 2028-06-27 | 966 | 17.5d | 0d | Lot 02 : Courants faibles | 35h |
| 969 | 8.10.10 | Réseaux neufs CVC | 5d | 2028-06-21 | 2028-06-27 | 966 | 17.5d | 0d | Lot 03 : Chauffage, climatisation, ventilation, plomberie | 35h |
| 970 | 8.10.11 | Pose plafond agro | 4d | 2028-06-28 | 2028-07-03 | 967, 968, 969 | 17.5d | 0d | Lot 10 : Cloisons et plafonds agroalimentaires | 28h |
| 971 | 8.10.12 | Pose équipement CFO | 5d | 2028-07-04 | 2028-07-10 | 970 | 17.5d | 0d | Lot 01 : Courants forts | 35h |
| 972 | 8.10.13 | Pose équipements CVC | 5d | 2028-07-04 | 2028-07-10 | 970 | 17.5d | 0d | Lot 03 : Chauffage, climatisation, ventilation, plomberie | 35h |
| 973 | 8.10.14 | Pose équipements CFA | 5d | 2028-07-04 | 2028-07-10 | 970 | 17.5d | 0d | Lot 02 : Courants faibles | 35h |
| 974 | 8.10.15 | Finitions murales | 2d | 2028-07-11 | 2028-07-12 | 971, 972, 973 | 17.5d | 0d | Lot 07 : Sols souples, protections murales | 14h |
| 975 | 8.10.16 | Pose sol | 3d | 2028-07-13 | 2028-07-18 | 974 | 17.5d | 0d | Lot 07 : Sols souples, protections murales | 21h |
| 976 | 8.10.17 | Installation paillasses | 1d | 2028-07-19 | 2028-07-19 | 975 | 17.5d |  | Lot 06 : Paillasses, matériel de laboratoire | 7h |
| 977 | 8.11 | Réception SP10 | 1d | 2028-08-14 | 2028-08-16 | 861, 896, 907, 912, 919, 934, 950, 955, 959, 883 | 0d |  | Lot 01 : Courants forts; Lot 02 : Courants faibles; Lot 03 : Chauffage, climatisation, ventilation, plomberie; Lot 06 : Paillasses, matériel de laboratoire; Lot 07 : Sols souples, protections murales; Lot 08 : Curage, démolitions, platrerie, peinture, faux-plafonds; Lot 09 : Menuiseries extérieures, cloisons vitrées, protections solaires; Lot 10 : Cloisons et plafonds agroalimentaires | 56h |
| 978 | 8.12 | **Déménagements** | 6d | 2028-08-16 | 2028-08-24 |  | 64d | 0d |  | 1687h |
| 979 | 8.12.1 | Nettoyage avant installation installation (11101-16_0012/18/47) | 1d | 2028-08-16 | 2028-08-17 | 977 | 64d | 0d | Prestataire entretien des locaux | 7h |
| 980 | 8.12.2 | HE vers 11101-13_0004 (Rangement) | 5d | 2028-08-17 | 2028-08-24 | 979 | 64d |  | Déménagement externe; Déménagement interne; Direction du laboratoire | 105h |
| 981 | 8.12.3 | HE vers 11101-13_0014 (Pièce Noire) | 5d | 2028-08-17 | 2028-08-24 | 979 | 64d |  | Déménagement externe; Déménagement interne; Direction du laboratoire | 105h |
| 982 | 8.12.4 | HE vers 11101-13_0018 (Pièce analyse) | 5d | 2028-08-17 | 2028-08-24 | 979 | 64d |  | Déménagement externe; Déménagement interne; Direction du laboratoire | 105h |
| 983 | 8.12.5 | HE vers 11101-13_0019 (Pièce TK) | 5d | 2028-08-17 | 2028-08-24 | 979 | 64d |  | Déménagement externe; Déménagement interne; Direction du laboratoire | 105h |
| 984 | 8.12.6 | HE vers 11101-13_0020 (Pièce Fish) | 5d | 2028-08-17 | 2028-08-24 | 979 | 64d |  | Déménagement externe; Déménagement interne; Direction du laboratoire | 105h |
| 985 | 8.12.7 | HE vers 11101-13_0021 (Culture Post.) | 5d | 2028-08-17 | 2028-08-24 | 979 | 64d |  | Déménagement externe; Déménagement interne; Direction du laboratoire | 105h |
| 986 | 8.12.8 | HE vers 11101-13_0022 (Pré nat.) | 5d | 2028-08-17 | 2028-08-24 | 979 | 64d |  | Déménagement externe; Déménagement interne; Direction du laboratoire | 105h |
| 987 | 8.12.9 | HE vers 11101-13_0022b (SAS) | 5d | 2028-08-17 | 2028-08-24 | 979 | 64d |  | Déménagement externe; Déménagement interne; Direction du laboratoire | 105h |
| 988 | 8.12.10 | HE vers 11101-13_0023 (Tk BM) | 5d | 2028-08-17 | 2028-08-24 | 979 | 64d |  | Déménagement externe; Déménagement interne; Direction du laboratoire | 105h |
| 989 | 8.12.11 | HE vers 11101-13_0048 (Pré PCR) | 5d | 2028-08-17 | 2028-08-24 | 979 | 64d |  | Déménagement externe; Déménagement interne; Direction du laboratoire | 105h |
| 990 | 8.12.12 | HE vers 11101-13_0007 (Bureau Med) | 5d | 2028-08-17 | 2028-08-24 | 979 | 64d |  | Déménagement externe; Déménagement interne; Direction du laboratoire | 105h |
| 991 | 8.12.13 | HE vers 11101-13_0006 (Secrétariat) | 5d | 2028-08-17 | 2028-08-24 | 979 | 64d |  | Déménagement externe; Déménagement interne; Direction du laboratoire | 105h |
| 992 | 8.12.14 | HE vers 11101-13_0037 (Salle vidéo P.) | 5d | 2028-08-17 | 2028-08-24 | 979 | 64d |  | Déménagement externe; Déménagement interne; Direction du laboratoire | 105h |
| 993 | 8.12.15 | HE vers 11101-13_0038 (Bureau Med.) | 5d | 2028-08-17 | 2028-08-24 | 979 | 64d |  | Déménagement externe; Déménagement interne; Direction du laboratoire | 105h |
| 994 | 8.12.16 | HE vers 11103-13_0001 (Bureau Med.) | 5d | 2028-08-17 | 2028-08-24 | 979 | 64d |  | Déménagement externe; Déménagement interne; Direction du laboratoire | 105h |
| 995 | 8.12.17 | HE vers 11103-13_0004 (Bureau Med.) | 5d | 2028-08-17 | 2028-08-24 | 979 | 64d |  | Déménagement externe; Déménagement interne; Direction du laboratoire | 105h |
| 996 | 8.13 | Emménagement Cytogénétique HE vers GM | 2d | 2028-08-24 | 2028-08-28 | 978 | 64d |  | Déménagement externe; Déménagement interne; Direction du laboratoire | 42h |

| ID | WBS | Task | Duration | Start | Finish | Predecessors | Total slack | Resources | Work |
| --- | --- | --- | --- | --- | --- | --- | --- | --- | --- |
| 998 | 9 | **Circulations RDC, 3e, 4e, 5e, 6e étage** | 56d | 2028-08-16 | 2028-11-03 |  | 0d |  | 462h |
| 999 | 9.1 | **partie 1** | 23d | 2028-08-16 | 2028-09-18 |  | 0d |  | 231h |
| 1000 | 9.1.1 | Pose faux-plafond | 10d | 2028-08-16 | 2028-08-30 | 977 | 13d | Lot 08 : Curage, démolitions, platrerie, peinture, faux-plafonds | 70h |
| 1001 | 9.1.2 | Pose des équipemes CFO | 10d | 2028-08-17 | 2028-08-31 | 977FS+1d | 0d | Lot 01 : Courants forts | 70h |
| 1002 | 9.1.3 | Pose des équipemes CFA | 1d | 2028-08-17 | 2028-08-18 | 977FS+1d | 9d | Lot 02 : Courants faibles | 7h |
| 1003 | 9.1.4 | Dépose sol | 3d | 2028-08-31 | 2028-09-05 | 1001, 1002 | 0d | Lot 08 : Curage, démolitions, platrerie, peinture, faux-plafonds | 21h |
| 1004 | 9.1.5 | Reprises de peinture | 3d | 2028-09-05 | 2028-09-08 | 1003 | 0d | Lot 08 : Curage, démolitions, platrerie, peinture, faux-plafonds | 21h |
| 1005 | 9.1.6 | Pose des protections murales | 1d | 2028-09-08 | 2028-09-11 | 1004 | 0d | Lot 07 : Sols souples, protections murales | 7h |
| 1006 | 9.1.7 | Pose sol | 5d | 2028-09-11 | 2028-09-18 | 1005 | 0d | Lot 07 : Sols souples, protections murales | 35h |
| 1007 | 9.2 | **partie 2** | 33d | 2028-09-18 | 2028-11-03 |  | 0d |  | 231h |
| 1008 | 9.2.1 | Pose faux-plafond | 10d | 2028-09-18 | 2028-10-02 | 999 | 0d | Lot 08 : Curage, démolitions, platrerie, peinture, faux-plafonds | 70h |
| 1009 | 9.2.2 | Pose des équipemes CFO | 10d | 2028-10-03 | 2028-10-17 | 1008FS+1d | 0d | Lot 01 : Courants forts | 70h |
| 1010 | 9.2.3 | Pose des équipemes CFA | 1d | 2028-10-03 | 2028-10-04 | 1008FS+1d | 9d | Lot 02 : Courants faibles | 7h |
| 1011 | 9.2.4 | Dépose sol | 3d | 2028-10-17 | 2028-10-20 | 1009, 1010 | 0d | Lot 08 : Curage, démolitions, platrerie, peinture, faux-plafonds | 21h |
| 1012 | 9.2.5 | Reprises de peinture | 3d | 2028-10-20 | 2028-10-25 | 1011 | 0d | Lot 08 : Curage, démolitions, platrerie, peinture, faux-plafonds | 21h |
| 1013 | 9.2.6 | Pose des protections murales | 1d | 2028-10-25 | 2028-10-26 | 1012 | 0d | Lot 07 : Sols souples, protections murales | 7h |
| 1014 | 9.2.7 | Pose sol | 5d | 2028-10-26 | 2028-11-03 | 1013 | 0d | Lot 07 : Sols souples, protections murales | 35h |
| 1016 | 10 | **Fin de chantier** | 557.5d | 2026-09-15 | 2028-11-27 |  | 0d |  | 196h |
| 1017 | 10.1 | Dépose lift | 3d | 2028-11-03 | 2028-11-08 | 998 | 0d | Lot 11 : Installations de chantier | 21h |
| 1018 | 10.2 | Repose BS et menuiserie extérieure | 2d | 2028-11-08 | 2028-11-10 | 1017 | 0d | Lot 09 : Menuiseries extérieures, cloisons vitrées, protections solaires | 14h |
| 1019 | 10.3 | Dépose Base vie et remise en état | 10d | 2028-11-10 | 2028-11-24 | 1018 | 0d | Lot 11 : Installations de chantier | 70h |
| 1020 | 10.4 | Réception finale | 1d | 2028-11-24 | 2028-11-27 | 1019 | 0d | Direction des Travaux, de l'Environnement et de la Sécurité; Direction du laboratoire; Lot 01 : Courants forts; Lot 02 : Courants faibles; Lot 03 : Chauffage, climatisation, ventilation, plomberie; Lot 04 : Fluides de laboratoire; Lot 05 : Portes automatiques; Lot 06 : Paillasses, matériel de laboratoire; Lot 07 : Sols souples, protections murales; Lot 08 : Curage, démolitions, platrerie, peinture, faux-plafonds; Lot 09 : Menuiseries extérieures, cloisons vitrées, protections solaires; Lot 10 : Cloisons et plafonds agroalimentaires; Lot 11 : Installations de chantier | 91h |
